# Ekushey Bhaban Master Plan3

Schedule from MS Project, 2010-03-26 to 2012-09-11, status date 2010-08-26, A marks actual dates.

## Calendars

- Standard: Mon-Fri 08:00-12:00, 13:00-17:00; Sat-Sun off. Exceptions (off unless hours are given): 2010-01-01 to 2010-09-08 08:00-12:00, 13:00-17:00 (City Scape), 2010-09-09 to 2010-09-15 (Eid-ul-Fitre), 2010-09-16 to 2010-11-18 08:00-12:00, 13:00-17:00 (Citiscape2), 2010-11-19 to 2010-11-26 (Eid-ul-Azha), 2010-11-27 to 2011-08-25 08:00-12:00, 13:00-17:00 (Cityscape3), 2011-08-26 to 2011-09-02 (Eid-ul-Fitre), 2011-09-03 to 2011-11-10 08:00-12:00, 13:00-17:00 (Cityscape4), 2011-11-11 to 2011-11-18 (Eid-ul-Azha), 2011-11-19 to 2012-08-16 08:00-12:00, 13:00-17:00 (Cityscape5).

## Schedule

| ID | WBS | Task | Duration | Start | Finish | Predecessors | Complete | Remaining | Total slack |
| --- | --- | --- | --- | --- | --- | --- | --- | --- | --- |
| 1 | 1 | **EKUSHEY BHABAN** | 862d | 2010-03-26 A | 2012-09-11 |  | 6% | 811.67d | 0d |
| 2 | 1.1 | **PRELIMINARIES** | 846d | 2010-03-26 A | 2012-08-20 |  | 32% | 571.97d | 16d |
| 3 | 1.1.1 | **MOBILIZATION-1-TEMPORARY OFFICE-SHED** | 22d | 2010-03-26 A | 2010-04-16 A |  | 100% |  |  |
| 4 | 1.1.1.1 | Mud Tank | 9d | 2010-03-26 A | 2010-04-03 A |  | 100% |  |  |
| 5 | 1.1.1.2 | Land Development | 4d | 2010-04-04 A | 2010-04-07 A | 4 | 100% |  |  |
| 6 | 1.1.1.3 | Office Shed | 4d | 2010-04-08 A | 2010-04-11 A | 5 | 100% |  |  |
| 7 | 1.1.1.4 | Labour Shed | 4d | 2010-04-08 A | 2010-04-11 A | 6SS | 100% |  |  |
| 8 | 1.1.1.5 | Cement Store | 4d | 2010-04-08 A | 2010-04-11 A | 6SS | 100% |  |  |
| 9 | 1.1.1.6 | Staff Residence | 4d | 2010-04-08 A | 2010-04-11 A | 6SS | 100% |  |  |
| 10 | 1.1.1.7 | Toilet | 7d | 2010-04-08 A | 2010-04-14 A | 6SS | 100% |  |  |
| 11 | 1.1.1.8 | Main Gate-1 | 7d | 2010-04-04 A | 2010-04-10 A | 4 | 100% |  |  |
| 12 | 1.1.1.9 | Electrical Wiring | 2d | 2010-04-15 A | 2010-04-16 A | 10 | 100% |  |  |
| 13 | 1.1.2 | **MOBILIZATION-2 -INFRASTRUCTURE** | 15d | 2010-08-11 A | 2010-08-25 |  | 89% | 1.59d | 701d |
| 14 | 1.1.2.1 | East Side Bed Preparation | 2d | 2010-08-11 A | 2010-08-12 A | 54FS-5d | 100% |  |  |
| 15 | 1.1.2.2 | Labour Shed & Kitchen Making | 9d | 2010-08-12 A | 2010-08-20 | 14FS-1d | 90% | 0.9d | 706d |
| 16 | 1.1.2.3 | South Side Bed Preparation | 3d | 2010-08-12 A | 2010-08-14 A | 14FS-1d | 100% |  |  |
| 17 | 1.1.2.4 | Cement Shed, Residence, Office & Toilet Making | 8d | 2010-08-13 A | 2010-08-20 | 16SS+1d | 85% | 1.2d | 706d |
| 18 | 1.1.2.5 | North Side Bed Preparation | 4d | 2010-08-22 A | 2010-08-25 A | 17FS+1d | 100% |  |  |
| 19 | 1.1.2.6 | Soling, CC for Woking Bed | 3d | 2010-08-23 A | 2010-08-25 A | 18FF | 100% |  |  |
| 20 | 1.1.2.7 | West Side Bed Preparation | 3d | 2010-08-15 A | 2010-08-17 A | 16 | 100% |  |  |
| 21 | 1.1.2.8 | Security Room Making | 7d | 2010-08-16 A | 2010-08-22 | 20FS-2d | 90% | 0.7d | 704d |
| 22 | 1.1.2.9 | Water Tank Tower Making & Shifting of Water Line From West to Est | 9d | 2010-08-12 A | 2010-08-20 A | 14SS+1d | 100% |  |  |
| 23 | 1.1.2.10 | Rain Water Drainage System (South) | 8d | 2010-08-13 A | 2010-08-20 A | 16SS+1d | 100% |  |  |
| 24 | 1.1.2.11 | Rain Water Drainage System (East) | 9d | 2010-08-12 A | 2010-08-20 A | 14FS-1d, 23FF | 100% |  |  |
| 25 | 1.1.2.12 | Water Reservoir Making (North) | 4d | 2010-08-22 A | 2010-08-25 A | 18FF | 100% |  |  |
| 26 | 1.1.2.13 | Generator Base Making | 8d | 2010-08-13 A | 2010-08-20 A | 23SS | 100% |  |  |
| 27 | 1.1.2.14 | Electrical Pipe Wiring | 6d | 2010-08-20 | 2010-08-25 | 26FS-1d |  |  | 726d |

| ID | WBS | Task | Duration | Start | Finish | Predecessors | Complete | Remaining | Total slack | Free slack | Constraint | Text1 |
| --- | --- | --- | --- | --- | --- | --- | --- | --- | --- | --- | --- | --- |
| 28 | 1.1.3 | **MOBILIZATION-3-GENERATOR & TOWER CRANE** | 33d | 2010-07-29 | 2010-08-30 |  |  |  | 699d |  |  |  |
| 29 | 1.1.3.1 | **Generator** | 33d | 2010-07-29 | 2010-08-30 |  |  |  | 699d |  |  |  |
| 30 | 1.1.3.1.1 | Supply | 30d | 2010-07-29 | 2010-08-27 | 31FF-3d |  |  | 724d |  |  |  |
| 31 | 1.1.3.1.2 | Installation | 3d | 2010-08-28 | 2010-08-30 | 26FS+7d |  |  | 721d | 0d |  |  |
| 32 | 1.1.4 | **PREPARTION FOR STRUCTURAL CONSTRUCTION** | 117d | 2010-08-21 | 2010-12-30 |  |  |  | 0d |  |  |  |
| 33 | 1.1.4.1 | Selection of Civil Contractor | 35d | 2010-08-21 | 2010-10-01 | 54 |  |  | 0d |  | finish no earlier than 2010-10-01 |  |
| 34 | 1.1.4.2 | Develop of Construction Method | 30d | 2010-09-02 | 2010-10-08 | 33FF+7d |  |  | 672d | 0d |  |  |
| 35 | 1.1.4.3 | Selection of Ready-mix Supplier | 7d | 2010-09-17 | 2010-09-23 | 34SS+8d |  |  | 687d |  |  |  |
| 36 | 1.1.4.4 | Structural Design Vetting From BUET | 45d | 2010-08-25 | 2010-10-15 |  |  |  | 11d | 0d | start no earlier than 2010-08-25 |  |
| 37 | 1.1.4.5 | Drill Work for Safety | 2d | 2010-11-30 | 2010-12-01 | 63FF |  |  | 626d |  |  |  |
| 38 | 1.1.4.6 | Selection & Agreement With Clinic for Medical Service | 7d | 2010-10-09 | 2010-10-15 | 36FF |  |  | 660d |  |  |  |
| 39 | 1.1.4.7 | Design Collection & Estimation of Structural Cost | 20d | 2010-11-04 | 2010-12-01 | 63FF |  |  | 626d |  |  |  |
| 40 | 1.1.4.8 | Selection of MEP Contractor | 10d | 2010-12-21 | 2010-12-30 | 74FF-15d |  |  | 597d |  |  |  |
| 41 | 1.1.5 | **MOBILIZATION-4-TOWER CRANE** | 32d | 2011-09-23 | 2011-10-24 |  |  |  | 307d |  |  |  |
| 42 | 1.1.5.1 | Selection | 15d | 2011-09-23 | 2011-10-08 | 43SF |  |  | 324d |  |  |  |
| 43 | 1.1.5.2 | Foundation | 3d | 2011-10-08 | 2011-10-11 | 44SF-7d |  |  | 321d | 0d |  |  |
| 44 | 1.1.5.3 | Installation | 7d | 2011-10-18 | 2011-10-24 | 523 |  |  | 307d | 0d |  |  |
| 45 | 1.1.6 | **MOBILIZATION-5-LIFTING HOIST** | 7d | 2012-05-17 | 2012-05-23 |  |  |  | 103d |  |  |  |
| 46 | 1.1.6.1 | Lifting Hoist Installation | 7d | 2012-05-17 | 2012-05-23 | 905 |  |  | 103d |  |  |  |
| 47 | 1.1.7 | **DEMOBILIZATION** | 78d | 2012-06-02 | 2012-08-20 |  |  |  | 0d |  |  |  |
| 48 | 1.1.7.1 | Dismantling Tower Crane | 2d | 2012-06-02 | 2012-06-03 | 896 |  |  | 9d | 0d |  |  |
| 49 | 1.1.7.2 | Dismatle Lifting Hoist | 2d | 2012-08-02 | 2012-08-03 | 907 |  |  | 0d |  |  |  |
| 50 | 1.1.7.3 | Dismantling Infrastructure | 15d | 2012-08-04 | 2012-08-20 | 49 |  |  | 0d |  |  |  |
| 51 | 1.2 | **SUB-STRUCTURE** | 375d | 2010-04-18 A | 2011-05-12 |  | 22% | 291.28d | 464d |  |  |  |
| 52 | 1.2.1 | **PART-1** | 120d | 2010-04-18 A | 2010-08-15 A |  | 100% |  |  |  |  |  |
| 53 | 1.2.1.1 | SHORE PILING (50 ft) | 100d | 2010-04-18 A | 2010-07-26 A | 3FS+1d | 100% |  |  |  |  | Nos. |

| ID | WBS | Task | Duration | Start | Finish | Predecessors | Complete | Total slack | Free slack | Text1 |
| --- | --- | --- | --- | --- | --- | --- | --- | --- | --- | --- |
| 54 | 1.2.1.2 | **PERIMETER BEAM** | 20d | 2010-07-27 A | 2010-08-15 A |  | 100% |  |  | ft |
| 55 | 1.2.1.2.1 | Excavation for PileHead Breaking | 15d | 2010-07-27 A | 2010-08-10 A | 53 | 100% |  |  |  |
| 56 | 1.2.1.2.2 | Pile Head Breaking | 15d | 2010-07-29 A | 2010-08-12 A | 55SS+2d | 100% |  |  |  |
| 57 | 1.2.1.2.3 | Re bar Work & Concreting | 16d | 2010-07-31 A | 2010-08-15 A | 56SS+2d | 100% |  |  |  |
| 58 | 1.2.2 | **PART-2** | 215d | 2010-10-02 | 2011-05-12 |  |  | 0d |  |  |
| 59 | 1.2.2.1 | **EXCAVATION** | 83d | 2010-10-02 | 2010-12-31 |  |  | 0d |  |  |
| 60 | 1.2.2.1.1 | Mobilization-1 (Equipment) | 5d | 2010-10-02 | 2010-10-06 | 33 |  | 0d |  |  |
| 61 | 1.2.2.1.2 | Mobilization-2(Bracing) | 15d | 2010-10-02 | 2010-10-16 | 60SS |  | 68d |  |  |
| 62 | 1.2.2.1.3 | Excavation-Part-1 | 18d | 2010-10-04 | 2010-10-21 | 60SS+2d |  | 0d |  |  |
| 63 | 1.2.2.1.4 | Bracing | 34d | 2010-10-21 | 2010-12-01 | 62FS-1d |  | 0d |  |  |
| 64 | 1.2.2.1.5 | Excvation- Part-2 | 59d | 2010-10-26 | 2010-12-31 | 63SS+5d, 36FS-6d |  | 0d |  |  |
| 65 | 1.2.2.2 | **Mat Foundation** | 45d | 2010-12-25 | 2011-02-07 |  |  | 0d |  |  |
| 66 | 1.2.2.2.1 | **Part-1** | 23d | 2010-12-25 | 2011-01-16 |  |  | 0d |  |  |
| 67 | 1.2.2.2.1.1 | Bed Preparation | 7d | 2010-12-25 | 2010-12-31 | 59FS-7d |  | 0d |  | sft |
| 68 | 1.2.2.2.1.2 | 2-Layer Polythene | 1d | 2011-01-01 | 2011-01-01 | 67 |  | 22d | 0d | sft |
| 69 | 1.2.2.2.1.3 | Lean Concrete | 1d | 2011-01-02 | 2011-01-02 | 68 |  | 22d | 0d | cft |
| 70 | 1.2.2.2.1.4 | Peripherial Brick Work | 1d | 2011-01-03 | 2011-01-03 | 69 |  | 22d | 0d |  |
| 71 | 1.2.2.2.1.5 | Plaster | 1d | 2011-01-04 | 2011-01-04 | 70 |  | 22d | 0d |  |
| 72 | 1.2.2.2.1.6 | Water Proofing | 2d | 2011-01-08 | 2011-01-09 | 71FS+3d |  | 22d | 0d |  |
| 73 | 1.2.2.2.1.7 | Re-Bar Fabrication | 4d | 2011-01-10 | 2011-01-13 | 72 |  | 22d | 0d | ton |
| 74 | 1.2.2.2.1.8 | MEP Works | 1d | 2011-01-14 | 2011-01-14 | 73 |  | 22d | 0d |  |
| 75 | 1.2.2.2.1.9 | Inspection | 1d | 2011-01-15 | 2011-01-15 | 74, 73 |  | 22d | 0d |  |
| 76 | 1.2.2.2.1.10 | Concreteing | 1d | 2011-01-16 | 2011-01-16 | 75 |  | 22d |  | cft |
| 77 | 1.2.2.2.2 | **Part-2** | 24d | 2011-01-01 | 2011-01-24 |  |  | 0d |  |  |
| 78 | 1.2.2.2.2.1 | Bed Preparation | 8d | 2011-01-01 | 2011-01-08 | 67 |  | 0d |  | sft |
| 79 | 1.2.2.2.2.2 | 2-Layer Polythene | 1d | 2011-01-09 | 2011-01-09 | 78 |  | 14d | 0d | sft |
| 80 | 1.2.2.2.2.3 | Lean Concrete | 1d | 2011-01-10 | 2011-01-10 | 79 |  | 14d | 0d | cft |
| 81 | 1.2.2.2.2.4 | Peripherial Brick Work | 1d | 2011-01-11 | 2011-01-11 | 80 |  | 14d | 0d |  |
| 82 | 1.2.2.2.2.5 | Plaster | 1d | 2011-01-12 | 2011-01-12 | 81 |  | 14d | 0d |  |
| 83 | 1.2.2.2.2.6 | Water Proofing | 2d | 2011-01-16 | 2011-01-17 | 82FS+3d |  | 14d | 0d |  |
| 84 | 1.2.2.2.2.7 | Re-Bar Fabrication | 4d | 2011-01-18 | 2011-01-21 | 83 |  | 14d | 0d | ton |
| 85 | 1.2.2.2.2.8 | MEP Works | 1d | 2011-01-22 | 2011-01-22 | 84 |  | 14d | 0d |  |
| 86 | 1.2.2.2.2.9 | Inspection | 1d | 2011-01-23 | 2011-01-23 | 84, 85 |  | 14d | 0d |  |
| 87 | 1.2.2.2.2.10 | Concreteing | 1d | 2011-01-24 | 2011-01-24 | 86 |  | 14d |  | cft |

| ID | WBS | Task | Duration | Start | Finish | Predecessors | Total slack | Free slack | Text1 |
| --- | --- | --- | --- | --- | --- | --- | --- | --- | --- |
| 88 | 1.2.2.2.3 | **Part-3** | 23d | 2011-01-09 | 2011-01-31 |  | 0d |  |  |
| 89 | 1.2.2.2.3.1 | Bed Preparation | 7d | 2011-01-09 | 2011-01-15 | 78 | 0d |  | sft |
| 90 | 1.2.2.2.3.2 | 2-Layer Polythene | 1d | 2011-01-16 | 2011-01-16 | 89 | 7d | 0d | sft |
| 91 | 1.2.2.2.3.3 | Lean Concrete | 1d | 2011-01-17 | 2011-01-17 | 90 | 7d | 0d | cft |
| 92 | 1.2.2.2.3.4 | Peripherial Brick Work | 1d | 2011-01-18 | 2011-01-18 | 91 | 7d | 0d |  |
| 93 | 1.2.2.2.3.5 | Plaster | 1d | 2011-01-19 | 2011-01-19 | 92 | 7d | 0d |  |
| 94 | 1.2.2.2.3.6 | Water Proofing | 2d | 2011-01-23 | 2011-01-24 | 93FS+3d | 7d | 0d |  |
| 95 | 1.2.2.2.3.7 | Re-Bar Fabrication | 4d | 2011-01-25 | 2011-01-28 | 94 | 7d | 0d | ton |
| 96 | 1.2.2.2.3.8 | MEP Works | 1d | 2011-01-29 | 2011-01-29 | 95 | 7d | 0d |  |
| 97 | 1.2.2.2.3.9 | Inspection | 1d | 2011-01-30 | 2011-01-30 | 95, 96 | 7d | 0d |  |
| 98 | 1.2.2.2.3.10 | Concreteing | 1d | 2011-01-31 | 2011-01-31 | 97 | 7d |  | cft |
| 99 | 1.2.2.2.4 | **Part-4** | 23d | 2011-01-16 | 2011-02-07 |  | 0d |  |  |
| 100 | 1.2.2.2.4.1 | Bed Preparation | 7d | 2011-01-16 | 2011-01-22 | 89 | 0d |  | sft |
| 101 | 1.2.2.2.4.2 | 2-Layer Polythene | 1d | 2011-01-23 | 2011-01-23 | 100 | 0d |  | sft |
| 102 | 1.2.2.2.4.3 | Lean Concrete | 1d | 2011-01-24 | 2011-01-24 | 101 | 0d |  | cft |
| 103 | 1.2.2.2.4.4 | Peripherial Brick Work | 1d | 2011-01-25 | 2011-01-25 | 102 | 0d |  |  |
| 104 | 1.2.2.2.4.5 | Plaster | 1d | 2011-01-26 | 2011-01-26 | 103 | 0d |  |  |
| 105 | 1.2.2.2.4.6 | Water Proofing | 2d | 2011-01-30 | 2011-01-31 | 104FS+3d | 0d |  |  |
| 106 | 1.2.2.2.4.7 | Re-Bar Fabrication | 4d | 2011-02-01 | 2011-02-04 | 105 | 0d |  | ton |
| 107 | 1.2.2.2.4.8 | MEP Works | 1d | 2011-02-05 | 2011-02-05 | 106 | 0d |  |  |
| 108 | 1.2.2.2.4.9 | Inspection | 1d | 2011-02-06 | 2011-02-06 | 106, 107 | 0d |  |  |
| 109 | 1.2.2.2.4.10 | Concreteing | 1d | 2011-02-07 | 2011-02-07 | 108 | 0d |  | cft |
| 110 | 1.2.2.3 | **BASEMENT-3** | 45d | 2011-02-08 | 2011-03-24 |  | 0d |  |  |
| 111 | 1.2.2.3.1 | **PART-1** | 24d | 2011-02-08 | 2011-03-03 |  | 0d |  |  |
| 112 | 1.2.2.3.1.1 | **Retaining Wall** | 16d | 2011-02-08 | 2011-02-23 |  | 0d |  | rft |
| 113 | 1.2.2.3.1.1.1 | Brick Wall | 2d | 2011-02-08 | 2011-02-09 | 65 | 0d |  | sft |
| 114 | 1.2.2.3.1.1.2 | Plaster | 1d | 2011-02-10 | 2011-02-10 | 113 | 0d |  | sft |
| 115 | 1.2.2.3.1.1.3 | Water Proofing | 1d | 2011-02-17 | 2011-02-17 | 114FF+7d | 0d |  | sft |
| 116 | 1.2.2.3.1.1.4 | Re-bar Work | 3d | 2011-02-18 | 2011-02-20 | 115 | 0d |  | ton |
| 117 | 1.2.2.3.1.1.5 | Form Work | 2d | 2011-02-20 | 2011-02-21 | 116FF+1d | 0d |  | sft |
| 118 | 1.2.2.3.1.1.6 | Conreting | 1d | 2011-02-22 | 2011-02-22 | 117FF+1d | 0d |  | cft |
| 119 | 1.2.2.3.1.1.7 | De-shuttering | 1d | 2011-02-23 | 2011-02-23 | 118FF+1d | 0d |  |  |

| ID | WBS | Task | Duration | Start | Finish | Predecessors | Total slack | Free slack | Text1 |
| --- | --- | --- | --- | --- | --- | --- | --- | --- | --- |
| 120 | 1.2.2.3.1.2 | **Water Reservoir** | 10d | 2011-02-08 | 2011-02-17 |  | 548d |  |  |
| 121 | 1.2.2.3.1.2.1 | **Vertical Wall** | 6d | 2011-02-08 | 2011-02-13 |  | 548d |  | ft |
| 122 | 1.2.2.3.1.2.1.1 | Re-bar Work | 3d | 2011-02-08 | 2011-02-10 | 65 | 548d | 0d | ton |
| 123 | 1.2.2.3.1.2.1.2 | Form Work | 3d | 2011-02-09 | 2011-02-11 | 122FF+1d | 548d | 0d | sft |
| 124 | 1.2.2.3.1.2.1.3 | Concrete | 2d | 2011-02-11 | 2011-02-12 | 123FF+1d | 548d | 0d | cft |
| 125 | 1.2.2.3.1.2.1.4 | De Shuttering | 2d | 2011-02-12 | 2011-02-13 | 124FF+1d | 552d |  |  |
| 126 | 1.2.2.3.1.2.2 | **Top Slab** | 5d | 2011-02-13 | 2011-02-17 |  | 548d |  |  |
| 127 | 1.2.2.3.1.2.2.1 | Form Work | 3d | 2011-02-13 | 2011-02-15 | 124 | 548d | 0d |  |
| 128 | 1.2.2.3.1.2.2.2 | Re-bar Work | 3d | 2011-02-14 | 2011-02-16 | 127FF+1d | 548d | 0d |  |
| 129 | 1.2.2.3.1.2.2.3 | Concrete | 1d | 2011-02-17 | 2011-02-17 | 128FF+1d | 548d |  |  |
| 130 | 1.2.2.3.1.3 | **Column** | 8d | 2011-02-08 | 2011-02-15 |  | 8d |  | nos. |
| 131 | 1.2.2.3.1.3.1 | Re-Bar Work | 2d | 2011-02-08 | 2011-02-09 | 65 | 8d | 0d |  |
| 132 | 1.2.2.3.1.3.2 | Form Work | 2d | 2011-02-10 | 2011-02-11 | 131 | 8d | 0d |  |
| 133 | 1.2.2.3.1.3.3 | Concrete | 2d | 2011-02-12 | 2011-02-13 | 132 | 8d | 0d |  |
| 134 | 1.2.2.3.1.3.4 | De-shuttering | 2d | 2011-02-14 | 2011-02-15 | 133 | 8d |  |  |
| 135 | 1.2.2.3.1.4 | **Shear Wall** | 12d | 2011-02-08 | 2011-02-19 |  | 4d |  | nos. |
| 136 | 1.2.2.3.1.4.1 | Re-Bar Work | 3d | 2011-02-08 | 2011-02-10 | 65 | 4d | 0d |  |
| 137 | 1.2.2.3.1.4.2 | Form Work | 3d | 2011-02-11 | 2011-02-13 | 136 | 4d | 0d |  |
| 138 | 1.2.2.3.1.4.3 | Concrete | 3d | 2011-02-14 | 2011-02-16 | 137 | 4d | 0d |  |
| 139 | 1.2.2.3.1.4.4 | De-shuttering | 3d | 2011-02-17 | 2011-02-19 | 138 | 4d |  |  |
| 140 | 1.2.2.3.1.5 | **Stair - 1** | 4d | 2011-02-08 | 2011-02-11 |  | 399d |  |  |
| 141 | 1.2.2.3.1.5.1 | **1st Flight** | 4d | 2011-02-08 | 2011-02-11 |  | 399d |  |  |
| 142 | 1.2.2.3.1.5.1.1 | Brick Work | 1d | 2011-02-08 | 2011-02-08 | 65 | 399d | 0d |  |
| 143 | 1.2.2.3.1.5.1.2 | Form Work | 1d | 2011-02-09 | 2011-02-09 | 142 | 399d | 0d |  |
| 144 | 1.2.2.3.1.5.1.3 | Re-bar Work | 1d | 2011-02-10 | 2011-02-10 | 143 | 399d | 0d |  |
| 145 | 1.2.2.3.1.5.1.4 | Concrete | 1d | 2011-02-11 | 2011-02-11 | 144 | 399d | 20d |  |

| ID | WBS | Task | Duration | Start | Finish | Predecessors | Total slack | Free slack | Text1 |
| --- | --- | --- | --- | --- | --- | --- | --- | --- | --- |
| 146 | 1.2.2.3.1.6 | **Ramp** | 2d | 2011-02-26 | 2011-02-27 |  | 538d |  |  |
| 147 | 1.2.2.3.1.6.1 | Form Work | 1d | 2011-02-26 | 2011-02-26 | 150FF | 538d | 0d |  |
| 148 | 1.2.2.3.1.6.2 | Re-Bar | 1d | 2011-02-27 | 2011-02-27 | 147 | 538d |  |  |
| 149 | 1.2.2.3.1.7 | **Roof Slab** | 8d | 2011-02-24 | 2011-03-03 |  | 0d |  |  |
| 150 | 1.2.2.3.1.7.1 | Form Work | 3d | 2011-02-24 | 2011-02-26 | 135, 130, 119 | 0d |  |  |
| 151 | 1.2.2.3.1.7.2 | Re-bar | 3d | 2011-02-26 | 2011-02-28 | 150FF+2d | 0d |  |  |
| 152 | 1.2.2.3.1.7.3 | MEP Work | 1d | 2011-03-01 | 2011-03-01 | 151 | 0d |  |  |
| 153 | 1.2.2.3.1.7.4 | Inspection | 1d | 2011-03-02 | 2011-03-02 | 152 | 0d |  |  |
| 154 | 1.2.2.3.1.7.5 | Concrete | 1d | 2011-03-03 | 2011-03-03 | 153 | 0d |  |  |
| 155 | 1.2.2.3.2 | **PART-2** | 21d | 2011-03-04 | 2011-03-24 | 154 | 368d |  |  |
| 156 | 1.2.2.3.2.1 | **Retaining Wall** | 14d | 2011-03-04 | 2011-03-17 |  | 368d | 0d | rft |
| 157 | 1.2.2.3.2.1.1 | Brick Wall | 2d | 2011-03-04 | 2011-03-05 | 154FF+1d | 368d | 0d | sft |
| 158 | 1.2.2.3.2.1.2 | Plaster | 2d | 2011-03-05 | 2011-03-06 | 157FF+1d | 368d | 0d | sft |
| 159 | 1.2.2.3.2.1.3 | Water Proofing | 2d | 2011-03-12 | 2011-03-13 | 158FF+7d | 368d | 0d | sft |
| 160 | 1.2.2.3.2.1.4 | Re-bar Work | 2d | 2011-03-13 | 2011-03-14 | 159FF+1d | 368d | 0d | ton |
| 161 | 1.2.2.3.2.1.5 | Form Work | 2d | 2011-03-14 | 2011-03-15 | 160FF+1d | 368d | 0d | sft |
| 162 | 1.2.2.3.2.1.6 | Conreting | 2d | 2011-03-15 | 2011-03-16 | 161FF+1d | 368d | 0d | cft |
| 163 | 1.2.2.3.2.1.7 | De-shuttering | 2d | 2011-03-16 | 2011-03-17 | 162FF+1d | 368d |  |  |
| 164 | 1.2.2.3.2.2 | **Column** | 5d | 2011-03-04 | 2011-03-08 |  | 377d | 9d | nos. |
| 165 | 1.2.2.3.2.2.1 | Re-Bar Work | 2d | 2011-03-04 | 2011-03-05 | 154FF+1d | 377d | 0d |  |
| 166 | 1.2.2.3.2.2.2 | Form Work | 2d | 2011-03-05 | 2011-03-06 | 165FF+1d | 377d | 0d |  |
| 167 | 1.2.2.3.2.2.3 | Concrete | 2d | 2011-03-06 | 2011-03-07 | 166FF+1d | 377d | 0d |  |
| 168 | 1.2.2.3.2.2.4 | De-shuttering | 2d | 2011-03-07 | 2011-03-08 | 167FF+1d | 377d |  |  |
| 169 | 1.2.2.3.2.3 | **Shear Wall** | 6d | 2011-03-04 | 2011-03-09 |  | 376d | 8d | nos. |
| 170 | 1.2.2.3.2.3.1 | Re-Bar Work | 3d | 2011-03-04 | 2011-03-06 | 154FF+1d | 376d | 0d |  |
| 171 | 1.2.2.3.2.3.2 | Form Work | 3d | 2011-03-05 | 2011-03-07 | 170FF+1d | 376d | 0d |  |
| 172 | 1.2.2.3.2.3.3 | Concrete | 3d | 2011-03-06 | 2011-03-08 | 171FF+1d | 376d | 0d |  |
| 173 | 1.2.2.3.2.3.4 | De-shuttering | 3d | 2011-03-07 | 2011-03-09 | 172FF+1d | 376d |  |  |

| ID | WBS | Task | Duration | Start | Finish | Predecessors | Total slack | Free slack | Text1 |
| --- | --- | --- | --- | --- | --- | --- | --- | --- | --- |
| 174 | 1.2.2.3.2.4 | **Stair - 1** | 3d | 2011-03-04 | 2011-03-06 |  | 379d | 11d |  |
| 175 | 1.2.2.3.2.4.1 | **2nd Flight** | 3d | 2011-03-04 | 2011-03-06 |  | 379d |  |  |
| 176 | 1.2.2.3.2.4.1.1 | Brick Work | 1d | 2011-03-04 | 2011-03-04 | 145 | 379d | 0d |  |
| 177 | 1.2.2.3.2.4.1.2 | Form Work | 1d | 2011-03-05 | 2011-03-05 | 176FF+1d | 379d | 0d |  |
| 178 | 1.2.2.3.2.4.1.3 | Re-bar Work | 1d | 2011-03-06 | 2011-03-06 | 177FF+1d | 379d |  |  |
| 179 | 1.2.2.3.2.5 | **Ramp** | 3d | 2011-03-04 | 2011-03-06 |  | 531d |  |  |
| 180 | 1.2.2.3.2.5.1 | Form Work | 1d | 2011-03-04 | 2011-03-04 | 154FF+1d | 531d | 0d |  |
| 181 | 1.2.2.3.2.5.2 | Re-Bar | 1d | 2011-03-05 | 2011-03-05 | 180FF+1d | 531d | 0d |  |
| 182 | 1.2.2.3.2.5.3 | Concrete | 1d | 2011-03-06 | 2011-03-06 | 181FF+1d | 531d |  |  |
| 183 | 1.2.2.3.2.6 | **Roof Slab** | 7d | 2011-03-18 | 2011-03-24 |  | 368d |  |  |
| 184 | 1.2.2.3.2.6.1 | Form Work | 2d | 2011-03-18 | 2011-03-19 | 156, 164, 169, 174 | 368d | 0d |  |
| 185 | 1.2.2.3.2.6.2 | Re-bar | 2d | 2011-03-20 | 2011-03-21 | 184FF+2d | 368d | 0d |  |
| 186 | 1.2.2.3.2.6.3 | MEP Work | 1d | 2011-03-22 | 2011-03-22 | 185 | 368d | 0d |  |
| 187 | 1.2.2.3.2.6.4 | Inspection | 1d | 2011-03-23 | 2011-03-23 | 186 | 368d | 0d |  |
| 188 | 1.2.2.3.2.6.5 | Concrete | 1d | 2011-03-24 | 2011-03-24 | 187 | 368d | 0d |  |
| 189 | 1.2.2.4 | **BASEMENT-2** | 45d | 2011-03-04 | 2011-04-17 |  | 0d |  |  |
| 190 | 1.2.2.4.1 | **PART-1** | 25d | 2011-03-04 | 2011-03-28 |  | 0d |  |  |
| 191 | 1.2.2.4.1.1 | **Retaining Wall** | 18d | 2011-03-04 | 2011-03-21 |  | 0d |  | rft |
| 192 | 1.2.2.4.1.1.1 | Brick Wall | 3d | 2011-03-04 | 2011-03-06 | 154 | 0d |  | sft |
| 193 | 1.2.2.4.1.1.2 | Plaster | 2d | 2011-03-07 | 2011-03-08 | 192 | 0d |  | sft |
| 194 | 1.2.2.4.1.1.3 | Water Proofing | 1d | 2011-03-15 | 2011-03-15 | 193FF+7d | 0d |  | sft |
| 195 | 1.2.2.4.1.1.4 | Re-bar Work | 3d | 2011-03-16 | 2011-03-18 | 194 | 0d |  | ton |
| 196 | 1.2.2.4.1.1.5 | Form Work | 2d | 2011-03-18 | 2011-03-19 | 195FF+1d | 0d |  | sft |
| 197 | 1.2.2.4.1.1.6 | Conreting | 1d | 2011-03-20 | 2011-03-20 | 196FF+1d | 0d |  | cft |
| 198 | 1.2.2.4.1.1.7 | De-shuttering | 1d | 2011-03-21 | 2011-03-21 | 197FF+1d | 0d |  |  |

| ID | WBS | Task | Duration | Start | Finish | Predecessors | Total slack | Free slack | Text1 |
| --- | --- | --- | --- | --- | --- | --- | --- | --- | --- |
| 199 | 1.2.2.4.1.2 | **Column** | 8d | 2011-03-04 | 2011-03-11 |  | 10d |  | nos. |
| 200 | 1.2.2.4.1.2.1 | Re-Bar Work | 2d | 2011-03-04 | 2011-03-05 | 154 | 10d | 0d |  |
| 201 | 1.2.2.4.1.2.2 | Form Work | 2d | 2011-03-06 | 2011-03-07 | 200 | 10d | 0d |  |
| 202 | 1.2.2.4.1.2.3 | Concrete | 2d | 2011-03-08 | 2011-03-09 | 201 | 10d | 0d |  |
| 203 | 1.2.2.4.1.2.4 | De-shuttering | 2d | 2011-03-10 | 2011-03-11 | 202 | 10d |  |  |
| 204 | 1.2.2.4.1.3 | **Shear Wall** | 12d | 2011-03-04 | 2011-03-15 |  | 6d |  | nos. |
| 205 | 1.2.2.4.1.3.1 | Re-Bar Work | 3d | 2011-03-04 | 2011-03-06 | 154 | 6d | 0d |  |
| 206 | 1.2.2.4.1.3.2 | Form Work | 3d | 2011-03-07 | 2011-03-09 | 205 | 6d | 0d |  |
| 207 | 1.2.2.4.1.3.3 | Concrete | 3d | 2011-03-10 | 2011-03-12 | 206 | 6d | 0d |  |
| 208 | 1.2.2.4.1.3.4 | De-shuttering | 3d | 2011-03-13 | 2011-03-15 | 207 | 6d |  |  |
| 209 | 1.2.2.4.1.4 | **Stair - 1** | 4d | 2011-03-25 | 2011-03-28 |  | 368d |  |  |
| 210 | 1.2.2.4.1.4.1 | **1st Flight** | 4d | 2011-03-25 | 2011-03-28 |  | 368d |  |  |
| 211 | 1.2.2.4.1.4.1.1 | Brick Work | 1d | 2011-03-25 | 2011-03-25 | 188 | 368d | 0d |  |
| 212 | 1.2.2.4.1.4.1.2 | Form Work | 1d | 2011-03-26 | 2011-03-26 | 211 | 368d | 0d |  |
| 213 | 1.2.2.4.1.4.1.3 | Re-bar Work | 1d | 2011-03-27 | 2011-03-27 | 212 | 368d | 0d |  |
| 214 | 1.2.2.4.1.4.1.4 | Concrete | 1d | 2011-03-28 | 2011-03-28 | 213 | 368d | 0d |  |
| 215 | 1.2.2.4.1.5 | **Ramp** | 2d | 2011-03-23 | 2011-03-24 |  | 513d |  |  |
| 216 | 1.2.2.4.1.5.1 | Form Work | 1d | 2011-03-23 | 2011-03-23 | 219FF | 513d | 0d |  |
| 217 | 1.2.2.4.1.5.2 | Re-Bar | 1d | 2011-03-24 | 2011-03-24 | 216 | 513d |  |  |
| 218 | 1.2.2.4.1.6 | **Roof Slab** | 7d | 2011-03-22 | 2011-03-28 |  | 0d |  |  |
| 219 | 1.2.2.4.1.6.1 | Form Work | 2d | 2011-03-22 | 2011-03-23 | 198, 199, 204 | 0d |  |  |
| 220 | 1.2.2.4.1.6.2 | Re-bar | 2d | 2011-03-24 | 2011-03-25 | 219FF+2d | 0d |  |  |
| 221 | 1.2.2.4.1.6.3 | MEP Work | 1d | 2011-03-26 | 2011-03-26 | 220 | 0d |  |  |
| 222 | 1.2.2.4.1.6.4 | Inspection | 1d | 2011-03-27 | 2011-03-27 | 221 | 0d |  |  |
| 223 | 1.2.2.4.1.6.5 | Concrete | 1d | 2011-03-28 | 2011-03-28 | 222 | 0d |  |  |

| ID | WBS | Task | Duration | Start | Finish | Predecessors | Total slack | Free slack | Text1 |
| --- | --- | --- | --- | --- | --- | --- | --- | --- | --- |
| 224 | 1.2.2.4.2 | **PART-2** | 22d | 2011-03-27 | 2011-04-17 |  | 359d |  |  |
| 225 | 1.2.2.4.2.1 | **Retaining Wall** | 14d | 2011-03-28 | 2011-04-10 |  | 358d | 0d | rft |
| 226 | 1.2.2.4.2.1.1 | Brick Wall | 2d | 2011-03-28 | 2011-03-29 | 223FF+1d | 358d | 0d | sft |
| 227 | 1.2.2.4.2.1.2 | Plaster | 2d | 2011-03-29 | 2011-03-30 | 226FF+1d | 358d | 0d | sft |
| 228 | 1.2.2.4.2.1.3 | Water Proofing | 2d | 2011-04-05 | 2011-04-06 | 227FF+7d | 358d | 0d | sft |
| 229 | 1.2.2.4.2.1.4 | Re-bar Work | 2d | 2011-04-06 | 2011-04-07 | 228FF+1d | 358d | 0d | ton |
| 230 | 1.2.2.4.2.1.5 | Form Work | 2d | 2011-04-07 | 2011-04-08 | 229FF+1d | 358d | 0d | sft |
| 231 | 1.2.2.4.2.1.6 | Conreting | 2d | 2011-04-08 | 2011-04-09 | 230FF+1d | 358d | 0d | cft |
| 232 | 1.2.2.4.2.1.7 | De-shuttering | 2d | 2011-04-09 | 2011-04-10 | 231FF+1d | 358d |  |  |
| 233 | 1.2.2.4.2.2 | **Column** | 5d | 2011-03-28 | 2011-04-01 |  | 367d | 9d | nos. |
| 234 | 1.2.2.4.2.2.1 | Re-Bar Work | 2d | 2011-03-28 | 2011-03-29 | 223FF+1d | 367d | 0d |  |
| 235 | 1.2.2.4.2.2.2 | Form Work | 2d | 2011-03-29 | 2011-03-30 | 234FF+1d | 367d | 0d |  |
| 236 | 1.2.2.4.2.2.3 | Concrete | 2d | 2011-03-30 | 2011-03-31 | 235FF+1d | 367d | 0d |  |
| 237 | 1.2.2.4.2.2.4 | De-shuttering | 2d | 2011-03-31 | 2011-04-01 | 236FF+1d | 367d |  |  |
| 238 | 1.2.2.4.2.3 | **Shear Wall** | 6d | 2011-03-27 | 2011-04-01 |  | 367d | 9d | nos. |
| 239 | 1.2.2.4.2.3.1 | Re-Bar Work | 3d | 2011-03-27 | 2011-03-29 | 223FF+1d | 367d | 0d |  |
| 240 | 1.2.2.4.2.3.2 | Form Work | 3d | 2011-03-28 | 2011-03-30 | 239FF+1d | 367d | 0d |  |
| 241 | 1.2.2.4.2.3.3 | Concrete | 3d | 2011-03-29 | 2011-03-31 | 240FF+1d | 367d | 0d |  |
| 242 | 1.2.2.4.2.3.4 | De-shuttering | 3d | 2011-03-30 | 2011-04-01 | 241FF+1d | 367d |  |  |
| 243 | 1.2.2.4.2.4 | **Stair - 1** | 3d | 2011-03-29 | 2011-03-31 |  | 368d | 10d |  |
| 244 | 1.2.2.4.2.4.1 | **2nd Flight** | 3d | 2011-03-29 | 2011-03-31 |  | 368d |  |  |
| 245 | 1.2.2.4.2.4.1.1 | Brick Work | 1d | 2011-03-29 | 2011-03-29 | 214 | 368d | 0d |  |
| 246 | 1.2.2.4.2.4.1.2 | Form Work | 1d | 2011-03-30 | 2011-03-30 | 245FF+1d | 368d | 0d |  |
| 247 | 1.2.2.4.2.4.1.3 | Re-bar Work | 1d | 2011-03-31 | 2011-03-31 | 246FF+1d | 368d |  |  |

| ID | WBS | Task | Duration | Start | Finish | Predecessors | Total slack | Free slack | Text1 |
| --- | --- | --- | --- | --- | --- | --- | --- | --- | --- |
| 248 | 1.2.2.4.2.5 | **Ramp** | 3d | 2011-03-29 | 2011-03-31 |  | 506d |  |  |
| 249 | 1.2.2.4.2.5.1 | Form Work | 1d | 2011-03-29 | 2011-03-29 | 223FF+1d | 506d | 0d |  |
| 250 | 1.2.2.4.2.5.2 | Re-Bar | 1d | 2011-03-30 | 2011-03-30 | 249FF+1d | 506d | 0d |  |
| 251 | 1.2.2.4.2.5.3 | Concrete | 1d | 2011-03-31 | 2011-03-31 | 250FF+1d | 506d |  |  |
| 252 | 1.2.2.4.2.6 | **Roof Slab** | 7d | 2011-04-11 | 2011-04-17 |  | 358d |  |  |
| 253 | 1.2.2.4.2.6.1 | Form Work | 2d | 2011-04-11 | 2011-04-12 | 225, 233, 238, 243 | 358d | 0d |  |
| 254 | 1.2.2.4.2.6.2 | Re-bar | 2d | 2011-04-13 | 2011-04-14 | 253FF+2d | 358d | 0d |  |
| 255 | 1.2.2.4.2.6.3 | MEP Work | 1d | 2011-04-15 | 2011-04-15 | 254 | 358d | 0d |  |
| 256 | 1.2.2.4.2.6.4 | Inspection | 1d | 2011-04-16 | 2011-04-16 | 255 | 358d | 0d |  |
| 257 | 1.2.2.4.2.6.5 | Concrete | 1d | 2011-04-17 | 2011-04-17 | 256 | 358d | 0d |  |
| 258 | 1.2.2.5 | **BASEMENT-1** | 45d | 2011-03-29 | 2011-05-12 |  | 0d |  |  |
| 259 | 1.2.2.5.1 | **PART-1** | 25d | 2011-03-29 | 2011-04-22 |  | 0d |  |  |
| 260 | 1.2.2.5.1.1 | **Retaining Wall** | 18d | 2011-03-29 | 2011-04-15 |  | 0d |  | rft |
| 261 | 1.2.2.5.1.1.1 | Brick Wall | 3d | 2011-03-29 | 2011-03-31 | 223 | 0d |  | sft |
| 262 | 1.2.2.5.1.1.2 | Plaster | 2d | 2011-04-01 | 2011-04-02 | 261 | 0d |  | sft |
| 263 | 1.2.2.5.1.1.3 | Water Proofing | 1d | 2011-04-09 | 2011-04-09 | 262FF+7d | 0d |  | sft |
| 264 | 1.2.2.5.1.1.4 | Re-bar Work | 3d | 2011-04-10 | 2011-04-12 | 263 | 0d |  | ton |
| 265 | 1.2.2.5.1.1.5 | Form Work | 2d | 2011-04-12 | 2011-04-13 | 264FF+1d | 0d |  | sft |
| 266 | 1.2.2.5.1.1.6 | Conreting | 1d | 2011-04-14 | 2011-04-14 | 265FF+1d | 0d |  | cft |
| 267 | 1.2.2.5.1.1.7 | De-shuttering | 1d | 2011-04-15 | 2011-04-15 | 266FF+1d | 0d |  |  |
| 268 | 1.2.2.5.1.2 | **Column** | 8d | 2011-03-29 | 2011-04-05 |  | 10d |  | nos. |
| 269 | 1.2.2.5.1.2.1 | Re-Bar Work | 2d | 2011-03-29 | 2011-03-30 | 223 | 10d | 0d |  |
| 270 | 1.2.2.5.1.2.2 | Form Work | 2d | 2011-03-31 | 2011-04-01 | 269 | 10d | 0d |  |
| 271 | 1.2.2.5.1.2.3 | Concrete | 2d | 2011-04-02 | 2011-04-03 | 270 | 10d | 0d |  |
| 272 | 1.2.2.5.1.2.4 | De-shuttering | 2d | 2011-04-04 | 2011-04-05 | 271 | 10d |  |  |

| ID | WBS | Task | Duration | Start | Finish | Predecessors | Total slack | Free slack | Text1 |
| --- | --- | --- | --- | --- | --- | --- | --- | --- | --- |
| 273 | 1.2.2.5.1.3 | **Shear Wall** | 12d | 2011-03-29 | 2011-04-09 |  | 6d |  | nos. |
| 274 | 1.2.2.5.1.3.1 | Re-Bar Work | 3d | 2011-03-29 | 2011-03-31 | 223 | 6d | 0d |  |
| 275 | 1.2.2.5.1.3.2 | Form Work | 3d | 2011-04-01 | 2011-04-03 | 274 | 6d | 0d |  |
| 276 | 1.2.2.5.1.3.3 | Concrete | 3d | 2011-04-04 | 2011-04-06 | 275 | 6d | 0d |  |
| 277 | 1.2.2.5.1.3.4 | De-shuttering | 3d | 2011-04-07 | 2011-04-09 | 276 | 6d |  |  |
| 278 | 1.2.2.5.1.4 | **Stair - 1** | 4d | 2011-03-29 | 2011-04-01 |  | 31d |  |  |
| 279 | 1.2.2.5.1.4.1 | **1st Flight** | 4d | 2011-03-29 | 2011-04-01 |  | 31d |  |  |
| 280 | 1.2.2.5.1.4.1.1 | Brick Work | 1d | 2011-03-29 | 2011-03-29 | 223 | 31d | 0d |  |
| 281 | 1.2.2.5.1.4.1.2 | Form Work | 1d | 2011-03-30 | 2011-03-30 | 280 | 31d | 0d |  |
| 282 | 1.2.2.5.1.4.1.3 | Re-bar Work | 1d | 2011-03-31 | 2011-03-31 | 281 | 31d | 0d |  |
| 283 | 1.2.2.5.1.4.1.4 | Concrete | 1d | 2011-04-01 | 2011-04-01 | 282 | 31d | 0d |  |
| 284 | 1.2.2.5.1.5 | **Ramp** | 2d | 2011-04-17 | 2011-04-18 |  | 488d |  |  |
| 285 | 1.2.2.5.1.5.1 | Form Work | 1d | 2011-04-17 | 2011-04-17 | 288FF | 488d | 0d |  |
| 286 | 1.2.2.5.1.5.2 | Re-Bar | 1d | 2011-04-18 | 2011-04-18 | 285 | 488d |  |  |
| 287 | 1.2.2.5.1.6 | **Roof Slab** | 7d | 2011-04-16 | 2011-04-22 |  | 0d |  |  |
| 288 | 1.2.2.5.1.6.1 | Form Work | 2d | 2011-04-16 | 2011-04-17 | 267, 268, 273 | 0d |  |  |
| 289 | 1.2.2.5.1.6.2 | Re-bar | 2d | 2011-04-18 | 2011-04-19 | 288FF+2d | 0d |  |  |
| 290 | 1.2.2.5.1.6.3 | MEP Work | 1d | 2011-04-20 | 2011-04-20 | 289 | 0d |  |  |
| 291 | 1.2.2.5.1.6.4 | Inspection | 1d | 2011-04-21 | 2011-04-21 | 290 | 0d |  |  |
| 292 | 1.2.2.5.1.6.5 | Concrete | 1d | 2011-04-22 | 2011-04-22 | 291 | 0d |  |  |
| 293 | 1.2.2.5.2 | **PART-2** | 41d | 2011-04-02 | 2011-05-12 |  | 20d |  |  |
| 294 | 1.2.2.5.2.1 | **Retaining Wall** | 14d | 2011-04-22 | 2011-05-05 |  | 0d |  | rft |
| 295 | 1.2.2.5.2.1.1 | Brick Wall | 2d | 2011-04-22 | 2011-04-23 | 292FF+1d | 0d |  | sft |
| 296 | 1.2.2.5.2.1.2 | Plaster | 2d | 2011-04-23 | 2011-04-24 | 295FF+1d | 0d |  | sft |
| 297 | 1.2.2.5.2.1.3 | Water Proofing | 2d | 2011-04-30 | 2011-05-01 | 296FF+7d | 0d |  | sft |
| 298 | 1.2.2.5.2.1.4 | Re-bar Work | 2d | 2011-05-01 | 2011-05-02 | 297FF+1d | 0d |  | ton |
| 299 | 1.2.2.5.2.1.5 | Form Work | 2d | 2011-05-02 | 2011-05-03 | 298FF+1d | 0d |  | sft |
| 300 | 1.2.2.5.2.1.6 | Conreting | 2d | 2011-05-03 | 2011-05-04 | 299FF+1d | 0d |  | cft |
| 301 | 1.2.2.5.2.1.7 | De-shuttering | 2d | 2011-05-04 | 2011-05-05 | 300FF+1d | 0d |  |  |

| ID | WBS | Task | Duration | Start | Finish | Predecessors | Total slack | Free slack | Text1 |
| --- | --- | --- | --- | --- | --- | --- | --- | --- | --- |
| 302 | 1.2.2.5.2.2 | **Column** | 5d | 2011-04-22 | 2011-04-26 |  | 9d |  | nos. |
| 303 | 1.2.2.5.2.2.1 | Re-Bar Work | 2d | 2011-04-22 | 2011-04-23 | 292FF+1d | 9d | 0d |  |
| 304 | 1.2.2.5.2.2.2 | Form Work | 2d | 2011-04-23 | 2011-04-24 | 303FF+1d | 9d | 0d |  |
| 305 | 1.2.2.5.2.2.3 | Concrete | 2d | 2011-04-24 | 2011-04-25 | 304FF+1d | 9d | 0d |  |
| 306 | 1.2.2.5.2.2.4 | De-shuttering | 2d | 2011-04-25 | 2011-04-26 | 305FF+1d | 9d |  |  |
| 307 | 1.2.2.5.2.3 | **Shear Wall** | 6d | 2011-04-21 | 2011-04-26 |  | 9d |  | nos. |
| 308 | 1.2.2.5.2.3.1 | Re-Bar Work | 3d | 2011-04-21 | 2011-04-23 | 292FF+1d | 9d | 0d |  |
| 309 | 1.2.2.5.2.3.2 | Form Work | 3d | 2011-04-22 | 2011-04-24 | 308FF+1d | 9d | 0d |  |
| 310 | 1.2.2.5.2.3.3 | Concrete | 3d | 2011-04-23 | 2011-04-25 | 309FF+1d | 9d | 0d |  |
| 311 | 1.2.2.5.2.3.4 | De-shuttering | 3d | 2011-04-24 | 2011-04-26 | 310FF+1d | 9d |  |  |
| 312 | 1.2.2.5.2.4 | **Stair - 1** | 3d | 2011-04-02 | 2011-04-04 |  | 31d |  |  |
| 313 | 1.2.2.5.2.4.1 | **2nd Flight** | 3d | 2011-04-02 | 2011-04-04 |  | 31d |  |  |
| 314 | 1.2.2.5.2.4.1.1 | Brick Work | 1d | 2011-04-02 | 2011-04-02 | 283 | 31d | 0d |  |
| 315 | 1.2.2.5.2.4.1.2 | Form Work | 1d | 2011-04-03 | 2011-04-03 | 314FF+1d | 31d | 0d |  |
| 316 | 1.2.2.5.2.4.1.3 | Re-bar Work | 1d | 2011-04-04 | 2011-04-04 | 315FF+1d | 31d |  |  |
| 317 | 1.2.2.5.2.5 | **Ramp** | 3d | 2011-04-23 | 2011-04-25 |  | 481d |  |  |
| 318 | 1.2.2.5.2.5.1 | Form Work | 1d | 2011-04-23 | 2011-04-23 | 292FF+1d | 481d | 0d |  |
| 319 | 1.2.2.5.2.5.2 | Re-Bar | 1d | 2011-04-24 | 2011-04-24 | 318FF+1d | 481d | 0d |  |
| 320 | 1.2.2.5.2.5.3 | Concrete | 1d | 2011-04-25 | 2011-04-25 | 319FF+1d | 481d |  |  |
| 321 | 1.2.2.5.2.6 | **Roof Slab** | 7d | 2011-05-06 | 2011-05-12 |  | 0d |  |  |
| 322 | 1.2.2.5.2.6.1 | Form Work | 2d | 2011-05-06 | 2011-05-07 | 294, 302, 307, 312 | 0d |  |  |
| 323 | 1.2.2.5.2.6.2 | Re-bar | 2d | 2011-05-08 | 2011-05-09 | 322FF+2d | 0d |  |  |
| 324 | 1.2.2.5.2.6.3 | MEP Work | 1d | 2011-05-10 | 2011-05-10 | 323 | 0d |  |  |
| 325 | 1.2.2.5.2.6.4 | Inspection | 1d | 2011-05-11 | 2011-05-11 | 324 | 0d |  |  |
| 326 | 1.2.2.5.2.6.5 | Concrete | 1d | 2011-05-12 | 2011-05-12 | 325 | 0d |  |  |

| ID | WBS | Task | Duration | Start | Finish | Predecessors | Total slack | Text1 |
| --- | --- | --- | --- | --- | --- | --- | --- | --- |
| 327 | 1.3 | **SUPER STRUCTURE** | 370d | 2011-05-13 | 2012-06-01 |  | 0d |  |
| 328 | 1.3.1 | **GROUND FLOOR** | 25d | 2011-05-13 | 2011-06-06 |  | 0d |  |
| 329 | 1.3.1.1 | **Column** | 12d | 2011-05-13 | 2011-05-24 |  | 0d | nos. |
| 330 | 1.3.1.1.1 | **1ST Lift** | 6d | 2011-05-13 | 2011-05-18 |  | 0d |  |
| 331 | 1.3.1.1.1.1 | Re-Bar Work | 1d | 2011-05-13 | 2011-05-13 | 326 | 0d |  |
| 332 | 1.3.1.1.1.2 | Form Work | 1d | 2011-05-14 | 2011-05-14 | 331 | 0d |  |
| 333 | 1.3.1.1.1.3 | Concrete | 1d | 2011-05-15 | 2011-05-15 | 332 | 0d |  |
| 334 | 1.3.1.1.1.4 | De-shuttering | 1d | 2011-05-18 | 2011-05-18 | 333FS+2d | 0d |  |
| 335 | 1.3.1.1.2 | **2nd Lift** | 6d | 2011-05-19 | 2011-05-24 |  | 0d |  |
| 336 | 1.3.1.1.2.1 | Re-Bar Work | 1d | 2011-05-19 | 2011-05-19 | 334 | 0d |  |
| 337 | 1.3.1.1.2.2 | Form Work | 1d | 2011-05-20 | 2011-05-20 | 336 | 0d |  |
| 338 | 1.3.1.1.2.3 | Concrete | 1d | 2011-05-21 | 2011-05-21 | 337 | 0d |  |
| 339 | 1.3.1.1.2.4 | De-shuttering | 1d | 2011-05-24 | 2011-05-24 | 338FS+2d | 0d |  |
| 340 | 1.3.1.2 | **Shear Wall** | 12d | 2011-05-13 | 2011-05-24 |  | 0d | nos. |
| 341 | 1.3.1.2.1 | **1st Lift** | 6d | 2011-05-13 | 2011-05-18 |  | 0d |  |
| 342 | 1.3.1.2.1.1 | Re-Bar Work | 1d | 2011-05-13 | 2011-05-13 | 326 | 0d |  |
| 343 | 1.3.1.2.1.2 | Form Work | 1d | 2011-05-14 | 2011-05-14 | 342 | 0d |  |
| 344 | 1.3.1.2.1.3 | Concrete | 1d | 2011-05-15 | 2011-05-15 | 343 | 0d |  |
| 345 | 1.3.1.2.1.4 | De-shuttering | 1d | 2011-05-18 | 2011-05-18 | 344FS+2d | 0d |  |
| 346 | 1.3.1.2.2 | **2nd Lift** | 6d | 2011-05-19 | 2011-05-24 |  | 0d |  |
| 347 | 1.3.1.2.2.1 | Re-Bar Work | 1d | 2011-05-19 | 2011-05-19 | 345 | 0d |  |
| 348 | 1.3.1.2.2.2 | Form Work | 1d | 2011-05-20 | 2011-05-20 | 347 | 0d |  |
| 349 | 1.3.1.2.2.3 | Concrete | 1d | 2011-05-21 | 2011-05-21 | 348 | 0d |  |
| 350 | 1.3.1.2.2.4 | De-shuttering | 1d | 2011-05-24 | 2011-05-24 | 349FS+2d | 0d |  |

| ID | WBS | Task | Duration | Start | Finish | Predecessors | Total slack | Free slack | Text1 |
| --- | --- | --- | --- | --- | --- | --- | --- | --- | --- |
| 351 | 1.3.1.3 | **Stair - 1 & 2** | 7d | 2011-05-13 | 2011-05-19 |  | 5d |  |  |
| 352 | 1.3.1.3.1 | **1st Flight** | 4d | 2011-05-13 | 2011-05-16 |  | 5d |  |  |
| 353 | 1.3.1.3.1.1 | Brick Work | 1d | 2011-05-13 | 2011-05-13 | 326 | 5d | 0d |  |
| 354 | 1.3.1.3.1.2 | Form Work | 1d | 2011-05-14 | 2011-05-14 | 353 | 5d | 0d |  |
| 355 | 1.3.1.3.1.3 | Re-bar Work | 1d | 2011-05-15 | 2011-05-15 | 354 | 5d | 0d |  |
| 356 | 1.3.1.3.1.4 | Concrete | 1d | 2011-05-16 | 2011-05-16 | 355 | 5d | 0d |  |
| 357 | 1.3.1.3.2 | **2nd Flight** | 3d | 2011-05-17 | 2011-05-19 |  | 5d |  |  |
| 358 | 1.3.1.3.2.1 | Form Work | 1d | 2011-05-17 | 2011-05-17 | 356 | 5d | 0d |  |
| 359 | 1.3.1.3.2.2 | Re-bar | 1d | 2011-05-18 | 2011-05-18 | 358 | 5d | 0d |  |
| 360 | 1.3.1.3.2.3 | Concrete | 1d | 2011-05-19 | 2011-05-19 | 359 | 5d |  |  |
| 361 | 1.3.1.4 | **Roof Slab** | 13d | 2011-05-25 | 2011-06-06 |  | 0d |  |  |
| 362 | 1.3.1.4.1 | Form Work | 5d | 2011-05-25 | 2011-05-29 | 339, 350, 360 | 0d |  |  |
| 363 | 1.3.1.4.2 | Re-bar | 4d | 2011-05-30 | 2011-06-02 | 362 | 0d |  |  |
| 364 | 1.3.1.4.3 | MEP Work | 1d | 2011-06-03 | 2011-06-03 | 363 | 0d |  |  |
| 365 | 1.3.1.4.4 | Inspection | 1d | 2011-06-04 | 2011-06-04 | 364 | 0d |  |  |
| 366 | 1.3.1.4.5 | Concrete | 2d | 2011-06-05 | 2011-06-06 | 365 | 0d |  |  |
| 367 | 1.3.2 | **1ST FLOOR** | 25d | 2011-06-07 | 2011-07-01 |  | 0d |  |  |
| 368 | 1.3.2.1 | **Column** | 12d | 2011-06-07 | 2011-06-18 |  | 0d |  | nos. |
| 369 | 1.3.2.1.1 | **1ST Lift** | 6d | 2011-06-07 | 2011-06-12 |  | 0d |  |  |
| 370 | 1.3.2.1.1.1 | Re-Bar Work | 1d | 2011-06-07 | 2011-06-07 | 366 | 0d |  |  |
| 371 | 1.3.2.1.1.2 | Form Work | 1d | 2011-06-08 | 2011-06-08 | 370 | 0d |  |  |
| 372 | 1.3.2.1.1.3 | Concrete | 1d | 2011-06-09 | 2011-06-09 | 371 | 0d |  |  |
| 373 | 1.3.2.1.1.4 | De-shuttering | 1d | 2011-06-12 | 2011-06-12 | 372FS+2d | 0d |  |  |
| 374 | 1.3.2.1.2 | **2nd Lift** | 6d | 2011-06-13 | 2011-06-18 |  | 0d |  |  |
| 375 | 1.3.2.1.2.1 | Re-Bar Work | 1d | 2011-06-13 | 2011-06-13 | 373 | 0d |  |  |
| 376 | 1.3.2.1.2.2 | Form Work | 1d | 2011-06-14 | 2011-06-14 | 375 | 0d |  |  |
| 377 | 1.3.2.1.2.3 | Concrete | 1d | 2011-06-15 | 2011-06-15 | 376 | 0d |  |  |
| 378 | 1.3.2.1.2.4 | De-shuttering | 1d | 2011-06-18 | 2011-06-18 | 377FS+2d | 0d |  |  |

| ID | WBS | Task | Duration | Start | Finish | Predecessors | Total slack | Free slack | Text1 |
| --- | --- | --- | --- | --- | --- | --- | --- | --- | --- |
| 379 | 1.3.2.2 | **Shear Wall** | 12d | 2011-06-07 | 2011-06-18 |  | 0d |  | nos. |
| 380 | 1.3.2.2.1 | **1st Lift** | 6d | 2011-06-07 | 2011-06-12 |  | 0d |  |  |
| 381 | 1.3.2.2.1.1 | Re-Bar Work | 1d | 2011-06-07 | 2011-06-07 | 366 | 0d |  |  |
| 382 | 1.3.2.2.1.2 | Form Work | 1d | 2011-06-08 | 2011-06-08 | 381 | 0d |  |  |
| 383 | 1.3.2.2.1.3 | Concrete | 1d | 2011-06-09 | 2011-06-09 | 382 | 0d |  |  |
| 384 | 1.3.2.2.1.4 | De-shuttering | 1d | 2011-06-12 | 2011-06-12 | 383FS+2d | 0d |  |  |
| 385 | 1.3.2.2.2 | **2nd Lift** | 6d | 2011-06-13 | 2011-06-18 |  | 0d |  |  |
| 386 | 1.3.2.2.2.1 | Re-Bar Work | 1d | 2011-06-13 | 2011-06-13 | 384 | 0d |  |  |
| 387 | 1.3.2.2.2.2 | Form Work | 1d | 2011-06-14 | 2011-06-14 | 386 | 0d |  |  |
| 388 | 1.3.2.2.2.3 | Concrete | 1d | 2011-06-15 | 2011-06-15 | 387 | 0d |  |  |
| 389 | 1.3.2.2.2.4 | De-shuttering | 1d | 2011-06-18 | 2011-06-18 | 388FS+2d | 0d |  |  |
| 390 | 1.3.2.3 | **Stair - 1 & 2** | 7d | 2011-06-07 | 2011-06-13 |  | 5d |  |  |
| 391 | 1.3.2.3.1 | **1st Flight** | 4d | 2011-06-07 | 2011-06-10 |  | 5d |  |  |
| 392 | 1.3.2.3.1.1 | Brick Work | 1d | 2011-06-07 | 2011-06-07 | 366 | 5d | 0d |  |
| 393 | 1.3.2.3.1.2 | Form Work | 1d | 2011-06-08 | 2011-06-08 | 392 | 5d | 0d |  |
| 394 | 1.3.2.3.1.3 | Re-bar Work | 1d | 2011-06-09 | 2011-06-09 | 393 | 5d | 0d |  |
| 395 | 1.3.2.3.1.4 | Concrete | 1d | 2011-06-10 | 2011-06-10 | 394 | 5d | 0d |  |
| 396 | 1.3.2.3.2 | **2nd Flight** | 3d | 2011-06-11 | 2011-06-13 |  | 5d |  |  |
| 397 | 1.3.2.3.2.1 | Form Work | 1d | 2011-06-11 | 2011-06-11 | 395 | 5d | 0d |  |
| 398 | 1.3.2.3.2.2 | Re-bar | 1d | 2011-06-12 | 2011-06-12 | 397 | 5d | 0d |  |
| 399 | 1.3.2.3.2.3 | Concrete | 1d | 2011-06-13 | 2011-06-13 | 398 | 5d |  |  |
| 400 | 1.3.2.4 | **Roof Slab** | 13d | 2011-06-19 | 2011-07-01 |  | 0d |  |  |
| 401 | 1.3.2.4.1 | Form Work | 5d | 2011-06-19 | 2011-06-23 | 378, 389, 399 | 0d |  |  |
| 402 | 1.3.2.4.2 | Re-bar | 4d | 2011-06-24 | 2011-06-27 | 401 | 0d |  |  |
| 403 | 1.3.2.4.3 | MEP Work | 1d | 2011-06-28 | 2011-06-28 | 402 | 0d |  |  |
| 404 | 1.3.2.4.4 | Inspection | 1d | 2011-06-29 | 2011-06-29 | 403 | 0d |  |  |
| 405 | 1.3.2.4.5 | Concrete | 2d | 2011-06-30 | 2011-07-01 | 404 | 0d |  |  |

| ID | WBS | Task | Duration | Start | Finish | Predecessors | Total slack | Free slack | Text1 |
| --- | --- | --- | --- | --- | --- | --- | --- | --- | --- |
| 406 | 1.3.3 | **2ND FLOOR** | 25d | 2011-07-02 | 2011-07-26 |  | 0d |  |  |
| 407 | 1.3.3.1 | **Column** | 12d | 2011-07-02 | 2011-07-13 |  | 0d |  | nos. |
| 408 | 1.3.3.1.1 | **1ST Lift** | 6d | 2011-07-02 | 2011-07-07 |  | 0d |  |  |
| 409 | 1.3.3.1.1.1 | Re-Bar Work | 1d | 2011-07-02 | 2011-07-02 | 405 | 0d |  |  |
| 410 | 1.3.3.1.1.2 | Form Work | 1d | 2011-07-03 | 2011-07-03 | 409 | 0d |  |  |
| 411 | 1.3.3.1.1.3 | Concrete | 1d | 2011-07-04 | 2011-07-04 | 410 | 0d |  |  |
| 412 | 1.3.3.1.1.4 | De-shuttering | 1d | 2011-07-07 | 2011-07-07 | 411FS+2d | 0d |  |  |
| 413 | 1.3.3.1.2 | **2nd Lift** | 6d | 2011-07-08 | 2011-07-13 |  | 0d |  |  |
| 414 | 1.3.3.1.2.1 | Re-Bar Work | 1d | 2011-07-08 | 2011-07-08 | 412 | 0d |  |  |
| 415 | 1.3.3.1.2.2 | Form Work | 1d | 2011-07-09 | 2011-07-09 | 414 | 0d |  |  |
| 416 | 1.3.3.1.2.3 | Concrete | 1d | 2011-07-10 | 2011-07-10 | 415 | 0d |  |  |
| 417 | 1.3.3.1.2.4 | De-shuttering | 1d | 2011-07-13 | 2011-07-13 | 416FS+2d | 0d |  |  |
| 418 | 1.3.3.2 | **Shear Wall** | 12d | 2011-07-02 | 2011-07-13 |  | 0d |  | nos. |
| 419 | 1.3.3.2.1 | **1st Lift** | 6d | 2011-07-02 | 2011-07-07 |  | 0d |  |  |
| 420 | 1.3.3.2.1.1 | Re-Bar Work | 1d | 2011-07-02 | 2011-07-02 | 405 | 0d |  |  |
| 421 | 1.3.3.2.1.2 | Form Work | 1d | 2011-07-03 | 2011-07-03 | 420 | 0d |  |  |
| 422 | 1.3.3.2.1.3 | Concrete | 1d | 2011-07-04 | 2011-07-04 | 421 | 0d |  |  |
| 423 | 1.3.3.2.1.4 | De-shuttering | 1d | 2011-07-07 | 2011-07-07 | 422FS+2d | 0d |  |  |
| 424 | 1.3.3.2.2 | **2nd Lift** | 6d | 2011-07-08 | 2011-07-13 |  | 0d |  |  |
| 425 | 1.3.3.2.2.1 | Re-Bar Work | 1d | 2011-07-08 | 2011-07-08 | 423 | 0d |  |  |
| 426 | 1.3.3.2.2.2 | Form Work | 1d | 2011-07-09 | 2011-07-09 | 425 | 0d |  |  |
| 427 | 1.3.3.2.2.3 | Concrete | 1d | 2011-07-10 | 2011-07-10 | 426 | 0d |  |  |
| 428 | 1.3.3.2.2.4 | De-shuttering | 1d | 2011-07-13 | 2011-07-13 | 427FS+2d | 0d |  |  |
| 429 | 1.3.3.3 | **Stair - 1 & 2** | 7d | 2011-07-02 | 2011-07-08 |  | 5d |  |  |
| 430 | 1.3.3.3.1 | **1st Flight** | 4d | 2011-07-02 | 2011-07-05 |  | 5d |  |  |
| 431 | 1.3.3.3.1.1 | Brick Work | 1d | 2011-07-02 | 2011-07-02 | 405 | 5d | 0d |  |
| 432 | 1.3.3.3.1.2 | Form Work | 1d | 2011-07-03 | 2011-07-03 | 431 | 5d | 0d |  |
| 433 | 1.3.3.3.1.3 | Re-bar Work | 1d | 2011-07-04 | 2011-07-04 | 432 | 5d | 0d |  |
| 434 | 1.3.3.3.1.4 | Concrete | 1d | 2011-07-05 | 2011-07-05 | 433 | 5d | 0d |  |

| ID | WBS | Task | Duration | Start | Finish | Predecessors | Total slack | Free slack | Text1 |
| --- | --- | --- | --- | --- | --- | --- | --- | --- | --- |
| 435 | 1.3.3.3.2 | **2nd Flight** | 3d | 2011-07-06 | 2011-07-08 |  | 5d |  |  |
| 436 | 1.3.3.3.2.1 | Form Work | 1d | 2011-07-06 | 2011-07-06 | 434 | 5d | 0d |  |
| 437 | 1.3.3.3.2.2 | Re-bar | 1d | 2011-07-07 | 2011-07-07 | 436 | 5d | 0d |  |
| 438 | 1.3.3.3.2.3 | Concrete | 1d | 2011-07-08 | 2011-07-08 | 437 | 5d |  |  |
| 439 | 1.3.3.4 | **Roof Slab** | 13d | 2011-07-14 | 2011-07-26 |  | 0d |  |  |
| 440 | 1.3.3.4.1 | Form Work | 5d | 2011-07-14 | 2011-07-18 | 417, 428, 438 | 0d |  |  |
| 441 | 1.3.3.4.2 | Re-bar | 4d | 2011-07-19 | 2011-07-22 | 440 | 0d |  |  |
| 442 | 1.3.3.4.3 | MEP Work | 1d | 2011-07-23 | 2011-07-23 | 441 | 0d |  |  |
| 443 | 1.3.3.4.4 | Inspection | 1d | 2011-07-24 | 2011-07-24 | 442 | 0d |  |  |
| 444 | 1.3.3.4.5 | Concrete | 2d | 2011-07-25 | 2011-07-26 | 443 | 0d |  |  |
| 445 | 1.3.4 | **3RD FLOOR** | 25d | 2011-07-27 | 2011-08-20 |  | 0d |  |  |
| 446 | 1.3.4.1 | **Column** | 12d | 2011-07-27 | 2011-08-07 |  | 0d |  | nos. |
| 447 | 1.3.4.1.1 | **1ST Lift** | 6d | 2011-07-27 | 2011-08-01 |  | 0d |  |  |
| 448 | 1.3.4.1.1.1 | Re-Bar Work | 1d | 2011-07-27 | 2011-07-27 | 444 | 0d |  |  |
| 449 | 1.3.4.1.1.2 | Form Work | 1d | 2011-07-28 | 2011-07-28 | 448 | 0d |  |  |
| 450 | 1.3.4.1.1.3 | Concrete | 1d | 2011-07-29 | 2011-07-29 | 449 | 0d |  |  |
| 451 | 1.3.4.1.1.4 | De-shuttering | 1d | 2011-08-01 | 2011-08-01 | 450FS+2d | 0d |  |  |
| 452 | 1.3.4.1.2 | **2nd Lift** | 6d | 2011-08-02 | 2011-08-07 |  | 0d |  |  |
| 453 | 1.3.4.1.2.1 | Re-Bar Work | 1d | 2011-08-02 | 2011-08-02 | 451 | 0d |  |  |
| 454 | 1.3.4.1.2.2 | Form Work | 1d | 2011-08-03 | 2011-08-03 | 453 | 0d |  |  |
| 455 | 1.3.4.1.2.3 | Concrete | 1d | 2011-08-04 | 2011-08-04 | 454 | 0d |  |  |
| 456 | 1.3.4.1.2.4 | De-shuttering | 1d | 2011-08-07 | 2011-08-07 | 455FS+2d | 0d |  |  |
| 457 | 1.3.4.2 | **Shear Wall** | 12d | 2011-07-27 | 2011-08-07 |  | 0d |  | nos. |
| 458 | 1.3.4.2.1 | **1st Lift** | 6d | 2011-07-27 | 2011-08-01 |  | 0d |  |  |
| 459 | 1.3.4.2.1.1 | Re-Bar Work | 1d | 2011-07-27 | 2011-07-27 | 444 | 0d |  |  |
| 460 | 1.3.4.2.1.2 | Form Work | 1d | 2011-07-28 | 2011-07-28 | 459 | 0d |  |  |
| 461 | 1.3.4.2.1.3 | Concrete | 1d | 2011-07-29 | 2011-07-29 | 460 | 0d |  |  |
| 462 | 1.3.4.2.1.4 | De-shuttering | 1d | 2011-08-01 | 2011-08-01 | 461FS+2d | 0d |  |  |

| ID | WBS | Task | Duration | Start | Finish | Predecessors | Total slack | Free slack | Text1 |
| --- | --- | --- | --- | --- | --- | --- | --- | --- | --- |
| 463 | 1.3.4.2.2 | **2nd Lift** | 6d | 2011-08-02 | 2011-08-07 |  | 0d |  |  |
| 464 | 1.3.4.2.2.1 | Re-Bar Work | 1d | 2011-08-02 | 2011-08-02 | 462 | 0d |  |  |
| 465 | 1.3.4.2.2.2 | Form Work | 1d | 2011-08-03 | 2011-08-03 | 464 | 0d |  |  |
| 466 | 1.3.4.2.2.3 | Concrete | 1d | 2011-08-04 | 2011-08-04 | 465 | 0d |  |  |
| 467 | 1.3.4.2.2.4 | De-shuttering | 1d | 2011-08-07 | 2011-08-07 | 466FS+2d | 0d |  |  |
| 468 | 1.3.4.3 | **Stair - 1 & 2** | 7d | 2011-07-27 | 2011-08-02 |  | 5d |  |  |
| 469 | 1.3.4.3.1 | **1st Flight** | 4d | 2011-07-27 | 2011-07-30 |  | 5d |  |  |
| 470 | 1.3.4.3.1.1 | Brick Work | 1d | 2011-07-27 | 2011-07-27 | 444 | 5d | 0d |  |
| 471 | 1.3.4.3.1.2 | Form Work | 1d | 2011-07-28 | 2011-07-28 | 470 | 5d | 0d |  |
| 472 | 1.3.4.3.1.3 | Re-bar Work | 1d | 2011-07-29 | 2011-07-29 | 471 | 5d | 0d |  |
| 473 | 1.3.4.3.1.4 | Concrete | 1d | 2011-07-30 | 2011-07-30 | 472 | 5d | 0d |  |
| 474 | 1.3.4.3.2 | **2nd Flight** | 3d | 2011-07-31 | 2011-08-02 |  | 5d |  |  |
| 475 | 1.3.4.3.2.1 | Form Work | 1d | 2011-07-31 | 2011-07-31 | 473 | 5d | 0d |  |
| 476 | 1.3.4.3.2.2 | Re-bar | 1d | 2011-08-01 | 2011-08-01 | 475 | 5d | 0d |  |
| 477 | 1.3.4.3.2.3 | Concrete | 1d | 2011-08-02 | 2011-08-02 | 476 | 5d |  |  |
| 478 | 1.3.4.4 | **Roof Slab** | 13d | 2011-08-08 | 2011-08-20 |  | 0d |  |  |
| 479 | 1.3.4.4.1 | Form Work | 5d | 2011-08-08 | 2011-08-12 | 456, 467, 477 | 0d |  |  |
| 480 | 1.3.4.4.2 | Re-bar | 4d | 2011-08-13 | 2011-08-16 | 479 | 0d |  |  |
| 481 | 1.3.4.4.3 | MEP Work | 1d | 2011-08-17 | 2011-08-17 | 480 | 0d |  |  |
| 482 | 1.3.4.4.4 | Inspection | 1d | 2011-08-18 | 2011-08-18 | 481 | 0d |  |  |
| 483 | 1.3.4.4.5 | Concrete | 2d | 2011-08-19 | 2011-08-20 | 482 | 0d |  |  |
| 484 | 1.3.5 | **4TH FLOOR** | 25d | 2011-08-21 | 2011-09-22 |  | 0d |  |  |
| 485 | 1.3.5.1 | **Column** | 12d | 2011-08-21 | 2011-09-09 |  | 0d |  | nos. |
| 486 | 1.3.5.1.1 | **1ST Lift** | 6d | 2011-08-21 | 2011-09-03 |  | 0d |  |  |
| 487 | 1.3.5.1.1.1 | Re-Bar Work | 1d | 2011-08-21 | 2011-08-21 | 483 | 0d |  |  |
| 488 | 1.3.5.1.1.2 | Form Work | 1d | 2011-08-22 | 2011-08-22 | 487 | 0d |  |  |
| 489 | 1.3.5.1.1.3 | Concrete | 1d | 2011-08-23 | 2011-08-23 | 488 | 0d |  |  |
| 490 | 1.3.5.1.1.4 | De-shuttering | 1d | 2011-09-03 | 2011-09-03 | 489FS+2d | 0d |  |  |

| ID | WBS | Task | Duration | Start | Finish | Predecessors | Total slack | Free slack | Text1 |
| --- | --- | --- | --- | --- | --- | --- | --- | --- | --- |
| 491 | 1.3.5.1.2 | **2nd Lift** | 6d | 2011-09-04 | 2011-09-09 |  | 0d |  |  |
| 492 | 1.3.5.1.2.1 | Re-Bar Work | 1d | 2011-09-04 | 2011-09-04 | 490 | 0d |  |  |
| 493 | 1.3.5.1.2.2 | Form Work | 1d | 2011-09-05 | 2011-09-05 | 492 | 0d |  |  |
| 494 | 1.3.5.1.2.3 | Concrete | 1d | 2011-09-06 | 2011-09-06 | 493 | 0d |  |  |
| 495 | 1.3.5.1.2.4 | De-shuttering | 1d | 2011-09-09 | 2011-09-09 | 494FS+2d | 0d |  |  |
| 496 | 1.3.5.2 | **Shear Wall** | 12d | 2011-08-21 | 2011-09-09 |  | 0d |  | nos. |
| 497 | 1.3.5.2.1 | **1st Lift** | 6d | 2011-08-21 | 2011-09-03 |  | 0d |  |  |
| 498 | 1.3.5.2.1.1 | Re-Bar Work | 1d | 2011-08-21 | 2011-08-21 | 483 | 0d |  |  |
| 499 | 1.3.5.2.1.2 | Form Work | 1d | 2011-08-22 | 2011-08-22 | 498 | 0d |  |  |
| 500 | 1.3.5.2.1.3 | Concrete | 1d | 2011-08-23 | 2011-08-23 | 499 | 0d |  |  |
| 501 | 1.3.5.2.1.4 | De-shuttering | 1d | 2011-09-03 | 2011-09-03 | 500FS+2d | 0d |  |  |
| 502 | 1.3.5.2.2 | **2nd Lift** | 6d | 2011-09-04 | 2011-09-09 |  | 0d |  |  |
| 503 | 1.3.5.2.2.1 | Re-Bar Work | 1d | 2011-09-04 | 2011-09-04 | 501 | 0d |  |  |
| 504 | 1.3.5.2.2.2 | Form Work | 1d | 2011-09-05 | 2011-09-05 | 503 | 0d |  |  |
| 505 | 1.3.5.2.2.3 | Concrete | 1d | 2011-09-06 | 2011-09-06 | 504 | 0d |  |  |
| 506 | 1.3.5.2.2.4 | De-shuttering | 1d | 2011-09-09 | 2011-09-09 | 505FS+2d | 0d |  |  |
| 507 | 1.3.5.3 | **Stair - 1 & 2** | 7d | 2011-08-21 | 2011-09-04 |  | 5d |  |  |
| 508 | 1.3.5.3.1 | **1st Flight** | 4d | 2011-08-21 | 2011-08-24 |  | 5d |  |  |
| 509 | 1.3.5.3.1.1 | Brick Work | 1d | 2011-08-21 | 2011-08-21 | 483 | 5d | 0d |  |
| 510 | 1.3.5.3.1.2 | Form Work | 1d | 2011-08-22 | 2011-08-22 | 509 | 5d | 0d |  |
| 511 | 1.3.5.3.1.3 | Re-bar Work | 1d | 2011-08-23 | 2011-08-23 | 510 | 5d | 0d |  |
| 512 | 1.3.5.3.1.4 | Concrete | 1d | 2011-08-24 | 2011-08-24 | 511 | 5d | 0d |  |
| 513 | 1.3.5.3.2 | **2nd Flight** | 3d | 2011-08-25 | 2011-09-04 |  | 5d |  |  |
| 514 | 1.3.5.3.2.1 | Form Work | 1d | 2011-08-25 | 2011-08-25 | 512 | 5d | 0d |  |
| 515 | 1.3.5.3.2.2 | Re-bar | 1d | 2011-09-03 | 2011-09-03 | 514 | 5d | 0d |  |
| 516 | 1.3.5.3.2.3 | Concrete | 1d | 2011-09-04 | 2011-09-04 | 515 | 5d |  |  |

| ID | WBS | Task | Duration | Start | Finish | Predecessors | Total slack | Text1 |
| --- | --- | --- | --- | --- | --- | --- | --- | --- |
| 517 | 1.3.5.4 | **Roof Slab** | 13d | 2011-09-10 | 2011-09-22 |  | 0d |  |
| 518 | 1.3.5.4.1 | Form Work | 5d | 2011-09-10 | 2011-09-14 | 495, 506, 516 | 0d |  |
| 519 | 1.3.5.4.2 | Re-bar | 4d | 2011-09-15 | 2011-09-18 | 518 | 0d |  |
| 520 | 1.3.5.4.3 | MEP Work | 1d | 2011-09-19 | 2011-09-19 | 519 | 0d |  |
| 521 | 1.3.5.4.4 | Inspection | 1d | 2011-09-20 | 2011-09-20 | 520 | 0d |  |
| 522 | 1.3.5.4.5 | Concrete | 2d | 2011-09-21 | 2011-09-22 | 521 | 0d |  |
| 523 | 1.3.6 | **5TH FLOOR** | 25d | 2011-09-23 | 2011-10-17 |  | 0d |  |
| 524 | 1.3.6.1 | **Column** | 12d | 2011-09-23 | 2011-10-04 |  | 0d | nos. |
| 525 | 1.3.6.1.1 | **1ST Lift** | 6d | 2011-09-23 | 2011-09-28 |  | 0d |  |
| 526 | 1.3.6.1.1.1 | Re-Bar Work | 1d | 2011-09-23 | 2011-09-23 | 522 | 0d |  |
| 527 | 1.3.6.1.1.2 | Form Work | 1d | 2011-09-24 | 2011-09-24 | 526 | 0d |  |
| 528 | 1.3.6.1.1.3 | Concrete | 1d | 2011-09-25 | 2011-09-25 | 527 | 0d |  |
| 529 | 1.3.6.1.1.4 | De-shuttering | 1d | 2011-09-28 | 2011-09-28 | 528FS+2d | 0d |  |
| 530 | 1.3.6.1.2 | **2nd Lift** | 6d | 2011-09-29 | 2011-10-04 |  | 0d |  |
| 531 | 1.3.6.1.2.1 | Re-Bar Work | 1d | 2011-09-29 | 2011-09-29 | 529 | 0d |  |
| 532 | 1.3.6.1.2.2 | Form Work | 1d | 2011-09-30 | 2011-09-30 | 531 | 0d |  |
| 533 | 1.3.6.1.2.3 | Concrete | 1d | 2011-10-01 | 2011-10-01 | 532 | 0d |  |
| 534 | 1.3.6.1.2.4 | De-shuttering | 1d | 2011-10-04 | 2011-10-04 | 533FS+2d | 0d |  |
| 535 | 1.3.6.2 | **Shear Wall** | 12d | 2011-09-23 | 2011-10-04 |  | 0d | nos. |
| 536 | 1.3.6.2.1 | **1st Lift** | 6d | 2011-09-23 | 2011-09-28 |  | 0d |  |
| 537 | 1.3.6.2.1.1 | Re-Bar Work | 1d | 2011-09-23 | 2011-09-23 | 522 | 0d |  |
| 538 | 1.3.6.2.1.2 | Form Work | 1d | 2011-09-24 | 2011-09-24 | 537 | 0d |  |
| 539 | 1.3.6.2.1.3 | Concrete | 1d | 2011-09-25 | 2011-09-25 | 538 | 0d |  |
| 540 | 1.3.6.2.1.4 | De-shuttering | 1d | 2011-09-28 | 2011-09-28 | 539FS+2d | 0d |  |

| ID | WBS | Task | Duration | Start | Finish | Predecessors | Total slack | Free slack | Text1 |
| --- | --- | --- | --- | --- | --- | --- | --- | --- | --- |
| 541 | 1.3.6.2.2 | **2nd Lift** | 6d | 2011-09-29 | 2011-10-04 |  | 0d |  |  |
| 542 | 1.3.6.2.2.1 | Re-Bar Work | 1d | 2011-09-29 | 2011-09-29 | 540 | 0d |  |  |
| 543 | 1.3.6.2.2.2 | Form Work | 1d | 2011-09-30 | 2011-09-30 | 542 | 0d |  |  |
| 544 | 1.3.6.2.2.3 | Concrete | 1d | 2011-10-01 | 2011-10-01 | 543 | 0d |  |  |
| 545 | 1.3.6.2.2.4 | De-shuttering | 1d | 2011-10-04 | 2011-10-04 | 544FS+2d | 0d |  |  |
| 546 | 1.3.6.3 | **Stair - 1 & 2** | 7d | 2011-09-23 | 2011-09-29 |  | 5d |  |  |
| 547 | 1.3.6.3.1 | **1st Flight** | 4d | 2011-09-23 | 2011-09-26 |  | 5d |  |  |
| 548 | 1.3.6.3.1.1 | Brick Work | 1d | 2011-09-23 | 2011-09-23 | 522 | 5d | 0d |  |
| 549 | 1.3.6.3.1.2 | Form Work | 1d | 2011-09-24 | 2011-09-24 | 548 | 5d | 0d |  |
| 550 | 1.3.6.3.1.3 | Re-bar Work | 1d | 2011-09-25 | 2011-09-25 | 549 | 5d | 0d |  |
| 551 | 1.3.6.3.1.4 | Concrete | 1d | 2011-09-26 | 2011-09-26 | 550 | 5d | 0d |  |
| 552 | 1.3.6.3.2 | **2nd Flight** | 3d | 2011-09-27 | 2011-09-29 |  | 5d |  |  |
| 553 | 1.3.6.3.2.1 | Form Work | 1d | 2011-09-27 | 2011-09-27 | 551 | 5d | 0d |  |
| 554 | 1.3.6.3.2.2 | Re-bar | 1d | 2011-09-28 | 2011-09-28 | 553 | 5d | 0d |  |
| 555 | 1.3.6.3.2.3 | Concrete | 1d | 2011-09-29 | 2011-09-29 | 554 | 5d |  |  |
| 556 | 1.3.6.4 | **Roof Slab** | 13d | 2011-10-05 | 2011-10-17 |  | 0d |  |  |
| 557 | 1.3.6.4.1 | Form Work | 5d | 2011-10-05 | 2011-10-09 | 534, 545, 555 | 0d |  |  |
| 558 | 1.3.6.4.2 | Re-bar | 4d | 2011-10-10 | 2011-10-13 | 557 | 0d |  |  |
| 559 | 1.3.6.4.3 | MEP Work | 1d | 2011-10-14 | 2011-10-14 | 558 | 0d |  |  |
| 560 | 1.3.6.4.4 | Inspection | 1d | 2011-10-15 | 2011-10-15 | 559 | 0d |  |  |
| 561 | 1.3.6.4.5 | Concrete | 2d | 2011-10-16 | 2011-10-17 | 560 | 0d |  |  |
| 562 | 1.3.7 | **6TH FLOOR** | 25d | 2011-10-18 | 2011-11-19 |  | 0d |  |  |
| 563 | 1.3.7.1 | **Column** | 12d | 2011-10-18 | 2011-10-29 |  | 0d |  | nos. |
| 564 | 1.3.7.1.1 | **1ST Lift** | 6d | 2011-10-18 | 2011-10-23 |  | 0d |  |  |
| 565 | 1.3.7.1.1.1 | Re-Bar Work | 1d | 2011-10-18 | 2011-10-18 | 561 | 0d |  |  |
| 566 | 1.3.7.1.1.2 | Form Work | 1d | 2011-10-19 | 2011-10-19 | 565 | 0d |  |  |
| 567 | 1.3.7.1.1.3 | Concrete | 1d | 2011-10-20 | 2011-10-20 | 566 | 0d |  |  |
| 568 | 1.3.7.1.1.4 | De-shuttering | 1d | 2011-10-23 | 2011-10-23 | 567FS+2d | 0d |  |  |

| ID | WBS | Task | Duration | Start | Finish | Predecessors | Total slack | Free slack | Text1 |
| --- | --- | --- | --- | --- | --- | --- | --- | --- | --- |
| 569 | 1.3.7.1.2 | **2nd Lift** | 6d | 2011-10-24 | 2011-10-29 |  | 0d |  |  |
| 570 | 1.3.7.1.2.1 | Re-Bar Work | 1d | 2011-10-24 | 2011-10-24 | 568 | 0d |  |  |
| 571 | 1.3.7.1.2.2 | Form Work | 1d | 2011-10-25 | 2011-10-25 | 570 | 0d |  |  |
| 572 | 1.3.7.1.2.3 | Concrete | 1d | 2011-10-26 | 2011-10-26 | 571 | 0d |  |  |
| 573 | 1.3.7.1.2.4 | De-shuttering | 1d | 2011-10-29 | 2011-10-29 | 572FS+2d | 0d |  |  |
| 574 | 1.3.7.2 | **Shear Wall** | 12d | 2011-10-18 | 2011-10-29 |  | 0d |  | nos. |
| 575 | 1.3.7.2.1 | **1st Lift** | 6d | 2011-10-18 | 2011-10-23 |  | 0d |  |  |
| 576 | 1.3.7.2.1.1 | Re-Bar Work | 1d | 2011-10-18 | 2011-10-18 | 561 | 0d |  |  |
| 577 | 1.3.7.2.1.2 | Form Work | 1d | 2011-10-19 | 2011-10-19 | 576 | 0d |  |  |
| 578 | 1.3.7.2.1.3 | Concrete | 1d | 2011-10-20 | 2011-10-20 | 577 | 0d |  |  |
| 579 | 1.3.7.2.1.4 | De-shuttering | 1d | 2011-10-23 | 2011-10-23 | 578FS+2d | 0d |  |  |
| 580 | 1.3.7.2.2 | **2nd Lift** | 6d | 2011-10-24 | 2011-10-29 |  | 0d |  |  |
| 581 | 1.3.7.2.2.1 | Re-Bar Work | 1d | 2011-10-24 | 2011-10-24 | 579 | 0d |  |  |
| 582 | 1.3.7.2.2.2 | Form Work | 1d | 2011-10-25 | 2011-10-25 | 581 | 0d |  |  |
| 583 | 1.3.7.2.2.3 | Concrete | 1d | 2011-10-26 | 2011-10-26 | 582 | 0d |  |  |
| 584 | 1.3.7.2.2.4 | De-shuttering | 1d | 2011-10-29 | 2011-10-29 | 583FS+2d | 0d |  |  |
| 585 | 1.3.7.3 | **Stair - 1 & 2** | 7d | 2011-10-18 | 2011-10-24 |  | 5d |  |  |
| 586 | 1.3.7.3.1 | **1st Flight** | 4d | 2011-10-18 | 2011-10-21 |  | 5d |  |  |
| 587 | 1.3.7.3.1.1 | Brick Work | 1d | 2011-10-18 | 2011-10-18 | 561 | 5d | 0d |  |
| 588 | 1.3.7.3.1.2 | Form Work | 1d | 2011-10-19 | 2011-10-19 | 587 | 5d | 0d |  |
| 589 | 1.3.7.3.1.3 | Re-bar Work | 1d | 2011-10-20 | 2011-10-20 | 588 | 5d | 0d |  |
| 590 | 1.3.7.3.1.4 | Concrete | 1d | 2011-10-21 | 2011-10-21 | 589 | 5d | 0d |  |
| 591 | 1.3.7.3.2 | **2nd Flight** | 3d | 2011-10-22 | 2011-10-24 |  | 5d |  |  |
| 592 | 1.3.7.3.2.1 | Form Work | 1d | 2011-10-22 | 2011-10-22 | 590 | 5d | 0d |  |
| 593 | 1.3.7.3.2.2 | Re-bar | 1d | 2011-10-23 | 2011-10-23 | 592 | 5d | 0d |  |
| 594 | 1.3.7.3.2.3 | Concrete | 1d | 2011-10-24 | 2011-10-24 | 593 | 5d |  |  |

| ID | WBS | Task | Duration | Start | Finish | Predecessors | Total slack | Text1 |
| --- | --- | --- | --- | --- | --- | --- | --- | --- |
| 595 | 1.3.7.4 | **Roof Slab** | 13d | 2011-10-30 | 2011-11-19 |  | 0d |  |
| 596 | 1.3.7.4.1 | Form Work | 5d | 2011-10-30 | 2011-11-03 | 573, 584, 594 | 0d |  |
| 597 | 1.3.7.4.2 | Re-bar | 4d | 2011-11-04 | 2011-11-07 | 596 | 0d |  |
| 598 | 1.3.7.4.3 | MEP Work | 1d | 2011-11-08 | 2011-11-08 | 597 | 0d |  |
| 599 | 1.3.7.4.4 | Inspection | 1d | 2011-11-09 | 2011-11-09 | 598 | 0d |  |
| 600 | 1.3.7.4.5 | Concrete | 2d | 2011-11-10 | 2011-11-19 | 599 | 0d |  |
| 601 | 1.3.8 | **7TH FLOOR** | 25d | 2011-11-20 | 2011-12-14 |  | 0d |  |
| 602 | 1.3.8.1 | **Column** | 12d | 2011-11-20 | 2011-12-01 |  | 0d | nos. |
| 603 | 1.3.8.1.1 | **1ST Lift** | 6d | 2011-11-20 | 2011-11-25 |  | 0d |  |
| 604 | 1.3.8.1.1.1 | Re-Bar Work | 1d | 2011-11-20 | 2011-11-20 | 600 | 0d |  |
| 605 | 1.3.8.1.1.2 | Form Work | 1d | 2011-11-21 | 2011-11-21 | 604 | 0d |  |
| 606 | 1.3.8.1.1.3 | Concrete | 1d | 2011-11-22 | 2011-11-22 | 605 | 0d |  |
| 607 | 1.3.8.1.1.4 | De-shuttering | 1d | 2011-11-25 | 2011-11-25 | 606FS+2d | 0d |  |
| 608 | 1.3.8.1.2 | **2nd Lift** | 6d | 2011-11-26 | 2011-12-01 |  | 0d |  |
| 609 | 1.3.8.1.2.1 | Re-Bar Work | 1d | 2011-11-26 | 2011-11-26 | 607 | 0d |  |
| 610 | 1.3.8.1.2.2 | Form Work | 1d | 2011-11-27 | 2011-11-27 | 609 | 0d |  |
| 611 | 1.3.8.1.2.3 | Concrete | 1d | 2011-11-28 | 2011-11-28 | 610 | 0d |  |
| 612 | 1.3.8.1.2.4 | De-shuttering | 1d | 2011-12-01 | 2011-12-01 | 611FS+2d | 0d |  |
| 613 | 1.3.8.2 | **Shear Wall** | 12d | 2011-11-20 | 2011-12-01 |  | 0d | nos. |
| 614 | 1.3.8.2.1 | **1st Lift** | 6d | 2011-11-20 | 2011-11-25 |  | 0d |  |
| 615 | 1.3.8.2.1.1 | Re-Bar Work | 1d | 2011-11-20 | 2011-11-20 | 600 | 0d |  |
| 616 | 1.3.8.2.1.2 | Form Work | 1d | 2011-11-21 | 2011-11-21 | 615 | 0d |  |
| 617 | 1.3.8.2.1.3 | Concrete | 1d | 2011-11-22 | 2011-11-22 | 616 | 0d |  |
| 618 | 1.3.8.2.1.4 | De-shuttering | 1d | 2011-11-25 | 2011-11-25 | 617FS+2d | 0d |  |

| ID | WBS | Task | Duration | Start | Finish | Predecessors | Total slack | Free slack | Text1 |
| --- | --- | --- | --- | --- | --- | --- | --- | --- | --- |
| 619 | 1.3.8.2.2 | **2nd Lift** | 6d | 2011-11-26 | 2011-12-01 |  | 0d |  |  |
| 620 | 1.3.8.2.2.1 | Re-Bar Work | 1d | 2011-11-26 | 2011-11-26 | 618 | 0d |  |  |
| 621 | 1.3.8.2.2.2 | Form Work | 1d | 2011-11-27 | 2011-11-27 | 620 | 0d |  |  |
| 622 | 1.3.8.2.2.3 | Concrete | 1d | 2011-11-28 | 2011-11-28 | 621 | 0d |  |  |
| 623 | 1.3.8.2.2.4 | De-shuttering | 1d | 2011-12-01 | 2011-12-01 | 622FS+2d | 0d |  |  |
| 624 | 1.3.8.3 | **Stair - 1 & 2** | 7d | 2011-11-20 | 2011-11-26 |  | 5d |  |  |
| 625 | 1.3.8.3.1 | **1st Flight** | 4d | 2011-11-20 | 2011-11-23 |  | 5d |  |  |
| 626 | 1.3.8.3.1.1 | Brick Work | 1d | 2011-11-20 | 2011-11-20 | 600 | 5d | 0d |  |
| 627 | 1.3.8.3.1.2 | Form Work | 1d | 2011-11-21 | 2011-11-21 | 626 | 5d | 0d |  |
| 628 | 1.3.8.3.1.3 | Re-bar Work | 1d | 2011-11-22 | 2011-11-22 | 627 | 5d | 0d |  |
| 629 | 1.3.8.3.1.4 | Concrete | 1d | 2011-11-23 | 2011-11-23 | 628 | 5d | 0d |  |
| 630 | 1.3.8.3.2 | **2nd Flight** | 3d | 2011-11-24 | 2011-11-26 |  | 5d |  |  |
| 631 | 1.3.8.3.2.1 | Form Work | 1d | 2011-11-24 | 2011-11-24 | 629 | 5d | 0d |  |
| 632 | 1.3.8.3.2.2 | Re-bar | 1d | 2011-11-25 | 2011-11-25 | 631 | 5d | 0d |  |
| 633 | 1.3.8.3.2.3 | Concrete | 1d | 2011-11-26 | 2011-11-26 | 632 | 5d |  |  |
| 634 | 1.3.8.4 | **Roof Slab** | 13d | 2011-12-02 | 2011-12-14 |  | 0d |  |  |
| 635 | 1.3.8.4.1 | Form Work | 5d | 2011-12-02 | 2011-12-06 | 612, 623, 633 | 0d |  |  |
| 636 | 1.3.8.4.2 | Re-bar | 4d | 2011-12-07 | 2011-12-10 | 635 | 0d |  |  |
| 637 | 1.3.8.4.3 | MEP Work | 1d | 2011-12-11 | 2011-12-11 | 636 | 0d |  |  |
| 638 | 1.3.8.4.4 | Inspection | 1d | 2011-12-12 | 2011-12-12 | 637 | 0d |  |  |
| 639 | 1.3.8.4.5 | Concrete | 2d | 2011-12-13 | 2011-12-14 | 638 | 0d |  |  |
| 640 | 1.3.9 | **8TH FLOOR** | 25d | 2011-12-15 | 2012-01-08 |  | 0d |  |  |
| 641 | 1.3.9.1 | **Column** | 12d | 2011-12-15 | 2011-12-26 |  | 0d |  | nos. |
| 642 | 1.3.9.1.1 | **1ST Lift** | 6d | 2011-12-15 | 2011-12-20 |  | 0d |  |  |
| 643 | 1.3.9.1.1.1 | Re-Bar Work | 1d | 2011-12-15 | 2011-12-15 | 639 | 0d |  |  |
| 644 | 1.3.9.1.1.2 | Form Work | 1d | 2011-12-16 | 2011-12-16 | 643 | 0d |  |  |
| 645 | 1.3.9.1.1.3 | Concrete | 1d | 2011-12-17 | 2011-12-17 | 644 | 0d |  |  |
| 646 | 1.3.9.1.1.4 | De-shuttering | 1d | 2011-12-20 | 2011-12-20 | 645FS+2d | 0d |  |  |

| ID | WBS | Task | Duration | Start | Finish | Predecessors | Total slack | Free slack | Text1 |
| --- | --- | --- | --- | --- | --- | --- | --- | --- | --- |
| 647 | 1.3.9.1.2 | **2nd Lift** | 6d | 2011-12-21 | 2011-12-26 |  | 0d |  |  |
| 648 | 1.3.9.1.2.1 | Re-Bar Work | 1d | 2011-12-21 | 2011-12-21 | 646 | 0d |  |  |
| 649 | 1.3.9.1.2.2 | Form Work | 1d | 2011-12-22 | 2011-12-22 | 648 | 0d |  |  |
| 650 | 1.3.9.1.2.3 | Concrete | 1d | 2011-12-23 | 2011-12-23 | 649 | 0d |  |  |
| 651 | 1.3.9.1.2.4 | De-shuttering | 1d | 2011-12-26 | 2011-12-26 | 650FS+2d | 0d |  |  |
| 652 | 1.3.9.2 | **Shear Wall** | 12d | 2011-12-15 | 2011-12-26 |  | 0d |  | nos. |
| 653 | 1.3.9.2.1 | **1st Lift** | 6d | 2011-12-15 | 2011-12-20 |  | 0d |  |  |
| 654 | 1.3.9.2.1.1 | Re-Bar Work | 1d | 2011-12-15 | 2011-12-15 | 639 | 0d |  |  |
| 655 | 1.3.9.2.1.2 | Form Work | 1d | 2011-12-16 | 2011-12-16 | 654 | 0d |  |  |
| 656 | 1.3.9.2.1.3 | Concrete | 1d | 2011-12-17 | 2011-12-17 | 655 | 0d |  |  |
| 657 | 1.3.9.2.1.4 | De-shuttering | 1d | 2011-12-20 | 2011-12-20 | 656FS+2d | 0d |  |  |
| 658 | 1.3.9.2.2 | **2nd Lift** | 6d | 2011-12-21 | 2011-12-26 |  | 0d |  |  |
| 659 | 1.3.9.2.2.1 | Re-Bar Work | 1d | 2011-12-21 | 2011-12-21 | 657 | 0d |  |  |
| 660 | 1.3.9.2.2.2 | Form Work | 1d | 2011-12-22 | 2011-12-22 | 659 | 0d |  |  |
| 661 | 1.3.9.2.2.3 | Concrete | 1d | 2011-12-23 | 2011-12-23 | 660 | 0d |  |  |
| 662 | 1.3.9.2.2.4 | De-shuttering | 1d | 2011-12-26 | 2011-12-26 | 661FS+2d | 0d |  |  |
| 663 | 1.3.9.3 | **Stair - 1 & 2** | 7d | 2011-12-15 | 2011-12-21 |  | 5d |  |  |
| 664 | 1.3.9.3.1 | **1st Flight** | 4d | 2011-12-15 | 2011-12-18 |  | 5d |  |  |
| 665 | 1.3.9.3.1.1 | Brick Work | 1d | 2011-12-15 | 2011-12-15 | 639 | 5d | 0d |  |
| 666 | 1.3.9.3.1.2 | Form Work | 1d | 2011-12-16 | 2011-12-16 | 665 | 5d | 0d |  |
| 667 | 1.3.9.3.1.3 | Re-bar Work | 1d | 2011-12-17 | 2011-12-17 | 666 | 5d | 0d |  |
| 668 | 1.3.9.3.1.4 | Concrete | 1d | 2011-12-18 | 2011-12-18 | 667 | 5d | 0d |  |
| 669 | 1.3.9.3.2 | **2nd Flight** | 3d | 2011-12-19 | 2011-12-21 |  | 5d |  |  |
| 670 | 1.3.9.3.2.1 | Form Work | 1d | 2011-12-19 | 2011-12-19 | 668 | 5d | 0d |  |
| 671 | 1.3.9.3.2.2 | Re-bar | 1d | 2011-12-20 | 2011-12-20 | 670 | 5d | 0d |  |
| 672 | 1.3.9.3.2.3 | Concrete | 1d | 2011-12-21 | 2011-12-21 | 671 | 5d |  |  |

| ID | WBS | Task | Duration | Start | Finish | Predecessors | Total slack | Text1 |
| --- | --- | --- | --- | --- | --- | --- | --- | --- |
| 673 | 1.3.9.4 | **Roof Slab** | 13d | 2011-12-27 | 2012-01-08 |  | 0d |  |
| 674 | 1.3.9.4.1 | Form Work | 5d | 2011-12-27 | 2011-12-31 | 651, 662, 672 | 0d |  |
| 675 | 1.3.9.4.2 | Re-bar | 4d | 2012-01-01 | 2012-01-04 | 674 | 0d |  |
| 676 | 1.3.9.4.3 | MEP Work | 1d | 2012-01-05 | 2012-01-05 | 675 | 0d |  |
| 677 | 1.3.9.4.4 | Inspection | 1d | 2012-01-06 | 2012-01-06 | 676 | 0d |  |
| 678 | 1.3.9.4.5 | Concrete | 2d | 2012-01-07 | 2012-01-08 | 677 | 0d |  |
| 679 | 1.3.10 | **9TH FLOOR** | 25d | 2012-01-09 | 2012-02-02 |  | 0d |  |
| 680 | 1.3.10.1 | **Column** | 12d | 2012-01-09 | 2012-01-20 |  | 0d | nos. |
| 681 | 1.3.10.1.1 | **1ST Lift** | 6d | 2012-01-09 | 2012-01-14 |  | 0d |  |
| 682 | 1.3.10.1.1.1 | Re-Bar Work | 1d | 2012-01-09 | 2012-01-09 | 678 | 0d |  |
| 683 | 1.3.10.1.1.2 | Form Work | 1d | 2012-01-10 | 2012-01-10 | 682 | 0d |  |
| 684 | 1.3.10.1.1.3 | Concrete | 1d | 2012-01-11 | 2012-01-11 | 683 | 0d |  |
| 685 | 1.3.10.1.1.4 | De-shuttering | 1d | 2012-01-14 | 2012-01-14 | 684FS+2d | 0d |  |
| 686 | 1.3.10.1.2 | **2nd Lift** | 6d | 2012-01-15 | 2012-01-20 |  | 0d |  |
| 687 | 1.3.10.1.2.1 | Re-Bar Work | 1d | 2012-01-15 | 2012-01-15 | 685 | 0d |  |
| 688 | 1.3.10.1.2.2 | Form Work | 1d | 2012-01-16 | 2012-01-16 | 687 | 0d |  |
| 689 | 1.3.10.1.2.3 | Concrete | 1d | 2012-01-17 | 2012-01-17 | 688 | 0d |  |
| 690 | 1.3.10.1.2.4 | De-shuttering | 1d | 2012-01-20 | 2012-01-20 | 689FS+2d | 0d |  |
| 691 | 1.3.10.2 | **Shear Wall** | 12d | 2012-01-09 | 2012-01-20 |  | 0d | nos. |
| 692 | 1.3.10.2.1 | **1st Lift** | 6d | 2012-01-09 | 2012-01-14 |  | 0d |  |
| 693 | 1.3.10.2.1.1 | Re-Bar Work | 1d | 2012-01-09 | 2012-01-09 | 678 | 0d |  |
| 694 | 1.3.10.2.1.2 | Form Work | 1d | 2012-01-10 | 2012-01-10 | 693 | 0d |  |
| 695 | 1.3.10.2.1.3 | Concrete | 1d | 2012-01-11 | 2012-01-11 | 694 | 0d |  |
| 696 | 1.3.10.2.1.4 | De-shuttering | 1d | 2012-01-14 | 2012-01-14 | 695FS+2d | 0d |  |

| ID | WBS | Task | Duration | Start | Finish | Predecessors | Total slack | Free slack | Text1 |
| --- | --- | --- | --- | --- | --- | --- | --- | --- | --- |
| 697 | 1.3.10.2.2 | **2nd Lift** | 6d | 2012-01-15 | 2012-01-20 |  | 0d |  |  |
| 698 | 1.3.10.2.2.1 | Re-Bar Work | 1d | 2012-01-15 | 2012-01-15 | 696 | 0d |  |  |
| 699 | 1.3.10.2.2.2 | Form Work | 1d | 2012-01-16 | 2012-01-16 | 698 | 0d |  |  |
| 700 | 1.3.10.2.2.3 | Concrete | 1d | 2012-01-17 | 2012-01-17 | 699 | 0d |  |  |
| 701 | 1.3.10.2.2.4 | De-shuttering | 1d | 2012-01-20 | 2012-01-20 | 700FS+2d | 0d |  |  |
| 702 | 1.3.10.3 | **Stair - 1 & 2** | 7d | 2012-01-09 | 2012-01-15 |  | 5d |  |  |
| 703 | 1.3.10.3.1 | **1st Flight** | 4d | 2012-01-09 | 2012-01-12 |  | 5d |  |  |
| 704 | 1.3.10.3.1.1 | Brick Work | 1d | 2012-01-09 | 2012-01-09 | 678 | 5d | 0d |  |
| 705 | 1.3.10.3.1.2 | Form Work | 1d | 2012-01-10 | 2012-01-10 | 704 | 5d | 0d |  |
| 706 | 1.3.10.3.1.3 | Re-bar Work | 1d | 2012-01-11 | 2012-01-11 | 705 | 5d | 0d |  |
| 707 | 1.3.10.3.1.4 | Concrete | 1d | 2012-01-12 | 2012-01-12 | 706 | 5d | 0d |  |
| 708 | 1.3.10.3.2 | **2nd Flight** | 3d | 2012-01-13 | 2012-01-15 |  | 5d |  |  |
| 709 | 1.3.10.3.2.1 | Form Work | 1d | 2012-01-13 | 2012-01-13 | 707 | 5d | 0d |  |
| 710 | 1.3.10.3.2.2 | Re-bar | 1d | 2012-01-14 | 2012-01-14 | 709 | 5d | 0d |  |
| 711 | 1.3.10.3.2.3 | Concrete | 1d | 2012-01-15 | 2012-01-15 | 710 | 5d |  |  |
| 712 | 1.3.10.4 | **Roof Slab** | 13d | 2012-01-21 | 2012-02-02 |  | 0d |  |  |
| 713 | 1.3.10.4.1 | Form Work | 5d | 2012-01-21 | 2012-01-25 | 690, 701, 711 | 0d |  |  |
| 714 | 1.3.10.4.2 | Re-bar | 4d | 2012-01-26 | 2012-01-29 | 713 | 0d |  |  |
| 715 | 1.3.10.4.3 | MEP Work | 1d | 2012-01-30 | 2012-01-30 | 714 | 0d |  |  |
| 716 | 1.3.10.4.4 | Inspection | 1d | 2012-01-31 | 2012-01-31 | 715 | 0d |  |  |
| 717 | 1.3.10.4.5 | Concrete | 2d | 2012-02-01 | 2012-02-02 | 716 | 0d |  |  |
| 718 | 1.3.11 | **10TH FLOOR** | 25d | 2012-02-03 | 2012-02-27 |  | 0d |  |  |
| 719 | 1.3.11.1 | **Column** | 12d | 2012-02-03 | 2012-02-14 |  | 0d |  | nos. |
| 720 | 1.3.11.1.1 | **1ST Lift** | 6d | 2012-02-03 | 2012-02-08 |  | 0d |  |  |
| 721 | 1.3.11.1.1.1 | Re-Bar Work | 1d | 2012-02-03 | 2012-02-03 | 717 | 0d |  |  |
| 722 | 1.3.11.1.1.2 | Form Work | 1d | 2012-02-04 | 2012-02-04 | 721 | 0d |  |  |
| 723 | 1.3.11.1.1.3 | Concrete | 1d | 2012-02-05 | 2012-02-05 | 722 | 0d |  |  |
| 724 | 1.3.11.1.1.4 | De-shuttering | 1d | 2012-02-08 | 2012-02-08 | 723FS+2d | 0d |  |  |

| ID | WBS | Task | Duration | Start | Finish | Predecessors | Total slack | Free slack | Text1 |
| --- | --- | --- | --- | --- | --- | --- | --- | --- | --- |
| 725 | 1.3.11.1.2 | **2nd Lift** | 6d | 2012-02-09 | 2012-02-14 |  | 0d |  |  |
| 726 | 1.3.11.1.2.1 | Re-Bar Work | 1d | 2012-02-09 | 2012-02-09 | 724 | 0d |  |  |
| 727 | 1.3.11.1.2.2 | Form Work | 1d | 2012-02-10 | 2012-02-10 | 726 | 0d |  |  |
| 728 | 1.3.11.1.2.3 | Concrete | 1d | 2012-02-11 | 2012-02-11 | 727 | 0d |  |  |
| 729 | 1.3.11.1.2.4 | De-shuttering | 1d | 2012-02-14 | 2012-02-14 | 728FS+2d | 0d |  |  |
| 730 | 1.3.11.2 | **Shear Wall** | 12d | 2012-02-03 | 2012-02-14 |  | 0d |  | nos. |
| 731 | 1.3.11.2.1 | **1st Lift** | 6d | 2012-02-03 | 2012-02-08 |  | 0d |  |  |
| 732 | 1.3.11.2.1.1 | Re-Bar Work | 1d | 2012-02-03 | 2012-02-03 | 717 | 0d |  |  |
| 733 | 1.3.11.2.1.2 | Form Work | 1d | 2012-02-04 | 2012-02-04 | 732 | 0d |  |  |
| 734 | 1.3.11.2.1.3 | Concrete | 1d | 2012-02-05 | 2012-02-05 | 733 | 0d |  |  |
| 735 | 1.3.11.2.1.4 | De-shuttering | 1d | 2012-02-08 | 2012-02-08 | 734FS+2d | 0d |  |  |
| 736 | 1.3.11.2.2 | **2nd Lift** | 6d | 2012-02-09 | 2012-02-14 |  | 0d |  |  |
| 737 | 1.3.11.2.2.1 | Re-Bar Work | 1d | 2012-02-09 | 2012-02-09 | 735 | 0d |  |  |
| 738 | 1.3.11.2.2.2 | Form Work | 1d | 2012-02-10 | 2012-02-10 | 737 | 0d |  |  |
| 739 | 1.3.11.2.2.3 | Concrete | 1d | 2012-02-11 | 2012-02-11 | 738 | 0d |  |  |
| 740 | 1.3.11.2.2.4 | De-shuttering | 1d | 2012-02-14 | 2012-02-14 | 739FS+2d | 0d |  |  |
| 741 | 1.3.11.3 | **Stair - 1 & 2** | 7d | 2012-02-03 | 2012-02-09 |  | 5d |  |  |
| 742 | 1.3.11.3.1 | **1st Flight** | 4d | 2012-02-03 | 2012-02-06 |  | 5d |  |  |
| 743 | 1.3.11.3.1.1 | Brick Work | 1d | 2012-02-03 | 2012-02-03 | 717 | 5d | 0d |  |
| 744 | 1.3.11.3.1.2 | Form Work | 1d | 2012-02-04 | 2012-02-04 | 743 | 5d | 0d |  |
| 745 | 1.3.11.3.1.3 | Re-bar Work | 1d | 2012-02-05 | 2012-02-05 | 744 | 5d | 0d |  |
| 746 | 1.3.11.3.1.4 | Concrete | 1d | 2012-02-06 | 2012-02-06 | 745 | 5d | 0d |  |
| 747 | 1.3.11.3.2 | **2nd Flight** | 3d | 2012-02-07 | 2012-02-09 |  | 5d |  |  |
| 748 | 1.3.11.3.2.1 | Form Work | 1d | 2012-02-07 | 2012-02-07 | 746 | 5d | 0d |  |
| 749 | 1.3.11.3.2.2 | Re-bar | 1d | 2012-02-08 | 2012-02-08 | 748 | 5d | 0d |  |
| 750 | 1.3.11.3.2.3 | Concrete | 1d | 2012-02-09 | 2012-02-09 | 749 | 5d |  |  |

| ID | WBS | Task | Duration | Start | Finish | Predecessors | Total slack | Text1 |
| --- | --- | --- | --- | --- | --- | --- | --- | --- |
| 751 | 1.3.11.4 | **Roof Slab** | 13d | 2012-02-15 | 2012-02-27 |  | 0d |  |
| 752 | 1.3.11.4.1 | Form Work | 5d | 2012-02-15 | 2012-02-19 | 729, 740, 750 | 0d |  |
| 753 | 1.3.11.4.2 | Re-bar | 4d | 2012-02-20 | 2012-02-23 | 752 | 0d |  |
| 754 | 1.3.11.4.3 | MEP Work | 1d | 2012-02-24 | 2012-02-24 | 753 | 0d |  |
| 755 | 1.3.11.4.4 | Inspection | 1d | 2012-02-25 | 2012-02-25 | 754 | 0d |  |
| 756 | 1.3.11.4.5 | Concrete | 2d | 2012-02-26 | 2012-02-27 | 755 | 0d |  |
| 757 | 1.3.12 | **11TH FLOOR** | 25d | 2012-02-28 | 2012-03-23 |  | 0d |  |
| 758 | 1.3.12.1 | **Column** | 12d | 2012-02-28 | 2012-03-10 |  | 0d | nos. |
| 759 | 1.3.12.1.1 | **1ST Lift** | 6d | 2012-02-28 | 2012-03-04 |  | 0d |  |
| 760 | 1.3.12.1.1.1 | Re-Bar Work | 1d | 2012-02-28 | 2012-02-28 | 756 | 0d |  |
| 761 | 1.3.12.1.1.2 | Form Work | 1d | 2012-02-29 | 2012-02-29 | 760 | 0d |  |
| 762 | 1.3.12.1.1.3 | Concrete | 1d | 2012-03-01 | 2012-03-01 | 761 | 0d |  |
| 763 | 1.3.12.1.1.4 | De-shuttering | 1d | 2012-03-04 | 2012-03-04 | 762FS+2d | 0d |  |
| 764 | 1.3.12.1.2 | **2nd Lift** | 6d | 2012-03-05 | 2012-03-10 |  | 0d |  |
| 765 | 1.3.12.1.2.1 | Re-Bar Work | 1d | 2012-03-05 | 2012-03-05 | 763 | 0d |  |
| 766 | 1.3.12.1.2.2 | Form Work | 1d | 2012-03-06 | 2012-03-06 | 765 | 0d |  |
| 767 | 1.3.12.1.2.3 | Concrete | 1d | 2012-03-07 | 2012-03-07 | 766 | 0d |  |
| 768 | 1.3.12.1.2.4 | De-shuttering | 1d | 2012-03-10 | 2012-03-10 | 767FS+2d | 0d |  |
| 769 | 1.3.12.2 | **Shear Wall** | 12d | 2012-02-28 | 2012-03-10 |  | 0d | nos. |
| 770 | 1.3.12.2.1 | **1st Lift** | 6d | 2012-02-28 | 2012-03-04 |  | 0d |  |
| 771 | 1.3.12.2.1.1 | Re-Bar Work | 1d | 2012-02-28 | 2012-02-28 | 756 | 0d |  |
| 772 | 1.3.12.2.1.2 | Form Work | 1d | 2012-02-29 | 2012-02-29 | 771 | 0d |  |
| 773 | 1.3.12.2.1.3 | Concrete | 1d | 2012-03-01 | 2012-03-01 | 772 | 0d |  |
| 774 | 1.3.12.2.1.4 | De-shuttering | 1d | 2012-03-04 | 2012-03-04 | 773FS+2d | 0d |  |

| ID | WBS | Task | Duration | Start | Finish | Predecessors | Total slack | Free slack | Text1 |
| --- | --- | --- | --- | --- | --- | --- | --- | --- | --- |
| 775 | 1.3.12.2.2 | **2nd Lift** | 6d | 2012-03-05 | 2012-03-10 |  | 0d |  |  |
| 776 | 1.3.12.2.2.1 | Re-Bar Work | 1d | 2012-03-05 | 2012-03-05 | 774 | 0d |  |  |
| 777 | 1.3.12.2.2.2 | Form Work | 1d | 2012-03-06 | 2012-03-06 | 776 | 0d |  |  |
| 778 | 1.3.12.2.2.3 | Concrete | 1d | 2012-03-07 | 2012-03-07 | 777 | 0d |  |  |
| 779 | 1.3.12.2.2.4 | De-shuttering | 1d | 2012-03-10 | 2012-03-10 | 778FS+2d | 0d |  |  |
| 780 | 1.3.12.3 | **Stair - 1 & 2** | 7d | 2012-02-28 | 2012-03-05 |  | 5d |  |  |
| 781 | 1.3.12.3.1 | **1st Flight** | 4d | 2012-02-28 | 2012-03-02 |  | 5d |  |  |
| 782 | 1.3.12.3.1.1 | Brick Work | 1d | 2012-02-28 | 2012-02-28 | 756 | 5d | 0d |  |
| 783 | 1.3.12.3.1.2 | Form Work | 1d | 2012-02-29 | 2012-02-29 | 782 | 5d | 0d |  |
| 784 | 1.3.12.3.1.3 | Re-bar Work | 1d | 2012-03-01 | 2012-03-01 | 783 | 5d | 0d |  |
| 785 | 1.3.12.3.1.4 | Concrete | 1d | 2012-03-02 | 2012-03-02 | 784 | 5d | 0d |  |
| 786 | 1.3.12.3.2 | **2nd Flight** | 3d | 2012-03-03 | 2012-03-05 |  | 5d |  |  |
| 787 | 1.3.12.3.2.1 | Form Work | 1d | 2012-03-03 | 2012-03-03 | 785 | 5d | 0d |  |
| 788 | 1.3.12.3.2.2 | Re-bar | 1d | 2012-03-04 | 2012-03-04 | 787 | 5d | 0d |  |
| 789 | 1.3.12.3.2.3 | Concrete | 1d | 2012-03-05 | 2012-03-05 | 788 | 5d |  |  |
| 790 | 1.3.12.4 | **Roof Slab** | 13d | 2012-03-11 | 2012-03-23 |  | 0d |  |  |
| 791 | 1.3.12.4.1 | Form Work | 5d | 2012-03-11 | 2012-03-15 | 768, 779, 789 | 0d |  |  |
| 792 | 1.3.12.4.2 | Re-bar | 4d | 2012-03-16 | 2012-03-19 | 791 | 0d |  |  |
| 793 | 1.3.12.4.3 | MEP Work | 1d | 2012-03-20 | 2012-03-20 | 792 | 0d |  |  |
| 794 | 1.3.12.4.4 | Inspection | 1d | 2012-03-21 | 2012-03-21 | 793 | 0d |  |  |
| 795 | 1.3.12.4.5 | Concrete | 2d | 2012-03-22 | 2012-03-23 | 794 | 0d |  |  |
| 796 | 1.3.13 | **12TH FLOOR** | 25d | 2012-03-24 | 2012-04-17 |  | 0d |  |  |
| 797 | 1.3.13.1 | **Column** | 12d | 2012-03-24 | 2012-04-04 |  | 0d |  | nos. |
| 798 | 1.3.13.1.1 | **1ST Lift** | 6d | 2012-03-24 | 2012-03-29 |  | 0d |  |  |
| 799 | 1.3.13.1.1.1 | Re-Bar Work | 1d | 2012-03-24 | 2012-03-24 | 795 | 0d |  |  |
| 800 | 1.3.13.1.1.2 | Form Work | 1d | 2012-03-25 | 2012-03-25 | 799 | 0d |  |  |
| 801 | 1.3.13.1.1.3 | Concrete | 1d | 2012-03-26 | 2012-03-26 | 800 | 0d |  |  |
| 802 | 1.3.13.1.1.4 | De-shuttering | 1d | 2012-03-29 | 2012-03-29 | 801FS+2d | 0d |  |  |

| ID | WBS | Task | Duration | Start | Finish | Predecessors | Total slack | Free slack | Text1 |
| --- | --- | --- | --- | --- | --- | --- | --- | --- | --- |
| 803 | 1.3.13.1.2 | **2nd Lift** | 6d | 2012-03-30 | 2012-04-04 |  | 0d |  |  |
| 804 | 1.3.13.1.2.1 | Re-Bar Work | 1d | 2012-03-30 | 2012-03-30 | 802 | 0d |  |  |
| 805 | 1.3.13.1.2.2 | Form Work | 1d | 2012-03-31 | 2012-03-31 | 804 | 0d |  |  |
| 806 | 1.3.13.1.2.3 | Concrete | 1d | 2012-04-01 | 2012-04-01 | 805 | 0d |  |  |
| 807 | 1.3.13.1.2.4 | De-shuttering | 1d | 2012-04-04 | 2012-04-04 | 806FS+2d | 0d |  |  |
| 808 | 1.3.13.2 | **Shear Wall** | 12d | 2012-03-24 | 2012-04-04 |  | 0d |  | nos. |
| 809 | 1.3.13.2.1 | **1st Lift** | 6d | 2012-03-24 | 2012-03-29 |  | 0d |  |  |
| 810 | 1.3.13.2.1.1 | Re-Bar Work | 1d | 2012-03-24 | 2012-03-24 | 795 | 0d |  |  |
| 811 | 1.3.13.2.1.2 | Form Work | 1d | 2012-03-25 | 2012-03-25 | 810 | 0d |  |  |
| 812 | 1.3.13.2.1.3 | Concrete | 1d | 2012-03-26 | 2012-03-26 | 811 | 0d |  |  |
| 813 | 1.3.13.2.1.4 | De-shuttering | 1d | 2012-03-29 | 2012-03-29 | 812FS+2d | 0d |  |  |
| 814 | 1.3.13.2.2 | **2nd Lift** | 6d | 2012-03-30 | 2012-04-04 |  | 0d |  |  |
| 815 | 1.3.13.2.2.1 | Re-Bar Work | 1d | 2012-03-30 | 2012-03-30 | 813 | 0d |  |  |
| 816 | 1.3.13.2.2.2 | Form Work | 1d | 2012-03-31 | 2012-03-31 | 815 | 0d |  |  |
| 817 | 1.3.13.2.2.3 | Concrete | 1d | 2012-04-01 | 2012-04-01 | 816 | 0d |  |  |
| 818 | 1.3.13.2.2.4 | De-shuttering | 1d | 2012-04-04 | 2012-04-04 | 817FS+2d | 0d |  |  |
| 819 | 1.3.13.3 | **Stair - 1 & 2** | 7d | 2012-03-24 | 2012-03-30 |  | 5d |  |  |
| 820 | 1.3.13.3.1 | **1st Flight** | 4d | 2012-03-24 | 2012-03-27 |  | 5d |  |  |
| 821 | 1.3.13.3.1.1 | Brick Work | 1d | 2012-03-24 | 2012-03-24 | 795 | 5d | 0d |  |
| 822 | 1.3.13.3.1.2 | Form Work | 1d | 2012-03-25 | 2012-03-25 | 821 | 5d | 0d |  |
| 823 | 1.3.13.3.1.3 | Re-bar Work | 1d | 2012-03-26 | 2012-03-26 | 822 | 5d | 0d |  |
| 824 | 1.3.13.3.1.4 | Concrete | 1d | 2012-03-27 | 2012-03-27 | 823 | 5d | 0d |  |
| 825 | 1.3.13.3.2 | **2nd Flight** | 3d | 2012-03-28 | 2012-03-30 |  | 5d |  |  |
| 826 | 1.3.13.3.2.1 | Form Work | 1d | 2012-03-28 | 2012-03-28 | 824 | 5d | 0d |  |
| 827 | 1.3.13.3.2.2 | Re-bar | 1d | 2012-03-29 | 2012-03-29 | 826 | 5d | 0d |  |
| 828 | 1.3.13.3.2.3 | Concrete | 1d | 2012-03-30 | 2012-03-30 | 827 | 5d |  |  |

| ID | WBS | Task | Duration | Start | Finish | Predecessors | Total slack | Text1 |
| --- | --- | --- | --- | --- | --- | --- | --- | --- |
| 829 | 1.3.13.4 | **Roof Slab** | 13d | 2012-04-05 | 2012-04-17 |  | 0d |  |
| 830 | 1.3.13.4.1 | Form Work | 5d | 2012-04-05 | 2012-04-09 | 807, 818, 828 | 0d |  |
| 831 | 1.3.13.4.2 | Re-bar | 4d | 2012-04-10 | 2012-04-13 | 830 | 0d |  |
| 832 | 1.3.13.4.3 | MEP Work | 1d | 2012-04-14 | 2012-04-14 | 831 | 0d |  |
| 833 | 1.3.13.4.4 | Inspection | 1d | 2012-04-15 | 2012-04-15 | 832 | 0d |  |
| 834 | 1.3.13.4.5 | Concrete | 2d | 2012-04-16 | 2012-04-17 | 833 | 0d |  |
| 835 | 1.3.14 | **13TH FLOOR** | 25d | 2012-04-18 | 2012-05-12 |  | 0d |  |
| 836 | 1.3.14.1 | **Column** | 12d | 2012-04-18 | 2012-04-29 |  | 0d | nos. |
| 837 | 1.3.14.1.1 | **1ST Lift** | 6d | 2012-04-18 | 2012-04-23 |  | 0d |  |
| 838 | 1.3.14.1.1.1 | Re-Bar Work | 1d | 2012-04-18 | 2012-04-18 | 834 | 0d |  |
| 839 | 1.3.14.1.1.2 | Form Work | 1d | 2012-04-19 | 2012-04-19 | 838 | 0d |  |
| 840 | 1.3.14.1.1.3 | Concrete | 1d | 2012-04-20 | 2012-04-20 | 839 | 0d |  |
| 841 | 1.3.14.1.1.4 | De-shuttering | 1d | 2012-04-23 | 2012-04-23 | 840FS+2d | 0d |  |
| 842 | 1.3.14.1.2 | **2nd Lift** | 6d | 2012-04-24 | 2012-04-29 |  | 0d |  |
| 843 | 1.3.14.1.2.1 | Re-Bar Work | 1d | 2012-04-24 | 2012-04-24 | 841 | 0d |  |
| 844 | 1.3.14.1.2.2 | Form Work | 1d | 2012-04-25 | 2012-04-25 | 843 | 0d |  |
| 845 | 1.3.14.1.2.3 | Concrete | 1d | 2012-04-26 | 2012-04-26 | 844 | 0d |  |
| 846 | 1.3.14.1.2.4 | De-shuttering | 1d | 2012-04-29 | 2012-04-29 | 845FS+2d | 0d |  |
| 847 | 1.3.14.2 | **Shear Wall** | 12d | 2012-04-18 | 2012-04-29 |  | 0d | nos. |
| 848 | 1.3.14.2.1 | **1st Lift** | 6d | 2012-04-18 | 2012-04-23 |  | 0d |  |
| 849 | 1.3.14.2.1.1 | Re-Bar Work | 1d | 2012-04-18 | 2012-04-18 | 834 | 0d |  |
| 850 | 1.3.14.2.1.2 | Form Work | 1d | 2012-04-19 | 2012-04-19 | 849 | 0d |  |
| 851 | 1.3.14.2.1.3 | Concrete | 1d | 2012-04-20 | 2012-04-20 | 850 | 0d |  |
| 852 | 1.3.14.2.1.4 | De-shuttering | 1d | 2012-04-23 | 2012-04-23 | 851FS+2d | 0d |  |

| ID | WBS | Task | Duration | Start | Finish | Predecessors | Total slack | Free slack | Text1 |
| --- | --- | --- | --- | --- | --- | --- | --- | --- | --- |
| 853 | 1.3.14.2.2 | **2nd Lift** | 6d | 2012-04-24 | 2012-04-29 |  | 0d |  |  |
| 854 | 1.3.14.2.2.1 | Re-Bar Work | 1d | 2012-04-24 | 2012-04-24 | 852 | 0d |  |  |
| 855 | 1.3.14.2.2.2 | Form Work | 1d | 2012-04-25 | 2012-04-25 | 854 | 0d |  |  |
| 856 | 1.3.14.2.2.3 | Concrete | 1d | 2012-04-26 | 2012-04-26 | 855 | 0d |  |  |
| 857 | 1.3.14.2.2.4 | De-shuttering | 1d | 2012-04-29 | 2012-04-29 | 856FS+2d | 0d |  |  |
| 858 | 1.3.14.3 | **Stair - 1 & 2** | 7d | 2012-04-18 | 2012-04-24 |  | 5d |  |  |
| 859 | 1.3.14.3.1 | **1st Flight** | 4d | 2012-04-18 | 2012-04-21 |  | 5d |  |  |
| 860 | 1.3.14.3.1.1 | Brick Work | 1d | 2012-04-18 | 2012-04-18 | 834 | 5d | 0d |  |
| 861 | 1.3.14.3.1.2 | Form Work | 1d | 2012-04-19 | 2012-04-19 | 860 | 5d | 0d |  |
| 862 | 1.3.14.3.1.3 | Re-bar Work | 1d | 2012-04-20 | 2012-04-20 | 861 | 5d | 0d |  |
| 863 | 1.3.14.3.1.4 | Concrete | 1d | 2012-04-21 | 2012-04-21 | 862 | 5d | 0d |  |
| 864 | 1.3.14.3.2 | **2nd Flight** | 3d | 2012-04-22 | 2012-04-24 |  | 5d |  |  |
| 865 | 1.3.14.3.2.1 | Form Work | 1d | 2012-04-22 | 2012-04-22 | 863 | 5d | 0d |  |
| 866 | 1.3.14.3.2.2 | Re-bar | 1d | 2012-04-23 | 2012-04-23 | 865 | 5d | 0d |  |
| 867 | 1.3.14.3.2.3 | Concrete | 1d | 2012-04-24 | 2012-04-24 | 866 | 5d |  |  |
| 868 | 1.3.14.4 | **Roof Slab** | 13d | 2012-04-30 | 2012-05-12 |  | 0d |  |  |
| 869 | 1.3.14.4.1 | Form Work | 5d | 2012-04-30 | 2012-05-04 | 846, 857, 867 | 0d |  |  |
| 870 | 1.3.14.4.2 | Re-bar | 4d | 2012-05-05 | 2012-05-08 | 869 | 0d |  |  |
| 871 | 1.3.14.4.3 | MEP Work | 1d | 2012-05-09 | 2012-05-09 | 870 | 0d |  |  |
| 872 | 1.3.14.4.4 | Inspection | 1d | 2012-05-10 | 2012-05-10 | 871 | 0d |  |  |
| 873 | 1.3.14.4.5 | Concrete | 2d | 2012-05-11 | 2012-05-12 | 872 | 0d |  |  |
| 874 | 1.3.15 | **MACHINE FLOOR** | 20d | 2012-05-13 | 2012-06-01 |  | 0d |  |  |
| 875 | 1.3.15.1 | **Column** | 12d | 2012-05-13 | 2012-05-24 |  | 0d |  | nos. |
| 876 | 1.3.15.1.1 | **1st Lift** | 6d | 2012-05-13 | 2012-05-18 | 873 | 0d |  |  |
| 877 | 1.3.15.1.1.1 | Re-Bar Work | 1d | 2012-05-13 | 2012-05-13 |  | 0d |  |  |
| 878 | 1.3.15.1.1.2 | Form Work | 1d | 2012-05-14 | 2012-05-14 | 877 | 0d |  |  |
| 879 | 1.3.15.1.1.3 | Concrete | 1d | 2012-05-15 | 2012-05-15 | 878 | 0d |  |  |
| 880 | 1.3.15.1.1.4 | De-shuttering | 1d | 2012-05-18 | 2012-05-18 | 879FS+2d | 0d |  |  |

| ID | WBS | Task | Duration | Start | Finish | Predecessors | Total slack | Free slack |
| --- | --- | --- | --- | --- | --- | --- | --- | --- |
| 881 | 1.3.15.1.2 | **2nd Lift** | 6d | 2012-05-19 | 2012-05-24 |  | 102d |  |
| 882 | 1.3.15.1.2.1 | Re-Bar Work | 1d | 2012-05-19 | 2012-05-19 | 880 | 102d | 0d |
| 883 | 1.3.15.1.2.2 | Form Work | 1d | 2012-05-20 | 2012-05-20 | 882 | 102d | 0d |
| 884 | 1.3.15.1.2.3 | Concrete | 1d | 2012-05-21 | 2012-05-21 | 883 | 102d | 0d |
| 885 | 1.3.15.1.2.4 | De-shuttering | 1d | 2012-05-24 | 2012-05-24 | 884FS+2d | 102d |  |
| 886 | 1.3.15.2 | Brcik Work upto M/c Room Bot Slab | 1d | 2012-05-13 | 2012-05-13 | 873 | 5d |  |
| 887 | 1.3.15.3 | **M/c Room Bottom Slab** | 3d | 2012-05-19 | 2012-05-21 |  | 0d |  |
| 888 | 1.3.15.3.1 | Form work | 1d | 2012-05-19 | 2012-05-19 | 886, 880 | 0d |  |
| 889 | 1.3.15.3.2 | Re-bar | 1d | 2012-05-20 | 2012-05-20 | 888 | 0d |  |
| 890 | 1.3.15.3.3 | Concrete | 1d | 2012-05-21 | 2012-05-21 | 889 | 0d |  |
| 891 | 1.3.15.4 | Brick Work upto Top Slab | 1d | 2012-05-22 | 2012-05-22 | 890 | 0d |  |
| 892 | 1.3.15.5 | **Top slab** | 10d | 2012-05-23 | 2012-06-01 |  | 0d |  |
| 893 | 1.3.15.5.1 | Form Work | 5d | 2012-05-23 | 2012-05-27 | 891, 886 | 0d |  |
| 894 | 1.3.15.5.2 | Re-bar Work | 3d | 2012-05-28 | 2012-05-30 | 893 | 0d |  |
| 895 | 1.3.15.5.3 | Inspection | 1d | 2012-05-31 | 2012-05-31 | 894 | 0d |  |
| 896 | 1.3.15.5.4 | Concrete | 1d | 2012-06-01 | 2012-06-01 | 895 | 0d |  |
| 897 | 1.3.15.6 | **Swimming Pool** | 5d | 2012-05-13 | 2012-05-17 |  | 109d |  |
| 898 | 1.3.15.6.1 | **Vertical Wall** | 5d | 2012-05-13 | 2012-05-17 |  | 109d |  |
| 899 | 1.3.15.6.1.1 | Re-bar | 2d | 2012-05-13 | 2012-05-14 | 873 | 109d | 0d |
| 900 | 1.3.15.6.1.2 | Formwork | 2d | 2012-05-15 | 2012-05-16 | 899 | 109d | 0d |
| 901 | 1.3.15.6.1.3 | Concrete | 1d | 2012-05-17 | 2012-05-17 | 900 | 109d |  |
| 902 | 1.3.15.7 | **Planter Box** | 6d | 2012-05-13 | 2012-05-18 |  | 103d |  |
| 903 | 1.3.15.7.1 | **Vertical Wall** | 6d | 2012-05-13 | 2012-05-18 |  | 103d |  |
| 904 | 1.3.15.7.1.1 | Re-bar | 2d | 2012-05-13 | 2012-05-14 | 873 | 103d | 0d |
| 905 | 1.3.15.7.1.2 | Formwork | 2d | 2012-05-15 | 2012-05-16 | 904 | 103d | 0d |
| 906 | 1.3.15.7.1.3 | Concrete | 2d | 2012-05-17 | 2012-05-18 | 905 | 108d |  |

| ID | WBS | Task | Duration | Start | Finish | Predecessors | Total slack | Free slack |
| --- | --- | --- | --- | --- | --- | --- | --- | --- |
| 907 | 1.4 | **FINISHING WORK** | 459d | 2011-04-15 | 2012-08-01 |  | 0d |  |
| 908 | 1.4.1 | **BASEMENT-3** | 77d | 2011-04-15 | 2011-06-30 |  | 382d |  |
| 909 | 1.4.1.1 | De-shuttering Roof Slab | 3d | 2011-04-15 | 2011-04-17 | 188FS+21d | 382d | 0d |
| 910 | 1.4.1.2 | Brick Work | 14d | 2011-04-18 | 2011-05-01 | 909 | 384d | 0d |
| 911 | 1.4.1.3 | Plaster | 14d | 2011-04-25 | 2011-05-08 | 910FF+7d | 384d | 2d |
| 912 | 1.4.1.4 | Column Guard/ Car Stopper | 7d | 2011-06-02 | 2011-06-09 | 914SF | 404d |  |
| 913 | 1.4.1.5 | Stair/Other Railing | 15d | 2011-05-25 | 2011-06-09 | 914SF | 404d |  |
| 914 | 1.4.1.6 | Resin Floor | 15d | 2011-06-09 | 2011-06-23 | 1194FF+7d | 382d | 0d |
| 915 | 1.4.1.7 | Painting | 30d | 2011-06-01 | 2011-06-30 | 914FF+7d, 911FS+21d | 382d |  |
| 916 | 1.4.2 | **BASEMENT-2** | 77d | 2011-05-09 | 2011-07-24 |  | 358d |  |
| 917 | 1.4.2.1 | De-shuttering Roof Slab | 3d | 2011-05-09 | 2011-05-11 | 257FS+21d | 358d | 0d |
| 918 | 1.4.2.2 | Brick Work | 14d | 2011-05-12 | 2011-05-25 | 917 | 360d | 0d |
| 919 | 1.4.2.3 | Plaster | 14d | 2011-05-19 | 2011-06-01 | 918FF+7d | 360d | 2d |
| 920 | 1.4.2.4 | Column Guard/ Car Stopper | 7d | 2011-06-26 | 2011-07-03 | 922SF | 380d |  |
| 921 | 1.4.2.5 | Stair/Other Railing | 15d | 2011-06-18 | 2011-07-03 | 922SF | 380d |  |
| 922 | 1.4.2.6 | Resin Floor | 15d | 2011-07-03 | 2011-07-17 | 1195FF+7d | 358d | 0d |
| 923 | 1.4.2.7 | Painting | 30d | 2011-06-25 | 2011-07-24 | 922FF+7d, 919FS+21d | 358d |  |
| 924 | 1.4.3 | **BASEMENT-1** | 77d | 2011-06-03 | 2011-08-18 |  | 333d |  |
| 925 | 1.4.3.1 | De-shuttering Roof Slab | 3d | 2011-06-03 | 2011-06-05 | 326FS+21d | 333d | 0d |
| 926 | 1.4.3.2 | Brick Work | 14d | 2011-06-06 | 2011-06-19 | 925 | 335d | 0d |
| 927 | 1.4.3.3 | Plaster | 14d | 2011-06-13 | 2011-06-26 | 926FF+7d | 335d | 2d |
| 928 | 1.4.3.4 | Column Guard/ Car Stopper | 7d | 2011-07-21 | 2011-07-28 | 930SF | 355d |  |
| 929 | 1.4.3.5 | Stair/Other Railing | 15d | 2011-07-13 | 2011-07-28 | 930SF | 355d |  |
| 930 | 1.4.3.6 | Resin Floor | 15d | 2011-07-28 | 2011-08-11 | 1196FF+7d | 333d | 0d |
| 931 | 1.4.3.7 | Painting | 30d | 2011-07-20 | 2011-08-18 | 930FF+7d, 927FS+21d | 333d |  |

| ID | WBS | Task | Duration | Start | Finish | Predecessors | Total slack | Free slack |
| --- | --- | --- | --- | --- | --- | --- | --- | --- |
| 932 | 1.4.4 | **GROUND FLOOR** | 62d | 2011-06-28 | 2011-09-05 |  | 323d |  |
| 933 | 1.4.4.1 | De-shuttering Roof Slab | 3d | 2011-06-28 | 2011-06-30 | 366FS+21d | 323d | 0d |
| 934 | 1.4.4.2 | Brick Work | 7d | 2011-07-01 | 2011-07-07 | 933 | 323d | 0d |
| 935 | 1.4.4.3 | Plaster | 7d | 2011-07-08 | 2011-07-14 | 934FF+7d | 323d | 0d |
| 936 | 1.4.4.4 | **Toilet Cubicals** | 11d | 2011-07-15 | 2011-07-25 |  | 357d |  |
| 937 | 1.4.4.4.1 | Water/ Sewarage Pipe Lines | 3d | 2011-07-15 | 2011-07-17 | 935 | 357d | 0d |
| 938 | 1.4.4.4.2 | Water Proofing Works | 1d | 2011-07-18 | 2011-07-18 | 937 | 357d | 0d |
| 939 | 1.4.4.4.3 | Tile Works/ Marble Top | 3d | 2011-07-19 | 2011-07-21 | 938 | 357d | 0d |
| 940 | 1.4.4.4.4 | Cubicals Install | 3d | 2011-07-22 | 2011-07-24 | 939 | 357d | 0d |
| 941 | 1.4.4.4.5 | Fitting & Fixtures | 1d | 2011-07-25 | 2011-07-25 | 940 | 357d |  |
| 942 | 1.4.4.5 | False Ceiling Works | 15d | 2011-08-14 | 2011-09-05 | 1197 | 323d |  |
| 943 | 1.4.4.6 | Paver Works | 15d | 2011-07-15 | 2011-07-29 | 935 | 353d |  |
| 944 | 1.4.4.7 | Sone/Wood/Glazing in Wall | 14d | 2011-07-23 | 2011-08-06 | 947SF | 346d |  |
| 945 | 1.4.4.8 | Stair/Other Railing | 15d | 2011-07-22 | 2011-08-06 | 947SF | 346d |  |
| 946 | 1.4.4.9 | Granite Flooring | 10d | 2011-08-08 | 2011-08-17 | 947FF-3d | 334d |  |
| 947 | 1.4.4.10 | Resin Floor | 15d | 2011-08-06 | 2011-08-20 | 1197FF+7d | 324d | 0d |
| 948 | 1.4.4.11 | Fire Door Installation | 7d | 2011-08-17 | 2011-08-23 | 947FF+3d | 328d |  |
| 949 | 1.4.4.12 | Painting | 15d | 2011-08-13 | 2011-09-04 | 947FF+7d, 935FS+21d | 324d |  |
| 950 | 1.4.5 | **1ST FLOOR** | 53d | 2011-07-23 | 2011-09-21 |  | 307d |  |
| 951 | 1.4.5.1 | De-shuttering Roof Slab | 3d | 2011-07-23 | 2011-07-25 | 405FS+21d | 307d | 0d |
| 952 | 1.4.5.2 | Brick Work | 7d | 2011-07-26 | 2011-08-01 | 951 | 307d | 0d |
| 953 | 1.4.5.3 | Plaster | 7d | 2011-08-02 | 2011-08-08 | 952FF+7d | 307d | 0d |
| 954 | 1.4.5.4 | **Toilet Cubicals** | 11d | 2011-08-09 | 2011-08-19 |  | 332d |  |
| 955 | 1.4.5.4.1 | Water/ Sewarage Pipe Lines | 3d | 2011-08-09 | 2011-08-11 | 953 | 332d | 0d |
| 956 | 1.4.5.4.2 | Water Proofing Works | 1d | 2011-08-12 | 2011-08-12 | 955 | 332d | 0d |
| 957 | 1.4.5.4.3 | Tile Works/ Marble Top | 3d | 2011-08-13 | 2011-08-15 | 956 | 332d | 0d |
| 958 | 1.4.5.4.4 | Cubicals Install | 3d | 2011-08-16 | 2011-08-18 | 957 | 332d | 0d |
| 959 | 1.4.5.4.5 | Fitting & Fixtures | 1d | 2011-08-19 | 2011-08-19 | 958 | 332d |  |
| 960 | 1.4.5.5 | False Ceiling Works | 15d | 2011-08-25 | 2011-09-16 | 1198 | 312d |  |
| 961 | 1.4.5.6 | Sone/Wood/Glazing in Wall | 14d | 2011-08-03 | 2011-08-17 | 964SF | 335d |  |
| 962 | 1.4.5.7 | Stair/Other Railing | 15d | 2011-08-02 | 2011-08-17 | 964SF | 335d |  |
| 963 | 1.4.5.8 | Granite Flooring | 10d | 2011-08-19 | 2011-09-05 | 964FF-3d | 323d |  |
| 964 | 1.4.5.9 | Resin Floor | 15d | 2011-08-17 | 2011-09-08 | 1198FF+7d | 313d | 0d |
| 965 | 1.4.5.10 | Fire Door Installation | 7d | 2011-09-05 | 2011-09-11 | 964FF+3d | 317d |  |
| 966 | 1.4.5.11 | Painting | 15d | 2011-09-07 | 2011-09-21 | 964FF+7d, 953FS+21d | 307d |  |

| ID | WBS | Task | Duration | Start | Finish | Predecessors | Total slack | Free slack |
| --- | --- | --- | --- | --- | --- | --- | --- | --- |
| 967 | 1.4.6 | **2ND FLOOR** | 53d | 2011-08-17 | 2011-10-16 |  | 282d |  |
| 968 | 1.4.6.1 | De-shuttering Roof Slab | 3d | 2011-08-17 | 2011-08-19 | 444FS+21d | 282d | 0d |
| 969 | 1.4.6.2 | Brick Work | 7d | 2011-08-20 | 2011-09-03 | 968 | 282d | 0d |
| 970 | 1.4.6.3 | Plaster | 7d | 2011-09-04 | 2011-09-10 | 969FF+7d | 282d | 0d |
| 971 | 1.4.6.4 | **Toilet Cubicals** | 11d | 2011-09-11 | 2011-09-21 |  | 307d |  |
| 972 | 1.4.6.4.1 | Water/ Sewarage Pipe Lines | 3d | 2011-09-11 | 2011-09-13 | 970 | 307d | 0d |
| 973 | 1.4.6.4.2 | Water Proofing Works | 1d | 2011-09-14 | 2011-09-14 | 972 | 307d | 0d |
| 974 | 1.4.6.4.3 | Tile Works/ Marble Top | 3d | 2011-09-15 | 2011-09-17 | 973 | 307d | 0d |
| 975 | 1.4.6.4.4 | Cubicals Install | 3d | 2011-09-18 | 2011-09-20 | 974 | 307d | 0d |
| 976 | 1.4.6.4.5 | Fitting & Fixtures | 1d | 2011-09-21 | 2011-09-21 | 975 | 307d |  |
| 977 | 1.4.6.5 | False Ceiling Works | 15d | 2011-09-27 | 2011-10-11 | 1199 | 287d |  |
| 978 | 1.4.6.6 | Sone/Wood/Glazing in Wall | 14d | 2011-09-05 | 2011-09-19 | 981SF | 310d |  |
| 979 | 1.4.6.7 | Stair/Other Railing | 15d | 2011-09-04 | 2011-09-19 | 981SF | 310d |  |
| 980 | 1.4.6.8 | Granite Flooring | 10d | 2011-09-21 | 2011-09-30 | 981FF-3d | 298d |  |
| 981 | 1.4.6.9 | Resin Floor | 15d | 2011-09-19 | 2011-10-03 | 1199FF+7d | 288d | 0d |
| 982 | 1.4.6.10 | Fire Door Installation | 7d | 2011-09-30 | 2011-10-06 | 981FF+3d | 292d |  |
| 983 | 1.4.6.11 | Painting | 15d | 2011-10-02 | 2011-10-16 | 981FF+7d, 970FS+21d | 282d |  |
| 984 | 1.4.7 | **3RD FLOOR** | 53d | 2011-09-19 | 2011-11-10 |  | 257d |  |
| 985 | 1.4.7.1 | De-shuttering Roof Slab | 3d | 2011-09-19 | 2011-09-21 | 483FS+21d | 257d | 0d |
| 986 | 1.4.7.2 | Brick Work | 7d | 2011-09-22 | 2011-09-28 | 985 | 257d | 0d |
| 987 | 1.4.7.3 | Plaster | 7d | 2011-09-29 | 2011-10-05 | 986FF+7d | 257d | 0d |
| 988 | 1.4.7.4 | **Toilet Cubicals** | 11d | 2011-10-06 | 2011-10-16 |  | 282d |  |
| 989 | 1.4.7.4.1 | Water/ Sewarage Pipe Lines | 3d | 2011-10-06 | 2011-10-08 | 987 | 282d | 0d |
| 990 | 1.4.7.4.2 | Water Proofing Works | 1d | 2011-10-09 | 2011-10-09 | 989 | 282d | 0d |
| 991 | 1.4.7.4.3 | Tile Works/ Marble Top | 3d | 2011-10-10 | 2011-10-12 | 990 | 282d | 0d |
| 992 | 1.4.7.4.4 | Cubicals Install | 3d | 2011-10-13 | 2011-10-15 | 991 | 282d | 0d |
| 993 | 1.4.7.4.5 | Fitting & Fixtures | 1d | 2011-10-16 | 2011-10-16 | 992 | 282d |  |
| 994 | 1.4.7.5 | False Ceiling Works | 15d | 2011-10-22 | 2011-11-05 | 1200 | 262d |  |
| 995 | 1.4.7.6 | Sone/Wood/Glazing in Wall | 14d | 2011-09-30 | 2011-10-14 | 998SF | 285d |  |
| 996 | 1.4.7.7 | Stair/Other Railing | 15d | 2011-09-29 | 2011-10-14 | 998SF | 285d |  |
| 997 | 1.4.7.8 | Granite Flooring | 10d | 2011-10-16 | 2011-10-25 | 998FF-3d | 273d |  |
| 998 | 1.4.7.9 | Resin Floor | 15d | 2011-10-14 | 2011-10-28 | 1200FF+7d | 263d | 0d |
| 999 | 1.4.7.10 | Fire Door Installation | 7d | 2011-10-25 | 2011-10-31 | 998FF+3d | 267d |  |
| 1000 | 1.4.7.11 | Painting | 15d | 2011-10-27 | 2011-11-10 | 998FF+7d, 987FS+21d | 257d |  |

| ID | WBS | Task | Duration | Start | Finish | Predecessors | Total slack | Free slack |
| --- | --- | --- | --- | --- | --- | --- | --- | --- |
| 1001 | 1.4.8 | **4TH FLOOR** | 53d | 2011-10-14 | 2011-12-13 |  | 232d |  |
| 1002 | 1.4.8.1 | De-shuttering Roof Slab | 3d | 2011-10-14 | 2011-10-16 | 522FS+21d | 232d | 0d |
| 1003 | 1.4.8.2 | Brick Work | 7d | 2011-10-17 | 2011-10-23 | 1002 | 232d | 0d |
| 1004 | 1.4.8.3 | Plaster | 7d | 2011-10-24 | 2011-10-30 | 1003FF+7d | 232d | 0d |
| 1005 | 1.4.8.4 | **Toilet Cubicals** | 11d | 2011-10-31 | 2011-11-10 |  | 257d |  |
| 1006 | 1.4.8.4.1 | Water/ Sewarage Pipe Lines | 3d | 2011-10-31 | 2011-11-02 | 1004 | 257d | 0d |
| 1007 | 1.4.8.4.2 | Water Proofing Works | 1d | 2011-11-03 | 2011-11-03 | 1006 | 257d | 0d |
| 1008 | 1.4.8.4.3 | Tile Works/ Marble Top | 3d | 2011-11-04 | 2011-11-06 | 1007 | 257d | 0d |
| 1009 | 1.4.8.4.4 | Cubicals Install | 3d | 2011-11-07 | 2011-11-09 | 1008 | 257d | 0d |
| 1010 | 1.4.8.4.5 | Fitting & Fixtures | 1d | 2011-11-10 | 2011-11-10 | 1009 | 257d |  |
| 1011 | 1.4.8.5 | False Ceiling Works | 15d | 2011-11-24 | 2011-12-08 | 1201 | 237d |  |
| 1012 | 1.4.8.6 | Sone/Wood/Glazing in Wall | 14d | 2011-10-25 | 2011-11-08 | 1015SF | 260d |  |
| 1013 | 1.4.8.7 | Stair/Other Railing | 15d | 2011-10-24 | 2011-11-08 | 1015SF | 260d |  |
| 1014 | 1.4.8.8 | Granite Flooring | 10d | 2011-11-10 | 2011-11-27 | 1015FF-3d | 248d |  |
| 1015 | 1.4.8.9 | Resin Floor | 15d | 2011-11-08 | 2011-11-30 | 1201FF+7d | 238d | 0d |
| 1016 | 1.4.8.10 | Fire Door Installation | 7d | 2011-11-27 | 2011-12-03 | 1015FF+3d | 242d |  |
| 1017 | 1.4.8.11 | Painting | 15d | 2011-11-29 | 2011-12-13 | 1015FF+7d, 1004FS+21d | 232d |  |
| 1018 | 1.4.9 | **5TH FLOOR** | 53d | 2011-11-08 | 2012-01-07 |  | 207d |  |
| 1019 | 1.4.9.1 | De-shuttering Roof Slab | 3d | 2011-11-08 | 2011-11-10 | 561FS+21d | 207d | 0d |
| 1020 | 1.4.9.2 | Brick Work | 7d | 2011-11-19 | 2011-11-25 | 1019 | 207d | 0d |
| 1021 | 1.4.9.3 | Plaster | 7d | 2011-11-26 | 2011-12-02 | 1020FF+7d | 207d | 0d |
| 1022 | 1.4.9.4 | **Toilet Cubicals** | 11d | 2011-12-03 | 2011-12-13 |  | 232d |  |
| 1023 | 1.4.9.4.1 | Water/ Sewarage Pipe Lines | 3d | 2011-12-03 | 2011-12-05 | 1021 | 232d | 0d |
| 1024 | 1.4.9.4.2 | Water Proofing Works | 1d | 2011-12-06 | 2011-12-06 | 1023 | 232d | 0d |
| 1025 | 1.4.9.4.3 | Tile Works/ Marble Top | 3d | 2011-12-07 | 2011-12-09 | 1024 | 232d | 0d |
| 1026 | 1.4.9.4.4 | Cubicals Install | 3d | 2011-12-10 | 2011-12-12 | 1025 | 232d | 0d |
| 1027 | 1.4.9.4.5 | Fitting & Fixtures | 1d | 2011-12-13 | 2011-12-13 | 1026 | 232d |  |
| 1028 | 1.4.9.5 | False Ceiling Works | 15d | 2011-12-19 | 2012-01-02 | 1202 | 212d |  |
| 1029 | 1.4.9.6 | Sone/Wood/Glazing in Wall | 14d | 2011-11-27 | 2011-12-11 | 1032SF | 235d |  |
| 1030 | 1.4.9.7 | Stair/Other Railing | 15d | 2011-11-26 | 2011-12-11 | 1032SF | 235d |  |
| 1031 | 1.4.9.8 | Granite Flooring | 10d | 2011-12-13 | 2011-12-22 | 1032FF-3d | 223d |  |
| 1032 | 1.4.9.9 | Resin Floor | 15d | 2011-12-11 | 2011-12-25 | 1202FF+7d | 213d | 0d |
| 1033 | 1.4.9.10 | Fire Door Installation | 7d | 2011-12-22 | 2011-12-28 | 1032FF+3d | 217d |  |
| 1034 | 1.4.9.11 | Painting | 15d | 2011-12-24 | 2012-01-07 | 1032FF+7d, 1021FS+21d | 207d |  |

| ID | WBS | Task | Duration | Start | Finish | Predecessors | Total slack | Free slack |
| --- | --- | --- | --- | --- | --- | --- | --- | --- |
| 1035 | 1.4.10 | **6TH FLOOR** | 53d | 2011-12-11 | 2012-02-01 |  | 182d |  |
| 1036 | 1.4.10.1 | De-shuttering Roof Slab | 3d | 2011-12-11 | 2011-12-13 | 600FS+21d | 182d | 0d |
| 1037 | 1.4.10.2 | Brick Work | 7d | 2011-12-14 | 2011-12-20 | 1036 | 182d | 0d |
| 1038 | 1.4.10.3 | Plaster | 7d | 2011-12-21 | 2011-12-27 | 1037FF+7d | 182d | 0d |
| 1039 | 1.4.10.4 | **Toilet Cubicals** | 11d | 2011-12-28 | 2012-01-07 |  | 207d |  |
| 1040 | 1.4.10.4.1 | Water/ Sewarage Pipe Lines | 3d | 2011-12-28 | 2011-12-30 | 1038 | 207d | 0d |
| 1041 | 1.4.10.4.2 | Water Proofing Works | 1d | 2011-12-31 | 2011-12-31 | 1040 | 207d | 0d |
| 1042 | 1.4.10.4.3 | Tile Works/ Marble Top | 3d | 2012-01-01 | 2012-01-03 | 1041 | 207d | 0d |
| 1043 | 1.4.10.4.4 | Cubicals Install | 3d | 2012-01-04 | 2012-01-06 | 1042 | 207d | 0d |
| 1044 | 1.4.10.4.5 | Fitting & Fixtures | 1d | 2012-01-07 | 2012-01-07 | 1043 | 207d |  |
| 1045 | 1.4.10.5 | False Ceiling Works | 15d | 2012-01-13 | 2012-01-27 | 1203 | 187d |  |
| 1046 | 1.4.10.6 | Sone/Wood/Glazing in Wall | 14d | 2011-12-22 | 2012-01-05 | 1049SF | 210d |  |
| 1047 | 1.4.10.7 | Stair/Other Railing | 15d | 2011-12-21 | 2012-01-05 | 1049SF | 210d |  |
| 1048 | 1.4.10.8 | Granite Flooring | 10d | 2012-01-07 | 2012-01-16 | 1049FF-3d | 198d |  |
| 1049 | 1.4.10.9 | Resin Floor | 15d | 2012-01-05 | 2012-01-19 | 1203FF+7d | 188d | 0d |
| 1050 | 1.4.10.10 | Fire Door Installation | 7d | 2012-01-16 | 2012-01-22 | 1049FF+3d | 192d |  |
| 1051 | 1.4.10.11 | Painting | 15d | 2012-01-18 | 2012-02-01 | 1049FF+7d, 1038FS+21d | 182d |  |
| 1052 | 1.4.11 | **7TH FLOOR** | 53d | 2012-01-05 | 2012-02-26 |  | 157d |  |
| 1053 | 1.4.11.1 | De-shuttering Roof Slab | 3d | 2012-01-05 | 2012-01-07 | 639FS+21d | 157d | 0d |
| 1054 | 1.4.11.2 | Brick Work | 7d | 2012-01-08 | 2012-01-14 | 1053 | 157d | 0d |
| 1055 | 1.4.11.3 | Plaster | 7d | 2012-01-15 | 2012-01-21 | 1054FF+7d | 157d | 0d |
| 1056 | 1.4.11.4 | **Toilet Cubicals** | 11d | 2012-01-22 | 2012-02-01 |  | 182d |  |
| 1057 | 1.4.11.4.1 | Water/ Sewarage Pipe Lines | 3d | 2012-01-22 | 2012-01-24 | 1055 | 182d | 0d |
| 1058 | 1.4.11.4.2 | Water Proofing Works | 1d | 2012-01-25 | 2012-01-25 | 1057 | 182d | 0d |
| 1059 | 1.4.11.4.3 | Tile Works/ Marble Top | 3d | 2012-01-26 | 2012-01-28 | 1058 | 182d | 0d |
| 1060 | 1.4.11.4.4 | Cubicals Install | 3d | 2012-01-29 | 2012-01-31 | 1059 | 182d | 0d |
| 1061 | 1.4.11.4.5 | Fitting & Fixtures | 1d | 2012-02-01 | 2012-02-01 | 1060 | 182d |  |
| 1062 | 1.4.11.5 | False Ceiling Works | 15d | 2012-02-07 | 2012-02-21 | 1204 | 162d |  |
| 1063 | 1.4.11.6 | Sone/Wood/Glazing in Wall | 14d | 2012-01-16 | 2012-01-30 | 1066SF | 185d |  |
| 1064 | 1.4.11.7 | Stair/Other Railing | 15d | 2012-01-15 | 2012-01-30 | 1066SF | 185d |  |
| 1065 | 1.4.11.8 | Granite Flooring | 10d | 2012-02-01 | 2012-02-10 | 1066FF-3d | 173d |  |
| 1066 | 1.4.11.9 | Resin Floor | 15d | 2012-01-30 | 2012-02-13 | 1204FF+7d | 163d | 0d |
| 1067 | 1.4.11.10 | Fire Door Installation | 7d | 2012-02-10 | 2012-02-16 | 1066FF+3d | 167d |  |
| 1068 | 1.4.11.11 | Painting | 15d | 2012-02-12 | 2012-02-26 | 1066FF+7d, 1055FS+21d | 157d |  |

| ID | WBS | Task | Duration | Start | Finish | Predecessors | Total slack | Free slack |
| --- | --- | --- | --- | --- | --- | --- | --- | --- |
| 1069 | 1.4.12 | **8TH FLOOR** | 53d | 2012-02-11 | 2012-04-03 |  | 120d |  |
| 1070 | 1.4.12.1 | De-shuttering Roof Slab | 3d | 2012-02-11 | 2012-02-13 | 680FS+21d | 120d | 0d |
| 1071 | 1.4.12.2 | Brick Work | 7d | 2012-02-14 | 2012-02-20 | 1070 | 120d | 0d |
| 1072 | 1.4.12.3 | Plaster | 7d | 2012-02-21 | 2012-02-27 | 1071FF+7d | 120d | 0d |
| 1073 | 1.4.12.4 | **Toilet Cubicals** | 11d | 2012-02-28 | 2012-03-09 |  | 145d |  |
| 1074 | 1.4.12.4.1 | Water/ Sewarage Pipe Lines | 3d | 2012-02-28 | 2012-03-01 | 1072 | 145d | 0d |
| 1075 | 1.4.12.4.2 | Water Proofing Works | 1d | 2012-03-02 | 2012-03-02 | 1074 | 145d | 0d |
| 1076 | 1.4.12.4.3 | Tile Works/ Marble Top | 3d | 2012-03-03 | 2012-03-05 | 1075 | 145d | 0d |
| 1077 | 1.4.12.4.4 | Cubicals Install | 3d | 2012-03-06 | 2012-03-08 | 1076 | 145d | 0d |
| 1078 | 1.4.12.4.5 | Fitting & Fixtures | 1d | 2012-03-09 | 2012-03-09 | 1077 | 145d |  |
| 1079 | 1.4.12.5 | False Ceiling Works | 15d | 2012-03-15 | 2012-03-29 | 1205 | 125d |  |
| 1080 | 1.4.12.6 | Sone/Wood/Glazing in Wall | 14d | 2012-02-22 | 2012-03-07 | 1083SF | 148d |  |
| 1081 | 1.4.12.7 | Stair/Other Railing | 15d | 2012-02-21 | 2012-03-07 | 1083SF | 148d |  |
| 1082 | 1.4.12.8 | Granite Flooring | 10d | 2012-03-09 | 2012-03-18 | 1083FF-3d | 136d |  |
| 1083 | 1.4.12.9 | Resin Floor | 15d | 2012-03-07 | 2012-03-21 | 1205FF+7d | 126d | 0d |
| 1084 | 1.4.12.10 | Fire Door Installation | 7d | 2012-03-18 | 2012-03-24 | 1083FF+3d | 130d |  |
| 1085 | 1.4.12.11 | Painting | 15d | 2012-03-20 | 2012-04-03 | 1083FF+7d, 1072FS+21d | 120d |  |
| 1086 | 1.4.13 | **9TH FLOOR** | 53d | 2012-02-24 | 2012-04-16 |  | 107d |  |
| 1087 | 1.4.13.1 | De-shuttering Roof Slab | 3d | 2012-02-24 | 2012-02-26 | 717FS+21d | 107d | 0d |
| 1088 | 1.4.13.2 | Brick Work | 7d | 2012-02-27 | 2012-03-04 | 1087 | 107d | 0d |
| 1089 | 1.4.13.3 | Plaster | 7d | 2012-03-05 | 2012-03-11 | 1088FF+7d | 107d | 0d |
| 1090 | 1.4.13.4 | **Toilet Cubicals** | 11d | 2012-03-12 | 2012-03-22 |  | 132d |  |
| 1091 | 1.4.13.4.1 | Water/ Sewarage Pipe Lines | 3d | 2012-03-12 | 2012-03-14 | 1089 | 132d | 0d |
| 1092 | 1.4.13.4.2 | Water Proofing Works | 1d | 2012-03-15 | 2012-03-15 | 1091 | 132d | 0d |
| 1093 | 1.4.13.4.3 | Tile Works/ Marble Top | 3d | 2012-03-16 | 2012-03-18 | 1092 | 132d | 0d |
| 1094 | 1.4.13.4.4 | Cubicals Install | 3d | 2012-03-19 | 2012-03-21 | 1093 | 132d | 0d |
| 1095 | 1.4.13.4.5 | Fitting & Fixtures | 1d | 2012-03-22 | 2012-03-22 | 1094 | 132d |  |
| 1096 | 1.4.13.5 | False Ceiling Works | 15d | 2012-03-28 | 2012-04-11 | 1206 | 112d |  |
| 1097 | 1.4.13.6 | Sone/Wood/Glazing in Wall | 14d | 2012-03-06 | 2012-03-20 | 1100SF | 135d |  |
| 1098 | 1.4.13.7 | Stair/Other Railing | 15d | 2012-03-05 | 2012-03-20 | 1100SF | 135d |  |
| 1099 | 1.4.13.8 | Granite Flooring | 10d | 2012-03-22 | 2012-03-31 | 1100FF-3d | 123d |  |
| 1100 | 1.4.13.9 | Resin Floor | 15d | 2012-03-20 | 2012-04-03 | 1206FF+7d | 113d | 0d |
| 1101 | 1.4.13.10 | Fire Door Installation | 7d | 2012-03-31 | 2012-04-06 | 1100FF+3d | 117d |  |
| 1102 | 1.4.13.11 | Painting | 15d | 2012-04-02 | 2012-04-16 | 1100FF+7d, 1089FS+21d | 107d |  |

| ID | WBS | Task | Duration | Start | Finish | Predecessors | Total slack | Free slack |
| --- | --- | --- | --- | --- | --- | --- | --- | --- |
| 1103 | 1.4.14 | **10TH FLOOR** | 53d | 2012-03-20 | 2012-05-11 |  | 82d |  |
| 1104 | 1.4.14.1 | De-shuttering Roof Slab | 3d | 2012-03-20 | 2012-03-22 | 756FS+21d | 82d | 0d |
| 1105 | 1.4.14.2 | Brick Work | 7d | 2012-03-23 | 2012-03-29 | 1104 | 82d | 0d |
| 1106 | 1.4.14.3 | Plaster | 7d | 2012-03-30 | 2012-04-05 | 1105FF+7d | 82d | 0d |
| 1107 | 1.4.14.4 | **Toilet Cubicals** | 11d | 2012-04-06 | 2012-04-16 |  | 107d |  |
| 1108 | 1.4.14.4.1 | Water/ Sewarage Pipe Lines | 3d | 2012-04-06 | 2012-04-08 | 1106 | 107d | 0d |
| 1109 | 1.4.14.4.2 | Water Proofing Works | 1d | 2012-04-09 | 2012-04-09 | 1108 | 107d | 0d |
| 1110 | 1.4.14.4.3 | Tile Works/ Marble Top | 3d | 2012-04-10 | 2012-04-12 | 1109 | 107d | 0d |
| 1111 | 1.4.14.4.4 | Cubicals Install | 3d | 2012-04-13 | 2012-04-15 | 1110 | 107d | 0d |
| 1112 | 1.4.14.4.5 | Fitting & Fixtures | 1d | 2012-04-16 | 2012-04-16 | 1111 | 107d |  |
| 1113 | 1.4.14.5 | False Ceiling Works | 15d | 2012-04-22 | 2012-05-06 | 1207 | 87d |  |
| 1114 | 1.4.14.6 | Sone/Wood/Glazing in Wall | 14d | 2012-03-31 | 2012-04-14 | 1117SF | 110d |  |
| 1115 | 1.4.14.7 | Stair/Other Railing | 15d | 2012-03-30 | 2012-04-14 | 1117SF | 110d |  |
| 1116 | 1.4.14.8 | Granite Flooring | 10d | 2012-04-16 | 2012-04-25 | 1117FF-3d | 98d |  |
| 1117 | 1.4.14.9 | Resin Floor | 15d | 2012-04-14 | 2012-04-28 | 1207FF+7d | 88d | 0d |
| 1118 | 1.4.14.10 | Fire Door Installation | 7d | 2012-04-25 | 2012-05-01 | 1117FF+3d | 92d |  |
| 1119 | 1.4.14.11 | Painting | 15d | 2012-04-27 | 2012-05-11 | 1117FF+7d, 1106FS+21d | 82d |  |
| 1120 | 1.4.15 | **11TH FLOOR** | 53d | 2012-04-14 | 2012-06-05 |  | 57d |  |
| 1121 | 1.4.15.1 | De-shuttering Roof Slab | 3d | 2012-04-14 | 2012-04-16 | 795FS+21d | 57d | 0d |
| 1122 | 1.4.15.2 | Brick Work | 7d | 2012-04-17 | 2012-04-23 | 1121 | 57d | 0d |
| 1123 | 1.4.15.3 | Plaster | 7d | 2012-04-24 | 2012-04-30 | 1122FF+7d | 57d | 0d |
| 1124 | 1.4.15.4 | **Toilet Cubicals** | 11d | 2012-05-01 | 2012-05-11 |  | 82d |  |
| 1125 | 1.4.15.4.1 | Water/ Sewarage Pipe Lines | 3d | 2012-05-01 | 2012-05-03 | 1123 | 82d | 0d |
| 1126 | 1.4.15.4.2 | Water Proofing Works | 1d | 2012-05-04 | 2012-05-04 | 1125 | 82d | 0d |
| 1127 | 1.4.15.4.3 | Tile Works/ Marble Top | 3d | 2012-05-05 | 2012-05-07 | 1126 | 82d | 0d |
| 1128 | 1.4.15.4.4 | Cubicals Install | 3d | 2012-05-08 | 2012-05-10 | 1127 | 82d | 0d |
| 1129 | 1.4.15.4.5 | Fitting & Fixtures | 1d | 2012-05-11 | 2012-05-11 | 1128 | 82d |  |
| 1130 | 1.4.15.5 | False Ceiling Works | 15d | 2012-05-17 | 2012-05-31 | 1208 | 62d |  |
| 1131 | 1.4.15.6 | Sone/Wood/Glazing in Wall | 14d | 2012-04-25 | 2012-05-09 | 1134SF | 85d |  |
| 1132 | 1.4.15.7 | Stair/Other Railing | 15d | 2012-04-24 | 2012-05-09 | 1134SF | 85d |  |
| 1133 | 1.4.15.8 | Granite Flooring | 10d | 2012-05-11 | 2012-05-20 | 1134FF-3d | 73d |  |
| 1134 | 1.4.15.9 | Resin Floor | 15d | 2012-05-09 | 2012-05-23 | 1208FF+7d | 63d | 0d |
| 1135 | 1.4.15.10 | Fire Door Installation | 7d | 2012-05-20 | 2012-05-26 | 1134FF+3d | 67d |  |
| 1136 | 1.4.15.11 | Painting | 15d | 2012-05-22 | 2012-06-05 | 1134FF+7d, 1123FS+21d | 57d |  |

| ID | WBS | Task | Duration | Start | Finish | Predecessors | Total slack | Free slack |
| --- | --- | --- | --- | --- | --- | --- | --- | --- |
| 1137 | 1.4.16 | **12TH FLOOR** | 53d | 2012-05-09 | 2012-06-30 |  | 32d |  |
| 1138 | 1.4.16.1 | De-shuttering Roof Slab | 3d | 2012-05-09 | 2012-05-11 | 834FS+21d | 32d | 0d |
| 1139 | 1.4.16.2 | Brick Work | 7d | 2012-05-12 | 2012-05-18 | 1138 | 32d | 0d |
| 1140 | 1.4.16.3 | Plaster | 7d | 2012-05-19 | 2012-05-25 | 1139FF+7d | 32d | 0d |
| 1141 | 1.4.16.4 | **Toilet Cubicals** | 11d | 2012-05-26 | 2012-06-05 |  | 57d |  |
| 1142 | 1.4.16.4.1 | Water/ Sewarage Pipe Lines | 3d | 2012-05-26 | 2012-05-28 | 1140 | 57d | 0d |
| 1143 | 1.4.16.4.2 | Water Proofing Works | 1d | 2012-05-29 | 2012-05-29 | 1142 | 57d | 0d |
| 1144 | 1.4.16.4.3 | Tile Works/ Marble Top | 3d | 2012-05-30 | 2012-06-01 | 1143 | 57d | 0d |
| 1145 | 1.4.16.4.4 | Cubicals Install | 3d | 2012-06-02 | 2012-06-04 | 1144 | 57d | 0d |
| 1146 | 1.4.16.4.5 | Fitting & Fixtures | 1d | 2012-06-05 | 2012-06-05 | 1145 | 57d |  |
| 1147 | 1.4.16.5 | False Ceiling Works | 15d | 2012-06-11 | 2012-06-25 | 1209 | 37d |  |
| 1148 | 1.4.16.6 | Sone/Wood/Glazing in Wall | 14d | 2012-05-20 | 2012-06-03 | 1151SF | 60d |  |
| 1149 | 1.4.16.7 | Stair/Other Railing | 15d | 2012-05-19 | 2012-06-03 | 1151SF | 60d |  |
| 1150 | 1.4.16.8 | Granite Flooring | 10d | 2012-06-05 | 2012-06-14 | 1151FF-3d | 48d |  |
| 1151 | 1.4.16.9 | Resin Floor | 15d | 2012-06-03 | 2012-06-17 | 1209FF+7d | 38d | 0d |
| 1152 | 1.4.16.10 | Fire Door Installation | 7d | 2012-06-14 | 2012-06-20 | 1151FF+3d | 42d |  |
| 1153 | 1.4.16.11 | Painting | 15d | 2012-06-16 | 2012-06-30 | 1151FF+7d, 1140FS+21d | 32d |  |
| 1154 | 1.4.17 | **13TH FLOOR** | 48d | 2012-06-03 | 2012-07-20 |  | 12d |  |
| 1155 | 1.4.17.1 | De-shuttering Roof Slab | 3d | 2012-06-03 | 2012-06-05 | 873FS+21d | 12d | 0d |
| 1156 | 1.4.17.2 | Brick Work | 7d | 2012-06-06 | 2012-06-12 | 1155 | 22d | 0d |
| 1157 | 1.4.17.3 | Plaster | 7d | 2012-06-13 | 2012-06-19 | 1156FF+7d | 22d | 0d |
| 1158 | 1.4.17.4 | **Toilet Cubicals** | 11d | 2012-06-20 | 2012-06-30 |  | 32d |  |
| 1159 | 1.4.17.4.1 | Water/ Sewarage Pipe Lines | 3d | 2012-06-20 | 2012-06-22 | 1157 | 32d | 0d |
| 1160 | 1.4.17.4.2 | Water Proofing Works | 1d | 2012-06-23 | 2012-06-23 | 1159 | 32d | 0d |
| 1161 | 1.4.17.4.3 | Tile Works/ Marble Top | 3d | 2012-06-24 | 2012-06-26 | 1160 | 32d | 0d |
| 1162 | 1.4.17.4.4 | Cubicals Install | 3d | 2012-06-27 | 2012-06-29 | 1161 | 32d | 0d |
| 1163 | 1.4.17.4.5 | Fitting & Fixtures | 1d | 2012-06-30 | 2012-06-30 | 1162 | 32d |  |
| 1164 | 1.4.17.5 | False Ceiling Works | 15d | 2012-07-06 | 2012-07-20 | 1210 | 12d |  |
| 1165 | 1.4.17.6 | Sone/Wood/Glazing in Wall | 14d | 2012-06-14 | 2012-06-28 | 1168SF | 35d |  |
| 1166 | 1.4.17.7 | Stair/Other Railing | 15d | 2012-06-13 | 2012-06-28 | 1168SF | 35d |  |
| 1167 | 1.4.17.8 | Granite Flooring | 10d | 2012-06-30 | 2012-07-09 | 1168FF-3d | 23d |  |
| 1168 | 1.4.17.9 | Resin Floor | 15d | 2012-06-28 | 2012-07-12 | 1210FF+7d | 13d | 0d |
| 1169 | 1.4.17.10 | Fire Door Installation | 7d | 2012-07-09 | 2012-07-15 | 1168FF+3d | 17d |  |
| 1170 | 1.4.17.11 | Painting | 15d | 2012-07-05 | 2012-07-19 | 1168FF+7d, 1157FF+21d | 13d |  |

| ID | WBS | Task | Duration | Start | Finish | Predecessors | Total slack | Free slack |
| --- | --- | --- | --- | --- | --- | --- | --- | --- |
| 1171 | 1.4.18 | **MACHINE FLOOR** | 40d | 2012-06-23 | 2012-08-01 |  | 0d |  |
| 1172 | 1.4.18.1 | Brick Work | 7d | 2012-06-23 | 2012-06-29 | 896FS+21d | 0d |  |
| 1173 | 1.4.18.2 | Plaster | 5d | 2012-06-30 | 2012-07-04 | 1172 | 0d |  |
| 1174 | 1.4.18.3 | Painting | 7d | 2012-07-26 | 2012-08-01 | 1211FF+7d, 1173FS+21d | 0d |  |
| 1175 | 1.4.18.4 | **Sweeming Pool** | 31d | 2012-06-23 | 2012-07-23 |  | 9d |  |
| 1176 | 1.4.18.4.1 | Deshuttering | 1d | 2012-06-23 | 2012-06-23 | 1172SS | 9d | 0d |
| 1177 | 1.4.18.4.2 | Making Steps | 3d | 2012-06-24 | 2012-06-26 | 1176 | 9d | 0d |
| 1178 | 1.4.18.4.3 | Water Proofing | 10d | 2012-06-27 | 2012-07-06 | 1177 | 9d | 0d |
| 1179 | 1.4.18.4.4 | Lean Concrete | 1d | 2012-07-07 | 2012-07-07 | 1178 | 9d | 0d |
| 1180 | 1.4.18.4.5 | Granaite Plaster | 3d | 2012-07-08 | 2012-07-10 | 1179 | 9d | 0d |
| 1181 | 1.4.18.4.6 | Tile Work | 10d | 2012-07-11 | 2012-07-20 | 1180 | 9d | 0d |
| 1182 | 1.4.18.4.7 | MEP Fittings | 3d | 2012-07-21 | 2012-07-23 | 1181 | 9d |  |
| 1183 | 1.4.18.5 | **Planter Box** | 24d | 2012-07-05 | 2012-07-28 |  | 4d |  |
| 1184 | 1.4.18.5.1 | Water Proofing | 10d | 2012-07-05 | 2012-07-14 | 1173 | 4d | 0d |
| 1185 | 1.4.18.5.2 | Making Bed For Plantation | 7d | 2012-07-15 | 2012-07-21 | 1184 | 4d | 0d |
| 1186 | 1.4.18.5.3 | Plantation | 7d | 2012-07-22 | 2012-07-28 | 1185 | 4d |  |
| 1187 | 1.4.18.6 | **Open Terrace** | 20d | 2012-07-05 | 2012-07-24 |  | 8d |  |
| 1188 | 1.4.18.6.1 | Water Proofing | 10d | 2012-07-05 | 2012-07-14 | 1173 | 8d | 0d |
| 1189 | 1.4.18.6.2 | Paver Fixing | 10d | 2012-07-15 | 2012-07-24 | 1188 | 8d |  |
| 1190 | 1.4.19 | **TOP ROOF SLAB** | 20d | 2012-07-05 | 2012-07-24 |  | 8d |  |
| 1191 | 1.4.19.1 | Water proofing | 10d | 2012-07-05 | 2012-07-14 | 1173, 1218 | 8d | 0d |
| 1192 | 1.4.19.2 | Paver Fixing | 10d | 2012-07-15 | 2012-07-24 | 1191 | 8d |  |
| 1193 | 1.5 | **MEP WORKS** | 443d | 2011-04-18 | 2012-07-19 |  | 30d |  |
| 1194 | 1.5.1 | BASEMENT-3 | 60d | 2011-04-18 | 2011-06-16 | 909 | 382d | 0d |
| 1195 | 1.5.2 | BASEMENT-2 | 60d | 2011-05-12 | 2011-07-10 | 917 | 358d | 0d |
| 1196 | 1.5.3 | BASEMENT-1 | 60d | 2011-06-06 | 2011-08-04 | 925 | 333d | 0d |
| 1197 | 1.5.4 | GROUND FLOOR | 30d | 2011-07-15 | 2011-08-13 | 935 | 323d | 0d |
| 1198 | 1.5.5 | 1ST FLOOR | 30d | 2011-07-26 | 2011-08-24 | 951 | 312d | 0d |
| 1199 | 1.5.6 | 2ND FLOOR | 30d | 2011-08-20 | 2011-09-26 | 968 | 287d | 0d |
| 1200 | 1.5.7 | 3RD FLOOR | 30d | 2011-09-22 | 2011-10-21 | 985 | 262d | 0d |
| 1201 | 1.5.8 | 4TH FLOOR | 30d | 2011-10-17 | 2011-11-23 | 1002 | 237d | 0d |
| 1202 | 1.5.9 | 5TH FLOOR | 30d | 2011-11-19 | 2011-12-18 | 1019 | 212d | 0d |
| 1203 | 1.5.10 | 6TH FLOOR | 30d | 2011-12-14 | 2012-01-12 | 1036 | 187d | 0d |
| 1204 | 1.5.11 | 7TH FLOOR | 30d | 2012-01-08 | 2012-02-06 | 1053 | 162d | 0d |
| 1205 | 1.5.12 | 8TH FLOOR | 30d | 2012-02-14 | 2012-03-14 | 1070 | 125d | 0d |
| 1206 | 1.5.13 | 9TH FLOOR | 30d | 2012-02-27 | 2012-03-27 | 1087 | 112d | 0d |
| 1207 | 1.5.14 | 10 TH FLOOR | 30d | 2012-03-23 | 2012-04-21 | 1104 | 87d | 0d |
| 1208 | 1.5.15 | 11TH FLOOR | 30d | 2012-04-17 | 2012-05-16 | 1121 | 62d | 0d |
| 1209 | 1.5.16 | 12TH FLOOR | 30d | 2012-05-12 | 2012-06-10 | 1138 | 37d | 0d |
| 1210 | 1.5.17 | 13TH FLOOR | 30d | 2012-06-06 | 2012-07-05 | 1155 | 12d | 0d |
| 1211 | 1.5.18 | MACHINE FLOOR | 60d | 2012-05-21 | 2012-07-19 | 1173FF+15d | 6d | 0d |
| 1212 | 1.5.19 | MEP WORKS - OUTSIDE | 60d | 2012-05-21 | 2012-07-19 | 1211FF | 30d |  |

| ID | WBS | Task | Duration | Start | Finish | Predecessors | Total slack | Free slack |
| --- | --- | --- | --- | --- | --- | --- | --- | --- |
| 1213 | 1.6 | **OUTSIDE FINISHING** | 67d | 2012-06-01 | 2012-08-06 |  | 28d |  |
| 1214 | 1.6.1 | PLASTER REPAIR | 15d | 2012-06-01 | 2012-06-15 | 895 | 28d | 0d |
| 1215 | 1.6.2 | CURTAIN WALL | 45d | 2012-06-16 | 2012-07-30 | 1214 | 28d | 0d |
| 1216 | 1.6.3 | TITANIUM | 15d | 2012-06-16 | 2012-06-30 | 1214 | 65d |  |
| 1217 | 1.6.4 | LOUVER FIXING | 7d | 2012-07-31 | 2012-08-06 | 1215 | 28d |  |
| 1218 | 1.7 | CLOSING SLAB AFTER TC DISMANTLING | 30d | 2012-06-04 | 2012-07-03 | 48 | 9d | 1d |
| 1219 | 1.8 | LAND SCAPING | 60d | 2012-07-05 | 2012-09-10 | 1212FF+15d, 47FF+15d | 0d |  |
| 1220 | 1.9 | PROJECT COMPLETE | 1d | 2012-09-11 | 2012-09-11 | 1219 | 0d |  |
