# Ekushey Bhaban Program-Progress (Ver-3.0)

Schedule from MS Project, 2010-01-25 to 2012-09-19, status date 2011-01-31, costs in Tk, A marks actual dates.

## Calendars

- Standard: Mon-Fri 08:00-12:00, 13:00-17:00; Sat-Sun off. Exceptions (off unless hours are given): 2010-01-01 to 2010-09-08 08:00-12:00, 13:00-17:00 (City Scape), 2010-09-09 to 2010-09-15 (Eid-ul-Fitre), 2010-09-16 to 2010-11-14 08:00-12:00, 13:00-17:00 (Citiscape2), 2010-11-15 to 2010-11-22 (Eid-ul-Azha), 2010-11-23 to 2011-08-25 08:00-12:00, 13:00-17:00 (Cityscape3), 2011-08-26 to 2011-09-02 (Eid-ul-Fitre), 2011-09-03 to 2011-11-10 08:00-12:00, 13:00-17:00 (Cityscape4), 2011-11-11 to 2011-11-18 (Eid-ul-Azha), 2011-11-19 to 2012-08-16 08:00-12:00, 13:00-17:00 (Cityscape5).

## Resources

| Resource | Group | Unit | Rate |
| --- | --- | --- | --- |
| Cement | Material-Civil | bag | 358 |
| Local Sand | Material-Civil | cft | 13 |
| Brick | Material-Civil | nos | 8 |
| Filling Sand | Material-Civil | cft | 10 |
| Excavation up to 10ft | Labour-Substructure-2 | cft | 3.5 |
| Excavation from 11ft to 20 ft | Labour-Substructure-2 | cft | 5.75 |
| Excavation from 21ft to 30 ft | Labour-Substructure-2 | cft | 10.5 |
| Excavation from 31ft to 33'-5" | Labour-Substructure-2 | cft | 12.75 |
| King Post- MS Pipe -250mm dia | Material-MS | ton | 49700 |
| MS Plate-12mm thick | Material-MS | ton | 56700 |
| I Joist (6"x14"/6"x16"x10/12mm) | Material-MS | ton | 64500 |
| Bracing-MS Pipe Driving | Labour-Substructure-2 | nos | 5000 |
| Bracing-MS Joist Fixing | Labour-Substructure-2 | kg | 5 |
| Bracing-MS Joist Removing | Labour-Substructure-2 | kg | 2.5 |
| Anchor Bolt-1/2" dia 6" Long | Material-MS | Nos | 147 |
| Readymix CC-2500 psi | Material-Civil | cft | 185 |
| Water Stopper-6" Width | Material-Civil | rft | 50 |
| Polythene (0.2mm thick) | Material-Civil | sft | 5.5 |
| Structural Work-Mat | Labour-Substructure-2 | sft | 200 |
| Structural Work-B2 Slab | Labour-Substructure-2 | sft | 195 |
| Structural Work-B1 Slab | Labour-Substructure-2 | sft | 190 |
| Structural Work-GF Slab | Labour-Substructure-2 | sft | 185 |
| Anchor Bolt-1/2" dia 8" Long | Material-MS | Nos. | 60 |
| Anchor Bolt-1/2" dia 7" Long | Material-MS | Nos. | 58 |
| Rowel Bolt-1/2" dia 4" Long | Material-MS | Nos. | 33.28 |
| Bonding Chemical | Material-Civil | L | 1600 |
| Water Stopper-8" Width | Material-Civil | rft | 80 |
| Excavation above 0.0 | Labour-Substructure-2 | cft | 3.5 |
| Readymix Concrete-4500 psi | Material-Civil | cft | 221 |
| Readymix Concrete-3500 psi | Material-Civil | cft | 202 |
| MS Rod - Grade 60 | Material-Civil | ton | 54000 |

## Schedule

| ID | WBS | Task | Duration | Start | Finish | Predecessors | Complete | Remaining | Baseline start | Baseline finish | Baseline duration | Total slack | Cost | Actual cost |
| --- | --- | --- | --- | --- | --- | --- | --- | --- | --- | --- | --- | --- | --- | --- |
| 1 | 1 | **EKUSHEY BHABAN** | 927.86d | 2010-01-25 A | 2012-09-19 |  | 18% | 760.95d | 2010-03-26 | 2012-09-12 | 862d | 0d | 40,294,879.77 | 25,924,614.76 |
| 2 | 1.1 | **PRELIMINARIES** | 911.86d | 2010-01-25 A | 2012-08-28 |  | 87% | 119.86d | 2010-03-26 | 2012-08-21 | 846d | 16d |  |  |
| 3 | 1.1.1 | **MOBILIZATION-1-TEMPORARY OFFICE-SHED** | 82d | 2010-01-25 A | 2010-04-16 A |  | 100% |  | 2010-03-26 | 2010-04-16 | 22d |  |  |  |
| 4 | 1.1.1.1 | Mud Tank | 9d | 2010-01-25 A | 2010-02-02 A |  | 100% |  | 2010-03-26 | 2010-03-26 | 9d |  |  |  |
| 5 | 1.1.1.2 | Land Development | 4d | 2010-02-03 A | 2010-02-06 A | 4 | 100% |  | 2010-04-04 | 2010-04-04 | 4d |  |  |  |
| 6 | 1.1.1.3 | Office Shed | 4d | 2010-04-08 A | 2010-04-11 A | 5 | 100% |  | 2010-04-08 | 2010-04-08 | 4d |  |  |  |
| 7 | 1.1.1.4 | Labour Shed | 4d | 2010-04-08 A | 2010-04-11 A | 6SS | 100% |  | 2010-04-08 | 2010-04-08 | 4d |  |  |  |
| 8 | 1.1.1.5 | Cement Store | 4d | 2010-04-08 A | 2010-04-11 A | 6SS | 100% |  | 2010-04-08 | 2010-04-08 | 4d |  |  |  |
| 9 | 1.1.1.6 | Staff Residence | 4d | 2010-04-08 A | 2010-04-11 A | 6SS | 100% |  | 2010-04-08 | 2010-04-08 | 4d |  |  |  |
| 10 | 1.1.1.7 | Toilet | 7d | 2010-04-08 A | 2010-04-14 A | 6SS | 100% |  | 2010-04-08 | 2010-04-08 | 7d |  |  |  |
| 11 | 1.1.1.8 | Main Gate-1 | 7d | 2010-04-04 A | 2010-04-10 A | 4 | 100% |  | 2010-04-04 | 2010-04-04 | 7d |  |  |  |
| 12 | 1.1.1.9 | Electrical Wiring | 2d | 2010-04-15 A | 2010-04-16 A | 10 | 100% |  | 2010-04-15 | 2010-04-15 | 2d |  |  |  |
| 13 | 1.1.2 | **MOBILIZATION-2 -INFRASTRUCTURE** | 15d | 2010-08-11 A | 2010-08-25 A |  | 100% |  | 2010-08-11 | 2010-08-25 | 15d |  |  |  |
| 14 | 1.1.2.1 | East Side Bed Preparation | 2d | 2010-08-11 A | 2010-08-12 A | 57FS-5d | 100% |  | 2010-08-11 | 2010-08-12 | 2d |  |  |  |
| 15 | 1.1.2.2 | Labour Shed & Kitchen Making | 9d | 2010-08-12 A | 2010-08-20 A | 14FS-1d | 100% |  | 2010-08-12 | 2010-08-20 | 9d |  |  |  |
| 16 | 1.1.2.3 | South Side Bed Preparation | 3d | 2010-08-12 A | 2010-08-14 A | 14FS-1d | 100% |  | 2010-08-12 | 2010-08-14 | 3d |  |  |  |
| 17 | 1.1.2.4 | Cement Shed, Residence, Office & Toilet Making | 8d | 2010-08-13 A | 2010-08-20 A | 16SS+1d | 100% |  | 2010-08-13 | 2010-08-20 | 8d |  |  |  |
| 18 | 1.1.2.5 | North Side Bed Preparation | 4d | 2010-08-22 A | 2010-08-25 A | 17FS+1d | 100% |  | 2010-08-22 | 2010-08-25 | 4d |  |  |  |
| 19 | 1.1.2.6 | Soling, CC for Woking Bed | 3d | 2010-08-23 A | 2010-08-25 A | 18FF | 100% |  | 2010-08-23 | 2010-08-25 | 3d |  |  |  |
| 20 | 1.1.2.7 | West Side Bed Preparation | 3d | 2010-08-15 A | 2010-08-17 A | 16 | 100% |  | 2010-08-15 | 2010-08-17 | 3d |  |  |  |
| 21 | 1.1.2.8 | Security Room Making | 7d | 2010-08-16 A | 2010-08-22 A | 20FS-2d | 100% |  | 2010-08-16 | 2010-08-22 | 7d |  |  |  |
| 22 | 1.1.2.9 | Water Tank Tower Making & Shifting of Water Line From West to Est | 9d | 2010-08-12 A | 2010-08-20 A | 14SS+1d | 100% |  | 2010-08-12 | 2010-08-20 | 9d |  |  |  |
| 23 | 1.1.2.10 | Rain Water Drainage System (South) | 8d | 2010-08-13 A | 2010-08-20 A | 16SS+1d | 100% |  | 2010-08-13 | 2010-08-20 | 8d |  |  |  |
| 24 | 1.1.2.11 | Rain Water Drainage System (East) | 9d | 2010-08-12 A | 2010-08-20 A | 14FS-1d, 23FF | 100% |  | 2010-08-12 | 2010-08-20 | 9d |  |  |  |
| 25 | 1.1.2.12 | Water Reservoir Making (North) | 4d | 2010-08-22 A | 2010-08-25 A | 18FF | 100% |  | 2010-08-22 | 2010-08-25 | 4d |  |  |  |
| 26 | 1.1.2.13 | Generator Base Making | 8d | 2010-08-13 A | 2010-08-20 A | 23SS | 100% |  | 2010-08-13 | 2010-08-20 | 8d |  |  |  |
| 27 | 1.1.2.14 | Electrical Pipe Wiring | 6d | 2010-08-20 A | 2010-08-25 A | 26FS-1d | 100% |  | 2010-08-20 | 2010-08-25 | 6d |  |  |  |

| ID | WBS | Task | Duration | Start | Finish | Predecessors | Complete | Remaining | Baseline start | Baseline finish | Baseline duration | Total slack | Free slack | Constraint | Cost | Actual cost | Text1 |
| --- | --- | --- | --- | --- | --- | --- | --- | --- | --- | --- | --- | --- | --- | --- | --- | --- | --- |
| 28 | 1.1.3 | **MOBILIZATION-3-GENERATOR & TOWER CRANE** | 33d | 2010-07-29 A | 2010-08-30 A |  | 100% |  | 2010-07-29 | 2010-08-30 | 33d |  |  |  |  |  |  |
| 29 | 1.1.3.1 | **Generator** | 33d | 2010-07-29 A | 2010-08-30 A |  | 100% |  | 2010-07-29 | 2010-08-30 | 0d? |  |  |  |  |  |  |
| 30 | 1.1.3.1.1 | Supply | 30d | 2010-07-29 A | 2010-08-27 A | 31FF-3d | 100% |  | 2010-07-29 | 2010-08-27 | 0d? |  |  |  |  |  |  |
| 31 | 1.1.3.1.2 | Installation | 3d | 2010-08-28 A | 2010-08-30 A | 26FS+7d | 100% |  | 2010-08-28 | 2010-08-30 | 0d? |  |  |  |  |  |  |
| 32 | 1.1.4 | **PREPARATION FOR STRUCTURAL CONSTRUCTION** | 115d | 2010-08-21 A | 2010-12-28 A |  | 100% |  | 2010-08-21 | 2010-12-31 | 111d |  |  |  |  |  |  |
| 33 | 1.1.4.1 | Selection of Civil Contractor | 35d | 2010-08-21 A | 2010-10-01 A | 54 | 100% |  | 2010-08-21 | 2010-10-01 | 35d |  |  | finish no earlier than 2010-10-01 |  |  |  |
| 34 | 1.1.4.2 | Develop of Construction Method | 30d | 2010-09-02 A | 2010-10-08 A | 103 | 100% |  | 2010-09-02 | 2010-10-08 | 30d |  |  |  |  |  |  |
| 35 | 1.1.4.3 | Selection of Ready-mix Supplier | 7d | 2010-11-01 A | 2010-11-07 A | 103SF-7d | 100% |  | 2010-09-17 | 2010-09-23 | 7d |  |  |  |  |  |  |
| 36 | 1.1.4.4 | Structural Design Vetting From BUET | 45d | 2010-09-27 A | 2010-11-10 A | 107SF-7d | 100% |  | 2010-08-25 | 2010-10-15 | 45d |  |  | start no earlier than 2010-08-25 |  |  |  |
| 37 | 1.1.4.5 | Drill Work for Safety/ Safety Induction | 2d | 2010-11-02 A | 2010-11-03 A | 73FF | 100% |  | 2010-11-30 | 2010-12-01 | 2d |  |  |  |  |  |  |
| 38 | 1.1.4.6 | Selection & Agreement With Clinic for Medical Service | 7d | 2010-11-04 A | 2010-11-10 A | 36FF | 100% |  | 2010-10-09 | 2010-10-15 | 7d |  |  |  |  |  |  |
| 39 | 1.1.4.7 | Design Collection & Estimation of Structural Cost | 40d | 2010-11-11 A | 2010-12-28 A | 36 | 100% |  | 2010-11-04 | 2010-12-01 | 20d |  |  |  |  |  |  |
| 40 | 1.1.4.8 | Selection of MEP Contractor | 10d | 2010-11-04 A | 2010-11-13 A | 108FF-15d | 100% |  | 2010-12-21 | 2010-12-30 | 10d |  |  |  |  |  |  |
| 41 | 1.1.5 | **MOBILIZATION-4-TOWER CRANE** | 32d | 2011-09-28 | 2011-10-30 |  |  |  | 2011-09-23 | 2011-10-25 | 32d | 307d |  |  |  |  |  |
| 42 | 1.1.5.1 | Selection | 15d | 2011-09-28 | 2011-10-13 | 43SF |  |  | 2011-09-23 | 2011-10-09 | 0d? | 324d |  |  |  |  |  |
| 43 | 1.1.5.2 | Foundation | 3d | 2011-10-13 | 2011-10-16 | 44SF-7d |  |  | 2011-10-08 | 2011-10-12 | 0d? | 321d | 0d |  |  |  |  |
| 44 | 1.1.5.3 | Installation | 7d | 2011-10-23 | 2011-10-30 | 557 |  |  | 2011-10-18 | 2011-10-25 | 0d? | 307d | 0d |  |  |  |  |
| 45 | 1.1.6 | **MOBILIZATION-5-LIFTING HOIST** | 7d | 2012-05-22 | 2012-05-29 |  |  |  | 2012-05-17 | 2012-05-24 | 7d | 103d |  |  |  |  |  |
| 46 | 1.1.6.1 | Lifting Hoist Installation | 7d | 2012-05-22 | 2012-05-29 | 939 |  |  | 2012-05-17 | 2012-05-24 | 0d? | 103d |  |  |  |  |  |
| 47 | 1.1.7 | **DEMOBILIZATION** | 78d | 2012-06-07 | 2012-08-28 |  |  |  | 2012-06-02 | 2012-08-21 | 78d | 0d |  |  |  |  |  |
| 48 | 1.1.7.1 | Dismantling Tower Crane | 2d | 2012-06-07 | 2012-06-09 | 930 |  |  | 2012-06-02 | 2012-06-04 | 0d? | 9d | 0d |  |  |  |  |
| 49 | 1.1.7.2 | Dismatle Lifting Hoist | 2d | 2012-08-07 | 2012-08-09 | 941 |  |  | 2012-08-02 | 2012-08-04 | 0d? | 0d |  |  |  |  |  |
| 50 | 1.1.7.3 | Dismantling Infrastructure | 15d | 2012-08-09 | 2012-08-28 | 49 |  |  | 2012-08-04 | 2012-08-21 | 0d? | 0d |  |  |  |  |  |
| 51 | 1.2 | **SUB-STRUCTURE** | 380.86d | 2010-04-18 A | 2011-05-18 |  | 62% | 145.11d | 2010-04-18 | 2011-05-13 | 375d | 464d |  |  | 40,294,879.77 | 25,924,614.76 |  |
| 52 | 1.2.1 | **PART-1** | 120d | 2010-04-18 A | 2010-08-15 A |  | 100% |  | 2010-04-18 | 2010-08-15 | 120d |  |  |  |  |  |  |
| 53 | 1.2.1.1 | SHORE PILING (50 ft) | 100d | 2010-04-18 A | 2010-07-26 A | 3FS+1d | 100% |  | 2010-04-18 | 2010-07-26 | 100d |  |  |  |  |  | Nos. |

| ID | WBS | Task | Duration | Start | Finish | Predecessors | Complete | Remaining | Baseline start | Baseline finish | Baseline duration | Total slack | Constraint | Resources | Cost | Actual cost | Text1 |
| --- | --- | --- | --- | --- | --- | --- | --- | --- | --- | --- | --- | --- | --- | --- | --- | --- | --- |
| 54 | 1.2.1.2 | **PERIMETER BEAM** | 20d | 2010-07-27 A | 2010-08-15 A |  | 100% |  | 2010-07-27 | 2010-08-15 | 20d |  |  |  |  |  | ft |
| 55 | 1.2.1.2.1 | Excavation for PileHead Breaking | 15d | 2010-07-27 A | 2010-08-10 A | 53 | 100% |  | 2010-07-27 | 2010-08-10 | 15d |  |  |  |  |  |  |
| 56 | 1.2.1.2.2 | Pile Head Breaking | 15d | 2010-07-29 A | 2010-08-12 A | 55SS+2d | 100% |  | 2010-07-29 | 2010-08-12 | 15d |  |  |  |  |  |  |
| 57 | 1.2.1.2.3 | Re bar Work & Concreting | 16d | 2010-07-30 A | 2010-08-15 A | 56SS+2d | 100% |  | 2010-07-31 | 2010-08-15 | 16d |  |  |  |  |  |  |
| 58 | 1.2.2 | **PART-2** | 220.86d | 2010-10-02 A | 2011-05-18 |  | 54% | 102.02d | 2010-10-02 | 2011-05-12 | 215d | 464d |  |  | 40,294,879.77 | 25,924,614.76 |  |
| 59 | 1.2.2.1 | **EXCAVATION** | 57d | 2010-10-02 A | 2010-12-05 A |  | 100% |  | 2010-10-02 | 2010-12-31 | 83d |  |  |  | 8,349,642.78 | 8,349,642.78 |  |
| 60 | 1.2.2.1.1 | Mobilization-1 (Equipment) | 5d | 2010-10-02 A | 2010-10-06 A | 33 | 100% |  | 2010-10-02 | 2010-10-06 | 5d |  |  |  |  |  |  |
| 61 | 1.2.2.1.2 | **Mobilization-2(Bracing)** | 44d | 2010-10-11 A | 2010-12-01 A | 60SS | 100% |  | 2010-10-02 | 2010-10-16 | 15d |  |  |  | 5,823,256 | 5,823,256 |  |
| 62 | 1.2.2.1.2.1 | MS Pipe | 1d | 2010-10-11 A | 2010-10-11 A |  | 100% |  |  |  |  |  |  | King Post- MS Pipe -250mm dia [8 ton]; MS Plate-12mm thick [2.5 ton] | 539,350 | 539,350 |  |
| 63 | 1.2.2.1.2.2 | MS Joist -1 | 1d | 2010-10-20 A | 2010-10-20 A |  | 100% |  |  |  |  |  | must finish on 2010-10-20 | I Joist (6"x14"/6"x16"x10/12mm) [17 ton]; Anchor Bolt-1/2" dia 6" Long [350 Nos]; Anchor Bolt-1/2" dia 7" Long [100 Nos.]; Anchor Bolt-1/2" dia 8" Long [1000 Nos.]; Rowel Bolt-1/2" dia 4" Long [200 Nos.] | 1,220,406 | 1,220,406 |  |
| 64 | 1.2.2.1.2.3 | MS Joist -2 | 1d | 2010-10-27 A | 2010-10-27 A |  | 100% |  |  |  |  |  | must finish on 2010-10-27 | I Joist (6"x14"/6"x16"x10/12mm) [16 ton] | 1,032,000 | 1,032,000 |  |
| 65 | 1.2.2.1.2.4 | MS Joist -3 | 1d | 2010-11-03 A | 2010-11-03 A |  | 100% |  |  |  |  |  | must finish on 2010-11-03 | I Joist (6"x14"/6"x16"x10/12mm) [20.5 ton] | 1,322,250 | 1,322,250 |  |
| 66 | 1.2.2.1.2.5 | MS Joist -4 | 0.5d | 2010-12-01 A | 2010-12-01 A |  | 100% |  |  |  |  |  | must start on 2010-12-01 | I Joist (6"x14"/6"x16"x10/12mm) [26.5 ton] | 1,709,250 | 1,709,250 |  |
| 67 | 1.2.2.1.2.6 | MS Joist -5 | 1d | 2010-12-01 A | 2010-12-01 A |  | 100% |  |  |  |  |  | must finish on 2010-12-01 |  |  |  |  |
| 68 | 1.2.2.1.3 | **Excavation-Part-1** | 19d | 2010-10-04 A | 2010-10-22 A |  | 100% |  | 2010-10-04 | 2010-10-21 | 18d |  |  |  | 529,793.65 | 529,793.65 | cft |
| 69 | 1.2.2.1.3.1 | Section # a/d : East to west 0' to 30' span | 4d | 2010-10-04 A | 2010-10-07 A | 60SS+2d | 100% |  |  |  |  |  |  | Excavation up to 10ft [20775.2 cft]; Excavation from 11ft to 20 ft [10388.1 cft] | 132,444.94 | 132,444.94 |  |
| 70 | 1.2.2.1.3.2 | Section # b/c : East to west 31' to 60' span | 4d | 2010-10-08 A | 2010-10-11 A | 69 | 100% |  |  |  |  |  |  | Excavation up to 10ft [20777.2 cft]; Excavation from 11ft to 20 ft [10388.1 cft] | 132,451.9 | 132,451.9 |  |
| 71 | 1.2.2.1.3.3 | Section # c/b : East to west 61' to 90' span | 4d | 2010-10-12 A | 2010-10-15 A | 70 | 100% |  |  |  |  |  |  | Excavation up to 10ft [20776.2 cft]; Excavation from 11ft to 20 ft [10388.1 cft] | 132,448.4 | 132,448.4 |  |
| 72 | 1.2.2.1.3.4 | Section # d/a : East to west 91' to 112' span | 7d | 2010-10-16 A | 2010-10-22 A | 71 | 100% |  |  |  |  |  |  | Excavation up to 10ft [20776.2 cft]; Excavation from 11ft to 20 ft [10388.1 cft] | 132,448.4 | 132,448.4 |  |
| 73 | 1.2.2.1.4 | **Bracing** | 21d | 2010-10-14 A | 2010-11-03 A |  | 100% |  | 2010-10-21 | 2010-12-01 | 34d |  |  |  | 300,000 | 300,000 |  |
| 74 | 1.2.2.1.4.1 | **Pipe driving work** | 18d | 2010-10-14 A | 2010-10-31 A |  | 100% |  |  |  |  |  |  |  | 60,000 | 60,000 |  |
| 75 | 1.2.2.1.4.1.1 | Section # d : East to west 0' to 30' span | 6d | 2010-10-14 A | 2010-10-19 A | 70FS+2d | 100% |  |  |  |  |  |  | Bracing-MS Pipe Driving [3 nos] | 15,000 | 15,000 |  |
| 76 | 1.2.2.1.4.1.2 | Section # c : East to west 31' to 60' span | 6d | 2010-10-18 A | 2010-10-23 A | 75FF+4d | 100% |  |  |  |  |  |  | Bracing-MS Pipe Driving [3 nos] | 15,000 | 15,000 |  |
| 77 | 1.2.2.1.4.1.3 | Section # b : East to west 61' to 90' span | 6d | 2010-10-22 A | 2010-10-27 A | 76FF+4d | 100% |  |  |  |  |  |  | Bracing-MS Pipe Driving [3 nos] | 15,000 | 15,000 |  |
| 78 | 1.2.2.1.4.1.4 | Section # a : East to west 91' to 112' span | 6d | 2010-10-26 A | 2010-10-31 A | 77FF+4d | 100% |  |  |  |  |  |  | Bracing-MS Pipe Driving [3 nos] | 15,000 | 15,000 |  |

| ID | WBS | Task | Type | Duration | Start | Finish | Predecessors | Complete | Baseline start | Baseline finish | Baseline duration | Resources | Cost | Actual cost | Text1 |
| --- | --- | --- | --- | --- | --- | --- | --- | --- | --- | --- | --- | --- | --- | --- | --- |
| 79 | 1.2.2.1.4.2 | **Peripheral joist setting work** |  | 18d | 2010-10-17 A | 2010-11-03 A |  | 100% |  |  |  |  | 240,000 | 240,000 |  |
| 80 | 1.2.2.1.4.2.1 | Section # d : East to west 0' to 30' span |  | 6d | 2010-10-17 A | 2010-10-22 A | 75SS+3d | 100% |  |  |  | Bracing-MS Joist Fixing [12000 kg] | 60,000 | 60,000 |  |
| 81 | 1.2.2.1.4.2.2 | Section # c : East to west 31' to 60' span |  | 6d | 2010-10-21 A | 2010-10-26 A | 80FF+4d | 100% |  |  |  | Bracing-MS Joist Fixing [12000 kg] | 60,000 | 60,000 |  |
| 82 | 1.2.2.1.4.2.3 | Section # b : East to west 61' to 90' span |  | 6d | 2010-10-25 A | 2010-10-30 A | 81FF+4d | 100% |  |  |  | Bracing-MS Joist Fixing [12000 kg] | 60,000 | 60,000 |  |
| 83 | 1.2.2.1.4.2.4 | Section # a : East to west 91' to 112' span |  | 6d | 2010-10-29 A | 2010-11-03 A | 82FF+4d | 100% |  |  |  | Bracing-MS Joist Fixing [12000 kg] | 60,000 | 60,000 |  |
| 84 | 1.2.2.1.5 | **Earth excavation - Phase 2 : (16' to 32')** |  | 29d | 2010-10-15 A | 2010-11-12 A |  | 100% | 2010-10-26 | 2010-12-31 | 59d |  | 1,111,527.77 | 1,111,527.77 |  |
| 85 | 1.2.2.1.5.1 | Section # d : East to west 0' to 30' span |  | 14d | 2010-10-15 A | 2010-10-28 A | 75SS+1d | 100% |  |  |  | Excavation from 11ft to 20 ft [10388.1 cft]; Excavation from 21ft to 30 ft [20776.2 cft] | 277,881.94 | 277,881.94 |  |
| 86 | 1.2.2.1.5.2 | Section # c : East to west 31' to 60' span |  | 14d | 2010-10-19 A | 2010-11-01 A | 85FF+4d | 100% |  |  |  | Excavation from 11ft to 20 ft [10388.1 cft]; Excavation from 21ft to 30 ft [20776.2 cft] | 277,881.94 | 277,881.94 |  |
| 87 | 1.2.2.1.5.3 | Section # b : East to west 61' to 90' span |  | 14d | 2010-10-23 A | 2010-11-05 A | 86FF+4d | 100% |  |  |  | Excavation from 11ft to 20 ft [10388.1 cft]; Excavation from 21ft to 30 ft [20776.2 cft] | 277,881.94 | 277,881.94 |  |
| 88 | 1.2.2.1.5.4 | Section # a : East to west 91' to 112' span |  | 14d | 2010-10-30 A | 2010-11-12 A | 87FF+7d | 100% |  |  |  | Excavation from 11ft to 20 ft [10388.1 cft]; Excavation from 21ft to 30 ft [20776.2 cft] | 277,881.94 | 277,881.94 |  |
| 89 | 1.2.2.1.6 | **Diagonal joist setting work** |  | 27d | 2010-10-24 A | 2010-11-27 A |  | 100% |  |  |  |  | 176,250 | 176,250 |  |
| 90 | 1.2.2.1.6.1 | Section # a : East to west 0' to 30' span |  | 10d | 2010-10-24 A | 2010-11-02 A | 80FS+1d | 100% |  |  |  | Bracing-MS Joist Fixing [9000 kg] | 45,000 | 45,000 |  |
| 91 | 1.2.2.1.6.2 | Section # b : East to west 31' to 60' span |  | 10d | 2010-10-28 A | 2010-11-06 A | 90FF+4d | 100% |  |  |  | Bracing-MS Joist Fixing [9000 kg] | 45,000 | 45,000 |  |
| 92 | 1.2.2.1.6.3 | Section # c : East to west 61' to 90' span |  | 10d | 2010-11-01 A | 2010-11-10 A | 91FF+4d | 100% |  |  |  | Bracing-MS Joist Fixing [9000 kg] | 45,000 | 45,000 |  |
| 93 | 1.2.2.1.6.4 | Section # d : East to west 91' to 112' span |  | 14d | 2010-11-06 A | 2010-11-27 A | 92FF+9d | 100% |  |  |  | Bracing-MS Joist Fixing [8250 kg] | 41,250 | 41,250 |  |
| 94 | 1.2.2.1.7 | **Earth excavn.-Phase 3: Barm+ extra** |  | 33d | 2010-10-26 A | 2010-12-05 A |  | 100% |  |  |  |  | 408,815.36 | 408,815.36 |  |
| 95 | 1.2.2.1.7.1 | Section # a/d : East to west 0' to 30' span |  | 15d | 2010-10-26 A | 2010-11-09 A | 90SS+2d | 100% |  |  |  | Excavation from 31ft to 33'-5" [7105.47 cft] | 90,594.74 | 90,594.74 |  |
| 96 | 1.2.2.1.7.2 | Section # b/c : East to west 31' to 60' span |  | 15d | 2010-10-29 A | 2010-11-12 A | 95FF+3d | 100% |  |  |  | Excavation from 31ft to 33'-5" [7105.47 cft] | 90,594.74 | 90,594.74 |  |
| 97 | 1.2.2.1.7.3 | Section # c/b : East to west 61' to 90' span |  | 15d | 2010-11-05 A | 2010-11-27 A | 96FF+7d | 100% |  |  |  | Excavation from 31ft to 33'-5" [7105.47 cft] | 90,594.74 | 90,594.74 |  |
| 98 | 1.2.2.1.7.4 | Section # d/a : East to west 91' to 112' span |  | 15d | 2010-11-13 A | 2010-12-05 A | 97FF+8d | 100% |  |  |  | Excavation from 31ft to 33'-5" [7105.47 cft]; Excavation above 0.0 [13267.5 cft] | 137,031.13 | 137,031.13 |  |
| 99 | 1.2.2.2 | **Mat Foundation** |  | 39.17d | 2010-11-03 A | 2010-12-20 A |  | 100% | 2010-12-25 | 2011-02-07 | 45d |  | 14,236,143.03 | 14,236,143.03 |  |
| 100 | 1.2.2.2.1 | **Part-1-Section # a : East to west 0' to 30' span** |  | 12.5d | 2010-11-03 A | 2010-11-23 A |  | 100% | 2010-12-25 | 2011-01-16 | 23d |  | 4,904,351.25 | 4,904,351.25 |  |
| 101 | 1.2.2.2.1.1 | Bed Preparation |  | 3d | 2010-11-03 A | 2010-11-10 A | 95FF+1d | 100% | 2010-12-25 | 2010-12-31 | 7d | MS Rod - Grade 60 [47.5 ton] | 2,565,000 | 2,565,000 | sft |
| 102 | 1.2.2.2.1.2 | 2-Layer Polythene |  | 0.5d | 2010-11-10 A | 2010-11-10 A | 101FF | 100% | 2011-01-01 | 2011-01-01 | 1d | Polythene (0.2mm thick) [3411.8 sft] | 18,764.9 | 18,764.9 | sft |
| 103 | 1.2.2.2.1.3 | Lean Concrete |  | 0.5d | 2010-11-11 A | 2010-11-11 A | 102 | 100% | 2011-01-02 | 2010-01-02 | 1d | Readymix CC-2500 psi [882.88 cft] | 163,332.8 | 163,332.8 | cft |
| 104 | 1.2.2.2.1.4 | Peripherial Brick Work | milestone | 0d | 2010-11-11 A | 2010-11-11 A | 103FF | 100% | 2011-01-03 | 2011-01-03 | 1d |  |  |  |  |
| 105 | 1.2.2.2.1.5 | Plaster | milestone | 0d | 2010-11-11 A | 2010-11-11 A | 104FF | 100% | 2011-01-04 | 2011-01-04 | 1d |  |  |  |  |
| 106 | 1.2.2.2.1.6 | Water Proofing | milestone | 0d | 2010-11-11 A | 2010-11-11 A | 105FF | 100% | 2011-01-08 | 2011-01-09 | 2d |  |  |  |  |
| 107 | 1.2.2.2.1.7 | Re-Bar Fabrication |  | 3d | 2010-11-11 A | 2010-11-14 A | 106 | 100% | 2011-01-10 | 2011-01-13 | 4d |  |  |  | ton |
| 108 | 1.2.2.2.1.8 | MEP Works |  | 1d | 2010-11-10 A | 2010-11-11 A | 106FF | 100% | 2011-01-14 | 2011-01-14 | 1d |  |  |  |  |
| 109 | 1.2.2.2.1.9 | Inspection |  | 1d | 2010-11-13 A | 2010-11-14 A | 107FF | 100% | 2011-01-15 | 2011-01-15 | 1d |  |  |  |  |
| 110 | 1.2.2.2.1.10 | Concreteing |  | 1d | 2010-11-14 A | 2010-11-23 A | 109 | 100% | 2011-01-16 | 2011-01-16 | 1d | Structural Work-Mat [2688 sft]; Water Stopper-8" Width [100 rft]; Readymix Concrete-4500 psi [7292.55 cft] | 2,157,253.55 | 2,157,253.55 | cft |

| ID | WBS | Task | Type | Duration | Start | Finish | Predecessors | Complete | Baseline start | Baseline finish | Baseline duration | Resources | Cost | Actual cost | Text1 |
| --- | --- | --- | --- | --- | --- | --- | --- | --- | --- | --- | --- | --- | --- | --- | --- |
| 111 | 1.2.2.2.2 | **Part-2-Section # b : East to west 31' to 60' span** |  | 15.18d | 2010-11-24 A | 2010-12-09 A |  | 100% | 2011-01-01 | 2011-01-24 | 24d |  | 4,565,833.39 | 4,565,833.39 |  |
| 112 | 1.2.2.2.2.1 | Bed Preparation |  | 7d | 2010-11-24 A | 2010-12-01 A | 101, 96FS+3d | 100% | 2011-01-01 | 2011-01-08 | 7d | MS Rod - Grade 60 [22.63 ton] | 1,222,020 | 1,222,020 | sft |
| 113 | 1.2.2.2.2.2 | 2-Layer Polythene |  | 1d | 2010-11-30 A | 2010-12-01 A | 112FF | 100% | 2011-01-09 | 2011-01-09 | 1d | Polythene (0.2mm thick) [3411.8 sft] | 18,764.9 | 18,764.9 | sft |
| 114 | 1.2.2.2.2.3 | Lean Concrete |  | 1d | 2010-12-01 A | 2010-12-02 A | 113 | 100% | 2011-01-10 | 2011-01-10 | 1d | Readymix CC-2500 psi [680.48 cft] | 125,888.8 | 125,888.8 | cft |
| 115 | 1.2.2.2.2.4 | Peripherial Brick Work | milestone | 0d | 2010-12-02 A | 2010-12-02 A | 114FF | 100% | 2011-01-11 | 2011-01-11 | 1d |  |  |  |  |
| 116 | 1.2.2.2.2.5 | Plaster | milestone | 0d | 2010-12-02 A | 2010-12-02 A | 115FF | 100% | 2011-01-12 | 2011-01-12 | 1d |  |  |  |  |
| 117 | 1.2.2.2.2.6 | Water Proofing | milestone | 0d | 2010-12-02 A | 2010-12-02 A | 116FF | 100% | 2011-01-16 | 2011-01-17 | 2d |  |  |  |  |
| 118 | 1.2.2.2.2.7 | Re-Bar Fabrication |  | 5d | 2010-12-02 A | 2010-12-07 A | 117 | 100% | 2011-01-18 | 2011-01-21 | 4d |  |  |  | ton |
| 119 | 1.2.2.2.2.8 | MEP Works |  | 1d | 2010-12-06 A | 2010-12-07 A | 118FF | 100% | 2011-01-22 | 2011-01-22 | 1d |  |  |  |  |
| 120 | 1.2.2.2.2.9 | Inspection |  | 1d | 2010-12-06 A | 2010-12-07 A | 119FF | 100% | 2011-01-23 | 2011-01-23 | 1d |  |  |  |  |
| 121 | 1.2.2.2.2.10 | Concreteing |  | 3d | 2010-12-06 A | 2010-12-09 A | 120FF+2d | 100% | 2011-01-24 | 2011-01-24 | 1d | Structural Work-Mat [2688 sft]; Bonding Chemical [9.83 L]; Water Stopper-8" Width [100 rft]; Readymix Concrete-4500 psi [11935.9 cft] | 3,199,159.69 | 3,199,159.69 | cft |
| 122 | 1.2.2.2.3 | **Part-3-Section # d : East to west 91' to 112' span** |  | 24.68d | 2010-11-25 A | 2010-12-20 A |  | 100% | 2011-01-09 | 2011-01-31 | 23d |  | 4,765,958.39 | 4,765,958.39 |  |
| 123 | 1.2.2.2.3.1 | Bed Preparation |  | 8d | 2010-11-25 A | 2010-12-09 A | 112FF+8d, 97FF+1d | 100% | 2011-01-09 | 2011-01-15 | 7d | MS Rod - Grade 60 [22.63 ton] | 1,222,020 | 1,222,020 | sft |
| 124 | 1.2.2.2.3.2 | 2-Layer Polythene |  | 1d | 2010-12-09 A | 2010-12-10 A | 123 | 100% | 2011-01-16 | 2011-01-16 | 1d | Polythene (0.2mm thick) [3411.8 sft] | 18,764.9 | 18,764.9 | sft |
| 125 | 1.2.2.2.3.3 | Lean Concrete |  | 2d | 2010-12-10 A | 2010-12-12 A | 124 | 100% | 2011-01-17 | 2011-01-17 | 1d | Readymix CC-2500 psi [680.48 cft] | 125,888.8 | 125,888.8 | cft |
| 126 | 1.2.2.2.3.4 | Peripherial Brick Work | milestone | 0d | 2010-12-12 A | 2010-12-12 A | 125FF | 100% | 2011-01-18 | 2011-01-18 | 1d |  |  |  |  |
| 127 | 1.2.2.2.3.5 | Plaster | milestone | 0d | 2010-12-12 A | 2010-12-12 A | 126FF | 100% | 2011-01-19 | 2011-01-19 | 1d |  |  |  |  |
| 128 | 1.2.2.2.3.6 | Water Proofing | milestone | 0d | 2010-12-12 A | 2010-12-12 A | 127FF | 100% | 2011-01-23 | 2011-01-24 | 2d |  |  |  |  |
| 129 | 1.2.2.2.3.7 | Re-Bar Fabrication |  | 6d | 2010-12-12 A | 2010-12-18 A | 128 | 100% | 2011-01-25 | 2011-01-28 | 4d |  |  |  | ton |
| 130 | 1.2.2.2.3.8 | MEP Works |  | 1d | 2010-12-17 A | 2010-12-18 A | 129FF | 100% | 2011-01-29 | 2011-01-29 | 1d |  |  |  |  |
| 131 | 1.2.2.2.3.9 | Inspection |  | 1d | 2010-12-17 A | 2010-12-18 A | 130FF | 100% | 2011-01-30 | 2011-01-30 | 1d |  |  |  |  |
| 132 | 1.2.2.2.3.10 | Concreteing |  | 3d | 2010-12-17 A | 2010-12-20 A | 131FF+2d | 100% | 2011-01-31 | 2011-01-31 | 1d | Structural Work-Mat [2688 sft]; Bonding Chemical [9.83 L]; Bracing-MS Joist Removing [83250 kg]; Readymix Concrete-4500 psi [11935.9 cft] | 3,399,284.69 | 3,399,284.69 | cft |
| 133 | 1.2.2.2.4 | **Part-4-Section # d : East to west 91' to 112' span** |  | 0d | 2010-12-20 A | 2010-12-20 A |  | 100% | 2011-01-16 | 2011-02-07 | 23d |  |  |  |  |
| 134 | 1.2.2.2.4.1 | Bed Preparation | milestone | 0d | 2010-12-20 A | 2010-12-20 A | 132FF | 100% | 2011-01-16 | 2011-01-22 | 7d |  |  |  | sft |
| 135 | 1.2.2.2.4.2 | 2-Layer Polythene | milestone | 0d | 2010-12-20 A | 2010-12-20 A | 134FF | 100% | 2011-01-23 | 2011-01-23 | 1d |  |  |  | sft |
| 136 | 1.2.2.2.4.3 | Lean Concrete | milestone | 0d | 2010-12-20 A | 2010-12-20 A | 135FF | 100% | 2011-01-24 | 2011-01-24 | 1d |  |  |  | cft |
| 137 | 1.2.2.2.4.4 | Peripherial Brick Work | milestone | 0d | 2010-12-20 A | 2010-12-20 A | 136FF | 100% | 2011-01-25 | 2011-01-25 | 1d |  |  |  |  |
| 138 | 1.2.2.2.4.5 | Plaster | milestone | 0d | 2010-12-20 A | 2010-12-20 A | 137FF | 100% | 2011-01-26 | 2011-01-26 | 1d |  |  |  |  |
| 139 | 1.2.2.2.4.6 | Water Proofing | milestone | 0d | 2010-12-20 A | 2010-12-20 A | 138FF | 100% | 2011-01-30 | 2011-01-31 | 2d |  |  |  |  |
| 140 | 1.2.2.2.4.7 | Re-Bar Fabrication | milestone | 0d | 2010-12-20 A | 2010-12-20 A | 139FF | 100% | 2011-02-01 | 2011-02-04 | 4d |  |  |  | ton |
| 141 | 1.2.2.2.4.8 | MEP Works | milestone | 0d | 2010-12-20 A | 2010-12-20 A | 140FF | 100% | 2011-02-05 | 2011-02-05 | 1d |  |  |  |  |
| 142 | 1.2.2.2.4.9 | Inspection | milestone | 0d | 2010-12-20 A | 2010-12-20 A | 141FF | 100% | 2011-02-06 | 2011-02-06 | 1d |  |  |  |  |
| 143 | 1.2.2.2.4.10 | Concreteing | milestone | 0d | 2010-12-20 A | 2010-12-20 A | 142FF | 100% | 2011-02-07 | 2011-02-07 | 1d |  |  |  | cft |

| ID | WBS | Task | Duration | Start | Finish | Predecessors | Complete | Remaining | Baseline start | Baseline finish | Baseline duration | Total slack | Free slack | Constraint | Resources | Cost | Actual cost | Text1 |
| --- | --- | --- | --- | --- | --- | --- | --- | --- | --- | --- | --- | --- | --- | --- | --- | --- | --- | --- |
| 144 | 1.2.2.3 | **BASEMENT-3** | 50.69d | 2010-12-20 A | 2011-02-08 |  | 55% | 22.61d | 2011-02-08 | 2011-03-24 | 45d | 563d |  |  |  | 4,772,059.59 | 1,878,926.99 |  |
| 145 | 1.2.2.3.1 | **LIFT-1** | 39.69d | 2010-12-20 A | 2011-01-28 |  | 83% | 6.56d | 2011-02-08 | 2011-03-03 | 24d | 574d |  |  |  | 2,685,719.07 | 1,878,737.49 |  |
| 146 | 1.2.2.3.1.1 | **Retaining Wall** | 34d | 2010-12-20 A | 2011-01-23 |  | 98% | 0.64d | 2011-02-08 | 2011-02-23 | 16d | 579.68d |  |  |  | 794,981.6 | 784,652.55 | rft |
| 147 | 1.2.2.3.1.1.1 | Brick Wall | 15d | 2010-12-20 A | 2011-01-04 A | 132 | 100% |  | 2011-02-08 | 2011-02-09 | 2d |  |  |  | Brick [4000.59 nos]; Cement [19.42 bag]; Local Sand [128.02 cft]; MS Rod - Grade 60 [4.41 ton] | 278,529.42 | 278,529.42 | sft |
| 148 | 1.2.2.3.1.1.2 | Plaster | 1d | 2011-01-03 A | 2011-01-04 A | 147FF | 100% |  | 2011-02-10 | 2011-02-10 | 1d |  |  |  |  |  |  | sft |
| 149 | 1.2.2.3.1.1.3 | Water Proofing | 3d | 2011-01-04 A | 2011-01-07 | 147 | 98% | 0.06d | 2011-02-17 | 2011-02-17 | 1d | 592.42d |  |  |  |  |  | sft |
| 150 | 1.2.2.3.1.1.4 | Re-bar Work | 6d | 2011-01-07 A | 2011-01-13 | 149 | 98% | 0.12d | 2011-02-18 | 2011-02-20 | 3d | 586.54d |  |  |  |  |  | ton |
| 151 | 1.2.2.3.1.1.5 | Form Work | 5d | 2011-01-13 A | 2011-01-18 | 150 | 98% | 0.1d | 2011-02-20 | 2011-02-21 | 2d | 581.64d |  |  | Polythene (0.2mm thick) [1 sft] | 5.5 | 5.39 | sft |
| 152 | 1.2.2.3.1.1.6 | Conreting | 2d | 2011-01-19 A | 2011-01-21 | 151FS+1d | 98% | 0.04d | 2011-02-22 | 2011-02-22 | 1d | 0d |  |  | Water Stopper-6" Width [1000 rft]; Bonding Chemical [1.87 L]; Readymix Concrete-4500 psi [2097.08 cft] | 516,446.68 | 506,117.75 | cft |
| 153 | 1.2.2.3.1.1.7 | De-shuttering | 1d | 2011-01-22 A | 2011-01-23 | 152FF+2d | 70% | 0.3d | 2011-02-23 | 2011-02-23 | 1d | 579.68d |  |  |  |  |  |  |
| 154 | 1.2.2.3.1.2 | **Water Reservoir** | 14d | 2011-01-11 A | 2011-01-24 |  | 90% | 1.4d | 2011-02-08 | 2011-02-17 | 10d | 577.86d |  |  |  | 558,614.17 | 156,224 |  |
| 155 | 1.2.2.3.1.2.1 | **Vertical Wall** | 11d | 2011-01-11 A | 2011-01-21 A |  | 100% |  | 2011-02-08 | 2011-02-13 | 6d |  |  |  |  | 156,224 | 156,224 | ft |
| 156 | 1.2.2.3.1.2.1.1 | Re-bar Work | 3d | 2011-01-11 A | 2011-01-13 A |  | 100% |  | 2011-02-08 | 2011-02-10 | 3d |  |  | start no earlier than 2011-01-11 | MS Rod - Grade 60 [2.88 ton] | 155,574 | 155,574 | ton |
| 157 | 1.2.2.3.1.2.1.2 | Form Work | 3d | 2011-01-14 A | 2011-01-16 A | 156 | 100% |  | 2011-02-09 | 2011-02-11 | 3d |  |  |  |  |  |  | sft |
| 158 | 1.2.2.3.1.2.1.3 | Concrete | 3d | 2011-01-17 A | 2011-01-19 A | 157 | 100% |  | 2011-02-11 | 2011-02-12 | 2d |  |  |  | Brick [1 nos]; Cement [1 bag]; Local Sand [1 cft]; Water Stopper-6" Width [1 rft]; Readymix Concrete-4500 psi [1 cft] | 650 | 650 | cft |
| 159 | 1.2.2.3.1.2.1.4 | De Shuttering | 2d | 2011-01-20 A | 2011-01-21 A | 158FF+2d | 100% |  | 2011-02-12 | 2011-02-13 | 2d |  |  |  |  |  |  |  |
| 160 | 1.2.2.3.1.2.2 | **Top Slab** | 4d | 2011-01-21 A | 2011-01-24 |  | 68% | 1.28d | 2011-02-13 | 2011-02-17 | 5d | 577.86d |  |  |  | 402,390.17 |  |  |
| 161 | 1.2.2.3.1.2.2.1 | Form Work | 2d | 2011-01-21 A | 2011-01-22 | 158 | 90% | 0.2d | 2011-02-13 | 2011-02-15 | 3d | 577.86d |  | start no earlier than 2011-01-20 |  |  |  |  |
| 162 | 1.2.2.3.1.2.2.2 | Re-bar Work | 2d | 2011-01-22 A | 2011-01-23 | 161FF+1d | 80% | 0.4d | 2011-02-14 | 2011-02-16 | 3d | 577.86d |  | start no earlier than 2011-01-20 |  |  |  |  |
| 163 | 1.2.2.3.1.2.2.3 | Concrete | 1d | 2011-01-24 | 2011-01-24 | 162FF+1d |  |  | 2011-02-17 | 2011-02-17 | 1d | 577.86d |  | start no earlier than 2011-01-20 | Readymix Concrete-4500 psi [1820.77 cft] | 402,390.17 |  |  |
| 164 | 1.2.2.3.1.3 | **Column** | 13d | 2011-01-12 A | 2011-01-25 |  | 87% | 1.7d | 2011-02-08 | 2011-02-15 | 8d | 573.68d | 2.69d |  |  | 654,151.19 | 635,408.51 | nos. |
| 165 | 1.2.2.3.1.3.1 | Re-Bar Work | 5d | 2011-01-12 A | 2011-01-17 A | 150FF+4d | 100% |  | 2011-02-08 | 2011-02-09 | 2d |  |  |  | MS Rod - Grade 60 [9.8 ton] | 529,200 | 529,200 |  |
| 166 | 1.2.2.3.1.3.2 | Form Work | 3d | 2011-01-17 A | 2011-01-20 | 165 | 85% | 0.45d | 2011-02-10 | 2011-02-11 | 2d | 414.24d |  |  |  |  |  |  |
| 167 | 1.2.2.3.1.3.3 | Concrete | 3d | 2011-01-20 A | 2011-01-23 | 166 | 85% | 0.45d | 2011-02-12 | 2011-02-13 | 2d | 411.69d |  |  | Readymix Concrete-4500 psi [565.39 cft] | 124,951.19 | 106,208.51 |  |
| 168 | 1.2.2.3.1.3.4 | De-shuttering | 2d | 2011-01-23 A | 2011-01-25 | 167FF+2d | 60% | 0.8d | 2011-02-14 | 2011-02-15 | 2d | 573.68d |  | start no earlier than 2011-01-20 |  |  |  |  |

| ID | WBS | Task | Type | Duration | Start | Finish | Predecessors | Complete | Remaining | Baseline start | Baseline finish | Baseline duration | Total slack | Free slack | Constraint | Resources | Cost | Actual cost | Text1 |
| --- | --- | --- | --- | --- | --- | --- | --- | --- | --- | --- | --- | --- | --- | --- | --- | --- | --- | --- | --- |
| 169 | 1.2.2.3.1.4 | **Shear Wall** |  | 38.69d | 2010-12-20 A | 2011-01-27 |  | 54% | 17.76d | 2011-02-08 | 2011-02-19 | 12d | 406d | 0d |  |  | 368,530.99 | 198,851.2 | nos. |
| 170 | 1.2.2.3.1.4.1 | Re-Bar Work |  | 3d | 2010-12-20 A | 2011-01-22 | 99 | 65% | 1.05d | 2011-02-08 | 2011-02-10 | 3d | 408d |  |  | MS Rod - Grade 60 [5.15 ton] | 278,100 | 180,765 |  |
| 171 | 1.2.2.3.1.4.2 | Form Work |  | 3d | 2011-01-21 A | 2011-01-24 | 170FF+2d | 20% | 2.4d | 2011-02-11 | 2011-02-13 | 3d | 408d |  |  |  |  |  |  |
| 172 | 1.2.2.3.1.4.3 | Concrete |  | 2d | 2011-01-23 A | 2011-01-25 | 171FF+1d | 20% | 1.6d | 2011-02-14 | 2011-02-16 | 3d | 408d |  |  | Readymix Concrete-4500 psi [409.19 cft] | 90,430.99 | 18,086.2 |  |
| 173 | 1.2.2.3.1.4.4 | De-shuttering |  | 3d | 2011-01-24 A | 2011-01-27 A | 172FF+2d | 100% |  | 2011-02-17 | 2011-02-19 | 3d |  |  |  |  |  |  |  |
| 174 | 1.2.2.3.1.5 | **Stair - 1** |  | 4d | 2011-01-21 A | 2011-01-24 |  | 69% | 1.26d | 2011-02-08 | 2011-02-11 | 4d | 411.86d |  |  |  | 175,114.12 | 103,601.22 |  |
| 175 | 1.2.2.3.1.5.1 | **1st Flight** |  | 4d | 2011-01-21 A | 2011-01-24 |  | 69% | 1.26d | 2011-02-08 | 2011-02-11 | 4d | 411.86d |  |  |  | 175,114.12 | 103,601.22 |  |
| 176 | 1.2.2.3.1.5.1.1 | Brick Work |  | 1d | 2011-01-21 A | 2011-01-21 A | 99 | 100% |  | 2011-02-08 | 2011-02-08 | 1d |  |  | start no earlier than 2011-01-20 |  |  |  |  |
| 177 | 1.2.2.3.1.5.1.2 | Form Work |  | 1d | 2011-01-22 A | 2011-01-22 | 176 | 60% | 0.4d | 2011-02-09 | 2011-02-09 | 1d | 413d |  | start no earlier than 2011-01-20 | MS Rod - Grade 60 [2.79 ton] | 150,660 | 90,396 |  |
| 178 | 1.2.2.3.1.5.1.3 | Re-bar Work |  | 1d | 2011-01-23 A | 2011-01-23 | 177 | 60% | 0.4d | 2011-02-10 | 2011-02-10 | 1d | 412.4d |  | start no earlier than 2011-01-20 |  |  |  |  |
| 179 | 1.2.2.3.1.5.1.4 | Concrete |  | 1d | 2011-01-24 A | 2011-01-24 | 178 | 54% | 0.46d | 2011-02-11 | 2011-02-11 | 1d | 411.86d |  | start no earlier than 2011-01-20 | Readymix Concrete-3500 psi [121.06 cft] | 24,454.12 | 13,205.22 |  |
| 180 | 1.2.2.3.1.6 | **Ramp** |  | 2d | 2011-01-22 | 2011-01-23 |  |  |  | 2011-02-26 | 2011-02-27 | 2d | 578.86d |  |  |  | 133,920 |  |  |
| 181 | 1.2.2.3.1.6.1 | Form Work |  | 1d | 2011-01-22 | 2011-01-22 | 177FF |  |  | 2011-02-26 | 2011-02-26 | 1d | 578.86d | 0d |  | MS Rod - Grade 60 [2.48 ton] | 133,920 |  |  |
| 182 | 1.2.2.3.1.6.2 | Re-Bar |  | 1d | 2011-01-23 | 2011-01-23 | 181 |  |  | 2011-02-27 | 2011-02-27 | 1d | 578.86d |  |  |  |  |  |  |
| 183 | 1.2.2.3.1.7 | **Roof Slab** |  | 1d | 2011-01-27 | 2011-01-28 |  |  |  | 2011-02-24 | 2011-03-03 | 8d | 571d |  |  |  | 407 |  |  |
| 184 | 1.2.2.3.1.7.1 | Form Work | milestone | 0d | 2011-01-27 | 2011-01-27 | 169, 164, 153 |  |  | 2011-02-24 | 2011-02-26 | 3d | 571d | 0d | start no earlier than 2011-01-20 | MS Rod - Grade 60 |  |  |  |
| 185 | 1.2.2.3.1.7.2 | Re-bar | milestone | 0d | 2011-01-27 | 2011-01-27 | 184FF |  |  | 2011-02-26 | 2011-03-28 | 3d | 571d | 0d | start no earlier than 2011-01-20 |  |  |  |  |
| 186 | 1.2.2.3.1.7.3 | MEP Work | milestone | 0d | 2011-01-27 | 2011-01-27 | 185FF |  |  | 2011-03-01 | 2011-03-01 | 1d | 571d | 0d | start no earlier than 2011-01-20 |  |  |  |  |
| 187 | 1.2.2.3.1.7.4 | Inspection | milestone | 0d | 2011-01-27 | 2011-01-27 | 186FF |  |  | 2011-03-02 | 2011-03-02 | 1d | 571d | 0d | start no earlier than 2011-01-20 |  |  |  |  |
| 188 | 1.2.2.3.1.7.5 | Concrete |  | 1d | 2011-01-27 | 2011-01-28 | 187 |  |  | 2011-03-03 | 2011-03-03 | 1d | 571d |  | start no earlier than 2011-01-20 | Structural Work-B2 Slab [1 sft]; Filling Sand [1 cft]; Readymix Concrete-3500 psi [1 cft] | 407 |  |  |
| 189 | 1.2.2.3.2 | **LIFT-2** |  | 24.68d | 2011-01-15 A | 2011-02-08 |  | 11% | 22.09d | 2011-03-04 | 2011-03-24 | 21d | 563d |  |  |  | 2,086,340.52 | 189.5 |  |
| 190 | 1.2.2.3.2.1 | **Retaining Wall** |  | 13d | 2011-01-15 A | 2011-01-28 |  | 24% | 9.94d | 2011-03-04 | 2011-03-17 | 14d | 411.69d | 3.69d |  |  | 526,281.28 | 189.5 | rft |
| 191 | 1.2.2.3.2.1.1 | Brick Wall |  | 8d | 2011-01-15 A | 2011-01-23 | 152FF+2d, 152 | 50% | 4d | 2011-03-04 | 2011-03-05 | 2d | 0d |  |  | Brick [1 nos]; Cement [1 bag]; Local Sand [1 cft] | 379 | 189.5 | sft |
| 192 | 1.2.2.3.2.1.2 | Plaster | milestone | 0d | 2011-01-23 | 2011-01-23 | 191FF |  |  | 2011-03-05 | 2011-03-06 | 2d | 0d |  |  |  |  |  | sft |
| 193 | 1.2.2.3.2.1.3 | Water Proofing |  | 1d | 2011-01-22 | 2011-01-23 | 191FF, 191FF+1d |  |  | 2011-03-12 | 2011-03-13 | 2d | 411.69d | 0d |  |  |  |  | sft |
| 194 | 1.2.2.3.2.1.4 | Re-bar Work |  | 2d | 2011-01-22 | 2011-01-24 | 193FF+1d |  |  | 2011-03-13 | 2011-03-14 | 2d | 411.69d | 0d |  |  |  |  | ton |
| 195 | 1.2.2.3.2.1.5 | Form Work |  | 2d | 2011-01-23 | 2011-01-25 | 194FF+1d |  |  | 2011-03-14 | 2011-03-15 | 2d | 411.69d | 0d |  | Polythene (0.2mm thick) [2263.2 sft] | 12,447.6 |  | sft |
| 196 | 1.2.2.3.2.1.6 | Conreting |  | 2d | 2011-01-24 | 2011-01-26 | 195FF+1d |  |  | 2011-03-15 | 2011-03-16 | 2d | 411.69d | 0d |  | Water Stopper-6" Width [1000 rft]; Readymix Concrete-4500 psi [2097.08 cft] | 513,454.68 |  | cft |
| 197 | 1.2.2.3.2.1.7 | De-shuttering |  | 2d | 2011-01-26 | 2011-01-28 | 196FF+2d |  |  | 2011-03-16 | 2011-03-17 | 2d | 411.69d |  |  |  |  |  |  |

| ID | WBS | Task | Duration | Start | Finish | Predecessors | Complete | Remaining | Baseline start | Baseline finish | Baseline duration | Total slack | Free slack | Constraint | Resources | Cost | Text1 |
| --- | --- | --- | --- | --- | --- | --- | --- | --- | --- | --- | --- | --- | --- | --- | --- | --- | --- |
| 198 | 1.2.2.3.2.2 | **Column** | 5d | 2011-01-23 A | 2011-01-28 |  | 5% | 4.75d | 2011-03-04 | 2011-03-08 | 5d | 411.69d | 3.69d |  |  | 124,951.19 | nos. |
| 199 | 1.2.2.3.2.2.1 | Form Work | 2d | 2011-01-23 | 2011-01-25 | 167 |  |  | 2011-03-05 | 2011-03-06 | 2d | 411.69d | 0d |  |  |  |  |
| 200 | 1.2.2.3.2.2.2 | Re-Bar Work | 1d | 2011-01-23 A | 2011-01-24 | 167 | 35% | 0.65d | 2011-03-04 | 2011-03-05 | 2d | 415.69d |  |  |  |  |  |
| 201 | 1.2.2.3.2.2.3 | Concrete | 2d | 2011-01-24 | 2011-01-26 | 199FF+1d |  |  | 2011-03-06 | 2011-03-07 | 2d | 411.69d | 0d | start no earlier than 2011-01-20 | Readymix Concrete-4500 psi [565.39 cft] | 124,951.19 |  |
| 202 | 1.2.2.3.2.2.4 | De-shuttering | 2d | 2011-01-26 | 2011-01-28 | 201FF+2d |  |  | 2011-03-07 | 2011-03-08 | 2d | 411.69d |  | start no earlier than 2011-01-20 |  |  |  |
| 203 | 1.2.2.3.2.3 | **Shear Wall** | 7d | 2011-01-24 A | 2011-01-31 |  | 8% | 6.47d | 2011-03-04 | 2011-03-09 | 6d | 408d | 0d |  |  | 90,430.99 | nos. |
| 204 | 1.2.2.3.2.3.1 | Re-Bar Work | 3d | 2011-01-24 A | 2011-01-27 | 172FF+2d | 30% | 2.1d | 2011-03-04 | 2011-03-06 | 3d | 408d | 0d |  |  |  |  |
| 205 | 1.2.2.3.2.3.2 | Form Work | 3d | 2011-01-25 | 2011-01-28 | 204FF+1d |  |  | 2011-03-05 | 2011-03-07 | 3d | 408d | 0d | start no earlier than 2011-01-20 |  |  |  |
| 206 | 1.2.2.3.2.3.3 | Concrete | 3d | 2011-01-26 | 2011-01-29 | 205FF+1d |  |  | 2011-03-06 | 2011-03-08 | 3d | 408d | 0d | start no earlier than 2011-01-20 | Readymix Concrete-4500 psi [409.19 cft] | 90,430.99 |  |
| 207 | 1.2.2.3.2.3.4 | De-shuttering | 3d | 2011-01-28 | 2011-01-31 | 206FF+2d |  |  | 2011-03-07 | 2011-03-09 | 3d | 408d |  | start no earlier than 2011-01-20 |  |  |  |
| 208 | 1.2.2.3.2.4 | **Stair - 1** | 3d | 2011-01-25 | 2011-01-27 |  |  |  | 2011-03-04 | 2011-03-06 | 3d | 411.86d | 3.86d |  |  |  |  |
| 209 | 1.2.2.3.2.4.1 | **2nd Flight** | 3d | 2011-01-25 | 2011-01-27 |  |  |  | 2011-03-04 | 2011-03-06 | 1d | 411.86d |  |  |  |  |  |
| 210 | 1.2.2.3.2.4.1.1 | Brick Work | 1d | 2011-01-25 | 2011-01-25 | 179 |  |  | 2011-03-04 | 2011-03-04 | 1d | 411.86d | 0d | start no earlier than 2011-01-20 |  |  |  |
| 211 | 1.2.2.3.2.4.1.2 | Form Work | 1d | 2011-01-26 | 2011-01-26 | 210FF+1d |  |  | 2011-03-05 | 2011-03-05 | 1d | 411.86d | 0d | start no earlier than 2011-01-20 |  |  |  |
| 212 | 1.2.2.3.2.4.1.3 | Re-bar Work | 1d | 2011-01-27 | 2011-01-27 | 211FF+1d |  |  | 2011-03-06 | 2011-03-06 | 1d | 411.86d |  | start no earlier than 2011-01-20 |  |  |  |
| 213 | 1.2.2.3.2.5 | **Ramp** | 3d | 2011-01-28 | 2011-01-31 |  |  |  | 2011-03-04 | 2011-03-06 | 3d | 571d |  |  |  |  |  |
| 214 | 1.2.2.3.2.5.1 | Form Work | 1d | 2011-01-28 | 2011-01-29 | 188FF+1d |  |  | 2011-03-04 | 2011-03-04 | 1d | 571d | 0d | start no earlier than 2011-01-20 |  |  |  |
| 215 | 1.2.2.3.2.5.2 | Re-Bar | 1d | 2011-01-29 | 2011-01-30 | 214FF+1d |  |  | 2011-03-05 | 2011-03-05 | 1d | 571d | 0d | start no earlier than 2011-01-20 |  |  |  |
| 216 | 1.2.2.3.2.5.3 | Concrete | 1d | 2011-01-30 | 2011-01-31 | 215FF+1d |  |  | 2011-03-06 | 2011-03-06 | 1d | 571d |  | start no earlier than 2011-01-20 |  |  |  |
| 217 | 1.2.2.3.2.6 | **Roof Slab** | 8d | 2011-01-31 | 2011-02-08 |  |  |  | 2011-03-18 | 2011-03-24 | 7d | 408d |  |  |  | 1,344,677.06 |  |
| 218 | 1.2.2.3.2.6.1 | Form Work | 2d | 2011-01-31 | 2011-02-02 | 190, 198, 203, 208 |  |  | 2011-03-18 | 2011-03-19 | 2d | 408d | 0d |  |  |  |  |
| 219 | 1.2.2.3.2.6.2 | Re-bar | 3d | 2011-02-02 | 2011-02-05 | 218FF+3d |  |  | 2011-03-20 | 2011-03-21 | 2d | 408d | 0d |  |  |  |  |
| 220 | 1.2.2.3.2.6.3 | MEP Work | 1d | 2011-02-05 | 2011-02-06 | 219 |  |  | 2011-03-22 | 2011-03-22 | 1d | 408d | 0d |  |  |  |  |
| 221 | 1.2.2.3.2.6.4 | Inspection | 1d | 2011-02-06 | 2011-02-07 | 220 |  |  | 2011-03-23 | 2011-03-23 | 1d | 408d | 0d |  |  |  |  |
| 222 | 1.2.2.3.2.6.5 | Concrete | 1d | 2011-02-07 | 2011-02-08 | 221 |  |  | 2011-03-24 | 2011-03-24 | 1d | 408d | 0d |  | Structural Work-B2 Slab [4032 sft]; Filling Sand [2000 cft]; Readymix Concrete-3500 psi [2665.53 cft] | 1,344,677.06 |  |

| ID | WBS | Task | Type | Duration | Start | Finish | Predecessors | Complete | Remaining | Baseline start | Baseline finish | Baseline duration | Total slack | Free slack | Constraint | Resources | Cost | Actual cost | Text1 |
| --- | --- | --- | --- | --- | --- | --- | --- | --- | --- | --- | --- | --- | --- | --- | --- | --- | --- | --- | --- |
| 223 | 1.2.2.4 | **BASEMENT-2** |  | 51d | 2011-01-28 A | 2011-03-20 |  | 9% | 46.59d | 2011-03-04 | 2011-04-17 | 45d | 523d |  |  |  | 6,469,105.02 | 1,459,901.97 |  |
| 224 | 1.2.2.4.1 | **PART-1** |  | 28d | 2011-01-28 A | 2011-02-25 |  | 17% | 23.12d | 2011-03-04 | 2011-03-28 | 25d | 546d |  |  |  | 4,405,418.51 | 1,459,901.97 |  |
| 225 | 1.2.2.4.1.1 | **Retaining Wall** |  | 11d | 2011-01-28 A | 2011-02-08 |  | 26% | 8.12d | 2011-03-04 | 2011-03-21 | 18d | 1d |  |  |  | 1,082,819.75 | 652,601.97 | rft |
| 226 | 1.2.2.4.1.1.1 | Brick Wall |  | 3d | 2011-01-28 A | 2011-01-31 A | 188 | 100% |  | 2011-03-04 | 2011-03-06 | 3d |  |  | start no earlier than 2011-01-20 | Brick [9334.72 nos]; Cement [45.31 bag]; Local Sand [298.71 cft]; MS Rod - Grade 60 [10.33 ton] | 652,601.97 | 652,601.97 | sft |
| 227 | 1.2.2.4.1.1.2 | Plaster |  | 2d | 2011-01-31 A | 2011-02-02 | 226 | 7% | 1.86d | 2011-03-07 | 2011-03-08 | 2d | 1d | 0d | start no earlier than 2011-01-20 |  |  |  | sft |
| 228 | 1.2.2.4.1.1.3 | Water Proofing | milestone | 0d | 2011-02-02 | 2011-02-02 | 227FF |  |  | 2011-03-15 | 2011-03-15 | 1d | 1d | 0d | start no earlier than 2011-01-20 |  |  |  | sft |
| 229 | 1.2.2.4.1.1.4 | Re-bar Work |  | 3d | 2011-02-02 | 2011-02-05 | 228 |  |  | 2011-03-16 | 2011-03-18 | 3d | 1d | 0d | start no earlier than 2011-01-20 |  |  |  | ton |
| 230 | 1.2.2.4.1.1.5 | Form Work |  | 2d | 2011-02-04 | 2011-02-06 | 229FF+1d |  |  | 2011-03-18 | 2011-03-19 | 2d | 1d | 0d |  | Polythene (0.2mm thick) [2263.2 sft] | 12,447.6 |  | sft |
| 231 | 1.2.2.4.1.1.6 | Conreting |  | 1d | 2011-02-06 | 2011-02-07 | 230FF+1d |  |  | 2011-03-20 | 2011-03-20 | 1d | 1d | 0d |  | Water Stopper-6" Width [1000 rft]; Bonding Chemical [1.87 L]; Readymix Concrete-4500 psi [1650.58 cft] | 417,770.18 |  | cft |
| 232 | 1.2.2.4.1.1.7 | De-shuttering |  | 1d | 2011-02-07 | 2011-02-08 | 231FF+1d |  |  | 2011-03-21 | 2011-03-21 | 1d | 1d |  |  |  |  |  |  |
| 233 | 1.2.2.4.1.2 | **Column** |  | 8d | 2011-01-28 A | 2011-02-05 |  | 39% | 4.86d | 2011-03-04 | 2011-03-11 | 8d | 4d |  |  |  | 652,133.46 | 529,200 | nos. |
| 234 | 1.2.2.4.1.2.1 | Re-Bar Work |  | 2d | 2011-01-28 A | 2011-01-30 A | 188 | 100% |  | 2011-03-04 | 2011-03-05 | 2d |  |  | start no earlier than 2011-01-20 | MS Rod - Grade 60 [9.8 ton] | 529,200 | 529,200 |  |
| 235 | 1.2.2.4.1.2.2 | Form Work |  | 2d | 2011-01-30 A | 2011-02-01 | 234 | 57% | 0.86d | 2011-03-06 | 2011-03-07 | 2d | 4d | 0d | start no earlier than 2011-01-20 |  |  |  |  |
| 236 | 1.2.2.4.1.2.3 | Concrete |  | 2d | 2011-02-01 | 2011-02-03 | 235 |  |  | 2011-03-08 | 2011-03-09 | 2d | 4d | 0d | start no earlier than 2011-01-20 | Readymix Concrete-4500 psi [556.26 cft] | 122,933.46 |  |  |
| 237 | 1.2.2.4.1.2.4 | De-shuttering |  | 2d | 2011-02-03 | 2011-02-05 | 236 |  |  | 2011-03-10 | 2011-03-11 | 2d | 4d |  | start no earlier than 2011-01-20 |  |  |  |  |
| 238 | 1.2.2.4.1.3 | **Shear Wall** |  | 12d | 2011-01-28 A | 2011-02-09 |  | 26% | 8.86d | 2011-03-04 | 2011-03-15 | 12d | 0d |  |  |  | 367,070.18 | 278,100 | nos. |
| 239 | 1.2.2.4.1.3.1 | Re-Bar Work |  | 3d | 2011-01-28 A | 2011-01-31 A | 188 | 100% |  | 2011-03-04 | 2011-03-06 | 33d |  |  | start no earlier than 2011-01-20 | MS Rod - Grade 60 [5.15 ton] | 278,100 | 278,100 |  |
| 240 | 1.2.2.4.1.3.2 | Form Work |  | 3d | 2011-01-31 A | 2011-02-03 | 239 | 5% | 2.86d | 2011-03-07 | 2011-03-09 | 3d | 0d |  | start no earlier than 2011-01-20 |  |  |  |  |
| 241 | 1.2.2.4.1.3.3 | Concrete |  | 3d | 2011-02-03 | 2011-02-06 | 240 |  |  | 2011-03-10 | 2011-03-12 | 3d | 0d |  | start no earlier than 2011-01-20 | Readymix Concrete-4500 psi [402.58 cft] | 88,970.18 |  |  |
| 242 | 1.2.2.4.1.3.4 | De-shuttering |  | 3d | 2011-02-06 | 2011-02-09 | 241 |  |  | 2011-03-13 | 2011-03-15 | 3d | 0d |  |  |  |  |  |  |
| 243 | 1.2.2.4.1.4 | **Stair - 1** |  | 4d | 2011-02-08 | 2011-02-12 |  |  |  | 2011-03-25 | 2011-03-28 | 4d | 408d |  |  |  | 175,114.12 |  |  |
| 244 | 1.2.2.4.1.4.1 | **1st Flight** |  | 4d | 2011-02-08 | 2011-02-12 |  |  |  | 2011-03-25 | 2011-03-28 | 4d | 408d |  |  |  | 175,114.12 |  |  |
| 245 | 1.2.2.4.1.4.1.1 | Brick Work |  | 1d | 2011-02-08 | 2011-02-09 | 222 |  |  | 2011-03-25 | 2011-03-25 | 1d | 408d | 0d |  |  |  |  |  |
| 246 | 1.2.2.4.1.4.1.2 | Form Work |  | 1d | 2011-02-09 | 2011-02-10 | 245 |  |  | 2011-03-26 | 2011-03-26 | 1d | 408d | 0d |  | MS Rod - Grade 60 [2.79 ton] | 150,660 |  |  |
| 247 | 1.2.2.4.1.4.1.3 | Re-bar Work |  | 1d | 2011-02-10 | 2011-02-11 | 246 |  |  | 2011-03-27 | 2011-03-27 | 1d | 408d | 0d |  |  |  |  |  |
| 248 | 1.2.2.4.1.4.1.4 | Concrete |  | 1d | 2011-02-11 | 2011-02-12 | 247 |  |  | 2011-03-28 | 2011-03-28 | 1d | 408d | 0d |  | Readymix Concrete-3500 psi [121.06 cft] | 24,454.12 |  |  |

| ID | WBS | Task | Type | Duration | Start | Finish | Predecessors | Baseline start | Baseline finish | Baseline duration | Total slack | Free slack | Resources | Cost | Text1 |
| --- | --- | --- | --- | --- | --- | --- | --- | --- | --- | --- | --- | --- | --- | --- | --- |
| 249 | 1.2.2.4.1.5 | **Ramp** |  | 2d | 2011-02-14 | 2011-02-16 |  | 2011-03-23 | 2011-03-24 | 2d | 555d |  |  | 133,920 |  |
| 250 | 1.2.2.4.1.5.1 | Form Work |  | 1d | 2011-02-14 | 2011-02-15 | 253FF | 2011-03-23 | 2011-03-23 | 1d | 555d | 0d | MS Rod - Grade 60 [2.48 ton] | 133,920 |  |
| 251 | 1.2.2.4.1.5.2 | Re-Bar |  | 1d | 2011-02-15 | 2011-02-16 | 250 | 2011-03-24 | 2011-03-24 | 1d | 555d |  |  |  |  |
| 252 | 1.2.2.4.1.6 | **Roof Slab** |  | 16d | 2011-02-09 | 2011-02-25 |  | 2011-03-22 | 2011-03-28 | 7d | 0d |  |  | 1,994,361 |  |
| 253 | 1.2.2.4.1.6.1 | Form Work |  | 6d | 2011-02-09 | 2011-02-15 | 232, 233, 238 | 2011-03-22 | 2011-03-23 | 2d | 0d |  | MS Rod - Grade 60 [12.76 ton] | 689,040 |  |
| 254 | 1.2.2.4.1.6.2 | Re-bar |  | 7d | 2011-02-15 | 2011-02-22 | 253FF+7d | 2011-03-24 | 2011-03-25 | 2d | 0d |  |  |  |  |
| 255 | 1.2.2.4.1.6.3 | MEP Work |  | 1d | 2011-02-22 | 2011-02-23 | 254 | 2011-03-26 | 2011-03-26 | 1d | 0d |  |  |  |  |
| 256 | 1.2.2.4.1.6.4 | Inspection |  | 1d | 2011-02-23 | 2011-02-24 | 255 | 2011-03-27 | 2011-03-27 | 1d | 0d |  |  |  |  |
| 257 | 1.2.2.4.1.6.5 | Concrete |  | 1d | 2011-02-24 | 2011-02-25 | 256 | 2011-03-28 | 2011-03-28 | 1d | 0d |  | Structural Work-B1 Slab [4032 sft]; Filling Sand [2000 cft]; Readymix Concrete-3500 psi [2570.5 cft] | 1,305,321 |  |
| 258 | 1.2.2.4.2 | **PART-2** |  | 36d | 2011-02-12 | 2011-03-20 |  | 2011-03-27 | 2011-04-17 | 22d | 404d |  |  | 2,063,686.51 |  |
| 259 | 1.2.2.4.2.1 | **Retaining Wall** |  | 7d | 2011-02-24 | 2011-03-03 |  | 2011-03-28 | 2011-04-10 | 14d | 392d | 0d |  | 522,007.75 | rft |
| 260 | 1.2.2.4.2.1.1 | Brick Wall |  | 2d | 2011-02-24 | 2011-02-26 | 257FF+1d | 2011-03-28 | 2011-03-29 | 2d | 392d | 0d | Brick [9334.72 nos]; Cement [45.31 bag]; Local Sand [298.71 cft] | 94,781.97 | sft |
| 261 | 1.2.2.4.2.1.2 | Plaster |  | 2d | 2011-02-25 | 2011-02-27 | 260FF+1d | 2011-03-29 | 2011-03-30 | 2d | 392d | 0d |  |  | sft |
| 262 | 1.2.2.4.2.1.3 | Water Proofing | milestone | 0d | 2011-02-27 | 2011-02-27 | 261FF | 2011-04-05 | 2011-04-06 | 2d | 392d | 0d |  |  | sft |
| 263 | 1.2.2.4.2.1.4 | Re-bar Work |  | 2d | 2011-02-26 | 2011-02-28 | 262FF+1d | 2011-04-06 | 2011-04-07 | 2d | 392d | 0d |  |  | ton |
| 264 | 1.2.2.4.2.1.5 | Form Work |  | 2d | 2011-02-27 | 2011-03-01 | 263FF+1d | 2011-04-07 | 2011-04-08 | 2d | 392d | 0d | Polythene (0.2mm thick) [2263.2 sft] | 12,447.6 | sft |
| 265 | 1.2.2.4.2.1.6 | Conreting |  | 2d | 2011-02-28 | 2011-03-02 | 264FF+1d | 2011-04-08 | 2011-04-09 | 2d | 392d | 0d | Water Stopper-6" Width [1000 rft]; Readymix Concrete-4500 psi [1650.58 cft] | 414,778.18 | cft |
| 266 | 1.2.2.4.2.1.7 | De-shuttering |  | 2d | 2011-03-01 | 2011-03-03 | 265FF+1d | 2011-04-09 | 2011-04-10 | 2d | 392d |  |  |  |  |
| 267 | 1.2.2.4.2.2 | **Column** |  | 5d | 2011-02-24 | 2011-03-01 |  | 2011-03-28 | 2011-04-01 | 5d | 394d | 2d |  | 122,933.46 | nos. |
| 268 | 1.2.2.4.2.2.1 | Re-Bar Work |  | 2d | 2011-02-24 | 2011-02-26 | 257FF+1d | 2011-03-28 | 2011-03-29 | 2d | 394d | 0d |  |  |  |
| 269 | 1.2.2.4.2.2.2 | Form Work |  | 2d | 2011-02-25 | 2011-02-27 | 268FF+1d | 2011-03-29 | 2011-03-30 | 2d | 394d | 0d |  |  |  |
| 270 | 1.2.2.4.2.2.3 | Concrete |  | 2d | 2011-02-26 | 2011-02-28 | 269FF+1d | 2011-03-30 | 2011-03-31 | 2d | 394d | 0d | Readymix Concrete-4500 psi [556.26 cft] | 122,933.46 |  |
| 271 | 1.2.2.4.2.2.4 | De-shuttering |  | 2d | 2011-02-27 | 2011-03-01 | 270FF+1d | 2011-03-31 | 2011-04-01 | 2d | 394d |  |  |  |  |
| 272 | 1.2.2.4.2.3 | **Shear Wall** |  | 6d | 2011-02-23 | 2011-03-01 |  | 2011-03-27 | 2011-04-01 | 6d | 394d | 2d |  | 88,970.18 | nos. |
| 273 | 1.2.2.4.2.3.1 | Re-Bar Work |  | 3d | 2011-02-23 | 2011-02-26 | 257FF+1d | 2011-03-27 | 2011-03-29 | 3d | 394d | 0d |  |  |  |
| 274 | 1.2.2.4.2.3.2 | Form Work |  | 3d | 2011-02-24 | 2011-02-27 | 273FF+1d | 2011-03-28 | 2011-03-30 | 3d | 394d | 0d |  |  |  |
| 275 | 1.2.2.4.2.3.3 | Concrete |  | 3d | 2011-02-25 | 2011-02-28 | 274FF+1d | 2011-03-29 | 2011-03-31 | 3d | 394d | 0d | Readymix Concrete-4500 psi [402.58 cft] | 88,970.18 |  |
| 276 | 1.2.2.4.2.3.4 | De-shuttering |  | 3d | 2011-02-26 | 2011-03-01 | 275FF+1d | 2011-03-30 | 2011-04-01 | 3d | 394d |  |  |  |  |

| ID | WBS | Task | Type | Duration | Start | Finish | Predecessors | Baseline start | Baseline finish | Baseline duration | Total slack | Free slack | Resources | Cost | Text1 |
| --- | --- | --- | --- | --- | --- | --- | --- | --- | --- | --- | --- | --- | --- | --- | --- |
| 277 | 1.2.2.4.2.4 | **Stair - 1** |  | 3d | 2011-02-12 | 2011-02-15 |  | 2011-03-29 | 2011-03-31 | 3d | 408d | 16d |  |  |  |
| 278 | 1.2.2.4.2.4.1 | **2nd Flight** |  | 3d | 2011-02-12 | 2011-02-15 |  | 2011-03-29 | 2011-03-31 | 3d | 408d |  |  |  |  |
| 279 | 1.2.2.4.2.4.1.1 | Brick Work |  | 1d | 2011-02-12 | 2011-02-13 | 248 | 2011-03-29 | 2011-03-29 | 1d | 408d | 0d |  |  |  |
| 280 | 1.2.2.4.2.4.1.2 | Form Work |  | 1d | 2011-02-13 | 2011-02-14 | 279FF+1d | 2011-03-30 | 2011-03-30 | 1d | 408d | 0d |  |  |  |
| 281 | 1.2.2.4.2.4.1.3 | Re-bar Work |  | 1d | 2011-02-14 | 2011-02-15 | 280FF+1d | 2011-03-31 | 2011-03-31 | 1d | 408d |  |  |  |  |
| 282 | 1.2.2.4.2.5 | **Ramp** |  | 3d | 2011-02-25 | 2011-02-28 |  | 2011-03-29 | 2011-03-31 | 3d | 543d |  |  |  |  |
| 283 | 1.2.2.4.2.5.1 | Form Work |  | 1d | 2011-02-25 | 2011-02-26 | 257FF+1d | 2011-03-29 | 2011-03-29 | 1d | 543d | 0d |  |  |  |
| 284 | 1.2.2.4.2.5.2 | Re-Bar |  | 1d | 2011-02-26 | 2011-02-27 | 283FF+1d | 2011-03-30 | 2011-03-30 | 1d | 543d | 0d |  |  |  |
| 285 | 1.2.2.4.2.5.3 | Concrete |  | 1d | 2011-02-27 | 2011-02-28 | 284FF+1d | 2011-03-31 | 2011-03-31 | 1d | 543d |  |  |  |  |
| 286 | 1.2.2.4.2.6 | **Roof Slab** |  | 17d | 2011-03-03 | 2011-03-20 |  | 2011-04-11 | 2011-04-17 | 7d | 392d |  |  | 1,329,775.12 |  |
| 287 | 1.2.2.4.2.6.1 | Form Work |  | 7d | 2011-03-03 | 2011-03-10 | 259, 267, 272, 277 | 2011-04-11 | 2011-04-12 | 2d | 392d | 0d |  |  |  |
| 288 | 1.2.2.4.2.6.2 | Re-bar |  | 7d | 2011-03-10 | 2011-03-17 | 287FF+7d | 2011-04-13 | 2011-04-14 | 2d | 392d | 0d |  |  |  |
| 289 | 1.2.2.4.2.6.3 | MEP Work |  | 1d | 2011-03-17 | 2011-03-18 | 288 | 2011-04-15 | 2011-04-15 | 1d | 392d | 0d |  |  |  |
| 290 | 1.2.2.4.2.6.4 | Inspection |  | 1d | 2011-03-18 | 2011-03-19 | 289 | 2011-04-16 | 2011-04-16 | 1d | 392d | 0d |  |  |  |
| 291 | 1.2.2.4.2.6.5 | Concrete |  | 1d | 2011-03-19 | 2011-03-20 | 290 | 2011-04-17 | 2011-04-17 | 1d | 392d | 0d | Structural Work-B1 Slab [4032 sft]; Filling Sand [2000 cft]; Readymix Concrete-3500 psi [2691.56 cft] | 1,329,775.12 |  |
| 292 | 1.2.2.5 | **BASEMENT-1** |  | 82d | 2011-02-25 | 2011-05-18 |  | 2011-03-29 | 2011-05-12 | 45d | 0d |  |  | 6,467,929.36 |  |
| 293 | 1.2.2.5.1 | **PART-1** |  | 50d | 2011-02-25 | 2011-04-16 |  | 2011-03-29 | 2011-04-22 | 25d | 0d |  |  | 4,433,420.68 |  |
| 294 | 1.2.2.5.1.1 | **Retaining Wall** |  | 21d | 2011-02-25 | 2011-03-18 |  | 2011-03-29 | 2011-04-15 | 18d | 0d |  |  | 1,082,912.57 | rft |
| 295 | 1.2.2.5.1.1.1 | Brick Wall |  | 10d | 2011-02-25 | 2011-03-07 | 257 | 2011-03-29 | 2011-03-31 | 3d | 0d |  | Brick [9334.72 nos]; Cement [45.31 bag]; Local Sand [298.71 cft]; MS Rod - Grade 60 [10.33 ton] | 652,601.97 | sft |
| 296 | 1.2.2.5.1.1.2 | Plaster |  | 3d | 2011-03-07 | 2011-03-10 | 295 | 2011-04-01 | 2011-04-02 | 2d | 0d |  |  |  | sft |
| 297 | 1.2.2.5.1.1.3 | Water Proofing | milestone | 0d | 2011-03-10 | 2011-03-10 | 296FF | 2011-04-09 | 2011-04-09 | 1d | 0d |  |  |  | sft |
| 298 | 1.2.2.5.1.1.4 | Re-bar Work |  | 3d | 2011-03-10 | 2011-03-13 | 297 | 2011-04-10 | 2011-04-12 | 3d | 0d |  |  |  | ton |
| 299 | 1.2.2.5.1.1.5 | Form Work |  | 3d | 2011-03-13 | 2011-03-16 | 298FF+3d | 2011-04-12 | 2011-04-13 | 2d | 0d |  | Polythene (0.2mm thick) [2263.2 sft] | 12,447.6 | sft |
| 300 | 1.2.2.5.1.1.6 | Conreting |  | 2d | 2011-03-15 | 2011-03-17 | 299FF+1d | 2011-04-14 | 2011-04-14 | 1d | 0d |  | Water Stopper-6" Width [1000 rft]; Bonding Chemical [1.87 L]; Readymix Concrete-4500 psi [1651 cft] | 417,863 | cft |
| 301 | 1.2.2.5.1.1.7 | De-shuttering |  | 1d | 2011-03-17 | 2011-03-18 | 300FF+1d | 2011-04-15 | 2011-04-15 | 1d | 0d |  |  |  |  |

| ID | WBS | Task | Duration | Start | Finish | Predecessors | Baseline start | Baseline finish | Baseline duration | Total slack | Free slack | Resources | Cost | Text1 |
| --- | --- | --- | --- | --- | --- | --- | --- | --- | --- | --- | --- | --- | --- | --- |
| 302 | 1.2.2.5.1.2 | **Column** | 10d | 2011-02-25 | 2011-03-07 |  | 2011-03-29 | 2011-04-05 | 8d | 11d |  |  | 677,351.77 | nos. |
| 303 | 1.2.2.5.1.2.1 | Re-Bar Work | 2d | 2011-02-25 | 2011-02-27 | 257 | 2011-03-29 | 2011-03-30 | 2d | 11d | 0d | MS Rod - Grade 60 [9.8 ton] | 529,200 |  |
| 304 | 1.2.2.5.1.2.2 | Form Work | 2d | 2011-02-27 | 2011-03-01 | 303 | 2011-03-31 | 2011-04-01 | 2d | 11d | 0d |  |  |  |
| 305 | 1.2.2.5.1.2.3 | Concrete | 4d | 2011-03-01 | 2011-03-05 | 304 | 2011-04-02 | 2011-04-03 | 2d | 11d | 0d | Readymix Concrete-4500 psi [670.37 cft] | 148,151.77 |  |
| 306 | 1.2.2.5.1.2.4 | De-shuttering | 2d | 2011-03-05 | 2011-03-07 | 305 | 2011-04-04 | 2011-04-05 | 2d | 11d |  |  |  |  |
| 307 | 1.2.2.5.1.3 | **Shear Wall** | 18d | 2011-02-25 | 2011-03-15 |  | 2011-03-29 | 2011-04-09 | 12d | 3d |  |  | 385,320.36 | nos. |
| 308 | 1.2.2.5.1.3.1 | Re-Bar Work | 6d | 2011-02-25 | 2011-03-03 | 257 | 2011-03-29 | 2011-03-31 | 3d | 3d | 0d | MS Rod - Grade 60 [5.15 ton] | 278,100 |  |
| 309 | 1.2.2.5.1.3.2 | Form Work | 3d | 2011-03-03 | 2011-03-06 | 308 | 2011-04-01 | 2011-04-03 | 3d | 3d | 0d |  |  |  |
| 310 | 1.2.2.5.1.3.3 | Concrete | 6d | 2011-03-06 | 2011-03-12 | 309 | 2011-04-04 | 2011-04-06 | 3d | 3d | 0d | Readymix Concrete-4500 psi [485.16 cft] | 107,220.36 |  |
| 311 | 1.2.2.5.1.3.4 | De-shuttering | 3d | 2011-03-12 | 2011-03-15 | 310 | 2011-04-07 | 2011-04-09 | 3d | 3d |  |  |  |  |
| 312 | 1.2.2.5.1.4 | **Stair - 1** | 6d | 2011-02-25 | 2011-03-03 |  | 2011-03-29 | 2011-04-01 | 4d | 55d |  |  | 175,114.12 |  |
| 313 | 1.2.2.5.1.4.1 | **1st Flight** | 6d | 2011-02-25 | 2011-03-03 |  | 2011-03-29 | 2011-04-01 | 4d | 55d |  |  | 175,114.12 |  |
| 314 | 1.2.2.5.1.4.1.1 | Brick Work | 2d | 2011-02-25 | 2011-02-27 | 257 | 2011-03-29 | 2011-03-29 | 1d | 55d | 0d |  |  |  |
| 315 | 1.2.2.5.1.4.1.2 | Form Work | 1d | 2011-02-27 | 2011-02-28 | 314 | 2011-03-30 | 2011-03-30 | 1d | 55d | 0d | MS Rod - Grade 60 [2.79 ton] | 150,660 |  |
| 316 | 1.2.2.5.1.4.1.3 | Re-bar Work | 1d | 2011-02-28 | 2011-03-01 | 315 | 2011-03-31 | 2011-03-31 | 1d | 55d | 0d |  |  |  |
| 317 | 1.2.2.5.1.4.1.4 | Concrete | 2d | 2011-03-01 | 2011-03-03 | 316 | 2011-04-01 | 2011-04-01 | 1d | 55d | 0d | Readymix Concrete-3500 psi [121.06 cft] | 24,454.12 |  |
| 318 | 1.2.2.5.1.5 | **Ramp** | 3d | 2011-04-03 | 2011-04-06 |  | 2011-04-17 | 2011-04-18 | 2d | 506d |  |  | 133,920 |  |
| 319 | 1.2.2.5.1.5.1 | Form Work | 2d | 2011-04-03 | 2011-04-05 | 322FF | 2011-04-17 | 2011-04-17 | 1d | 506d | 0d | MS Rod - Grade 60 [2.48 ton] | 133,920 |  |
| 320 | 1.2.2.5.1.5.2 | Re-Bar | 1d | 2011-04-05 | 2011-04-06 | 319 | 2011-04-18 | 2011-04-18 | 1d | 506d |  |  |  |  |
| 321 | 1.2.2.5.1.6 | **Roof Slab** | 29d | 2011-03-18 | 2011-04-16 |  | 2011-04-16 | 2011-04-22 | 7d | 0d |  |  | 1,978,801.86 |  |
| 322 | 1.2.2.5.1.6.1 | Form Work | 18d | 2011-03-18 | 2011-04-05 | 301, 302, 307 | 2011-04-16 | 2011-04-17 | 2d | 0d |  | MS Rod - Grade 60 [12.78 ton] | 690,120 |  |
| 323 | 1.2.2.5.1.6.2 | Re-bar | 8d | 2011-04-04 | 2011-04-12 | 322FF+7d | 2011-04-18 | 2011-04-19 | 2d | 0d |  |  |  |  |
| 324 | 1.2.2.5.1.6.3 | MEP Work | 1d | 2011-04-12 | 2011-04-13 | 323 | 2011-04-20 | 2011-04-20 | 1d | 0d |  |  |  |  |
| 325 | 1.2.2.5.1.6.4 | Inspection | 1d | 2011-04-13 | 2011-04-14 | 324 | 2011-04-21 | 2011-04-21 | 1d | 0d |  |  |  |  |
| 326 | 1.2.2.5.1.6.5 | Concrete | 2d | 2011-04-14 | 2011-04-16 | 325 | 2011-04-22 | 2011-04-22 | 1d | 0d |  | Structural Work-GF Slab [4032 sft]; Filling Sand [2000 cft]; Readymix Concrete-3500 psi [2587.93 cft] | 1,288,681.86 |  |

| ID | WBS | Task | Type | Duration | Start | Finish | Predecessors | Baseline start | Baseline finish | Baseline duration | Total slack | Free slack | Resources | Cost | Text1 |
| --- | --- | --- | --- | --- | --- | --- | --- | --- | --- | --- | --- | --- | --- | --- | --- |
| 327 | 1.2.2.5.2 | **PART-2** |  | 76d | 2011-03-03 | 2011-05-18 |  | 2011-04-02 | 2011-05-12 | 41d | 42d |  |  | 2,034,508.68 |  |
| 328 | 1.2.2.5.2.1 | **Retaining Wall** |  | 16d | 2011-04-14 | 2011-04-30 |  | 2011-04-22 | 2011-05-05 | 14d | 0d |  |  | 472,100.57 | rft |
| 329 | 1.2.2.5.2.1.1 | Brick Wall |  | 5d | 2011-04-14 | 2011-04-19 | 326FF+3d | 2011-04-22 | 2011-04-23 | 2d | 0d |  | Brick [9334.72 nos]; Cement [45.31 bag]; Local Sand [298.71 cft] | 94,781.97 | sft |
| 330 | 1.2.2.5.2.1.2 | Plaster |  | 3d | 2011-04-19 | 2011-04-22 | 329FF+3d | 2011-04-23 | 2011-04-24 | 2d | 0d |  |  |  | sft |
| 331 | 1.2.2.5.2.1.3 | Water Proofing | milestone | 0d | 2011-04-22 | 2011-04-22 | 330FF | 2011-04-30 | 2011-05-01 | 2d | 0d |  |  |  | sft |
| 332 | 1.2.2.5.2.1.4 | Re-bar Work |  | 3d | 2011-04-20 | 2011-04-23 | 331FF+1d | 2011-05-01 | 2011-05-02 | 2d | 0d |  |  |  | ton |
| 333 | 1.2.2.5.2.1.5 | Form Work |  | 3d | 2011-04-25 | 2011-04-28 | 332FF+5d | 2011-05-02 | 2011-05-03 | 2d | 0d |  | Polythene (0.2mm thick) [2263.2 sft] | 12,447.6 | sft |
| 334 | 1.2.2.5.2.1.6 | Conreting |  | 4d | 2011-04-25 | 2011-04-29 | 333FF+1d | 2011-05-03 | 2011-05-04 | 2d | 0d |  | Readymix Concrete-4500 psi [1651 cft] | 364,871 | cft |
| 335 | 1.2.2.5.2.1.7 | De-shuttering |  | 2d | 2011-04-28 | 2011-04-30 | 334FF+1d | 2011-05-04 | 2011-05-05 | 2d | 0d |  |  |  |  |
| 336 | 1.2.2.5.2.2 | **Column** |  | 5d | 2011-04-15 | 2011-04-20 |  | 2011-04-22 | 2011-04-26 | 5d | 10d |  |  | 148,151.77 | nos. |
| 337 | 1.2.2.5.2.2.1 | Re-Bar Work |  | 2d | 2011-04-15 | 2011-04-17 | 326FF+1d | 2011-04-22 | 2011-04-23 | 2d | 10d | 0d |  |  |  |
| 338 | 1.2.2.5.2.2.2 | Form Work |  | 2d | 2011-04-16 | 2011-04-18 | 337FF+1d | 2011-04-23 | 2011-04-24 | 2d | 10d | 0d |  |  |  |
| 339 | 1.2.2.5.2.2.3 | Concrete |  | 4d | 2011-04-15 | 2011-04-19 | 338FF+1d | 2011-04-24 | 2011-04-25 | 2d | 10d | 0d | Readymix Concrete-4500 psi [670.37 cft] | 148,151.77 |  |
| 340 | 1.2.2.5.2.2.4 | De-shuttering |  | 2d | 2011-04-18 | 2011-04-20 | 339FF+1d | 2011-04-25 | 2011-04-26 | 2d | 10d |  |  |  |  |
| 341 | 1.2.2.5.2.3 | **Shear Wall** |  | 7d | 2011-04-13 | 2011-04-20 |  | 2011-04-21 | 2011-04-26 | 6d | 10d |  |  | 107,220.36 | nos. |
| 342 | 1.2.2.5.2.3.1 | Re-Bar Work |  | 3d | 2011-04-14 | 2011-04-17 | 326FF+1d | 2011-04-21 | 2011-04-23 | 3d | 10d | 0d |  |  |  |
| 343 | 1.2.2.5.2.3.2 | Form Work |  | 3d | 2011-04-15 | 2011-04-18 | 342FF+1d | 2011-04-22 | 2011-04-24 | 3d | 10d | 0d |  |  |  |
| 344 | 1.2.2.5.2.3.3 | Concrete |  | 6d | 2011-04-13 | 2011-04-19 | 343FF+1d | 2011-04-23 | 2011-04-25 | 3d | 10d | 0d | Readymix Concrete-4500 psi [485.16 cft] | 107,220.36 |  |
| 345 | 1.2.2.5.2.3.4 | De-shuttering |  | 3d | 2011-04-17 | 2011-04-20 | 344FF+1d | 2011-04-24 | 2011-04-26 | 3d | 10d |  |  |  |  |
| 346 | 1.2.2.5.2.4 | **Stair - 1** |  | 3d | 2011-03-03 | 2011-03-06 |  | 2011-04-02 | 2011-04-04 | 3d | 55d |  |  |  |  |
| 347 | 1.2.2.5.2.4.1 | **2nd Flight** |  | 3d | 2011-03-03 | 2011-03-06 |  | 2011-04-02 | 2011-04-04 | 3d | 55d |  |  |  |  |
| 348 | 1.2.2.5.2.4.1.1 | Brick Work |  | 1d | 2011-03-03 | 2011-03-04 | 317 | 2011-04-02 | 2011-04-02 | 1d | 55d | 0d |  |  |  |
| 349 | 1.2.2.5.2.4.1.2 | Form Work |  | 1d | 2011-03-04 | 2011-03-05 | 348FF+1d | 2011-04-03 | 2011-04-03 | 1d | 55d | 0d |  |  |  |
| 350 | 1.2.2.5.2.4.1.3 | Re-bar Work |  | 1d | 2011-03-05 | 2011-03-06 | 349FF+1d | 2011-04-04 | 2011-04-04 | 1d | 55d |  |  |  |  |

| ID | WBS | Task | Duration | Start | Finish | Predecessors | Baseline start | Baseline finish | Baseline duration | Total slack | Free slack | Resources | Cost | Text1 |
| --- | --- | --- | --- | --- | --- | --- | --- | --- | --- | --- | --- | --- | --- | --- |
| 351 | 1.2.2.5.2.5 | **Ramp** | 3d | 2011-04-16 | 2011-04-19 |  | 2011-04-23 | 2011-04-25 | 3d | 493d |  |  |  |  |
| 352 | 1.2.2.5.2.5.1 | Form Work | 1d | 2011-04-16 | 2011-04-17 | 326FF+1d | 2011-04-23 | 2011-04-23 | 1d | 493d | 0d |  |  |  |
| 353 | 1.2.2.5.2.5.2 | Re-Bar | 1d | 2011-04-17 | 2011-04-18 | 352FF+1d | 2011-04-24 | 2011-04-24 | 1d | 493d | 0d |  |  |  |
| 354 | 1.2.2.5.2.5.3 | Concrete | 2d | 2011-04-17 | 2011-04-19 | 353FF+1d | 2011-04-25 | 2011-04-25 | 1d | 493d |  |  |  |  |
| 355 | 1.2.2.5.2.6 | **Roof Slab** | 18d | 2011-04-30 | 2011-05-18 |  | 2011-05-06 | 2011-05-12 | 7d | 0d |  |  | 1,307,035.98 |  |
| 356 | 1.2.2.5.2.6.1 | Form Work | 7d | 2011-04-30 | 2011-05-07 | 328, 336, 341, 346 | 2011-05-06 | 2011-05-07 | 2d | 0d |  |  |  |  |
| 357 | 1.2.2.5.2.6.2 | Re-bar | 8d | 2011-05-06 | 2011-05-14 | 356FF+7d | 2011-05-08 | 2011-05-09 | 2d | 0d |  |  |  |  |
| 358 | 1.2.2.5.2.6.3 | MEP Work | 1d | 2011-05-14 | 2011-05-15 | 357 | 2011-05-10 | 2011-05-10 | 1d | 0d |  |  |  |  |
| 359 | 1.2.2.5.2.6.4 | Inspection | 1d | 2011-05-15 | 2011-05-16 | 358 | 2011-05-11 | 2011-05-11 | 1d | 0d |  |  |  |  |
| 360 | 1.2.2.5.2.6.5 | Concrete | 2d | 2011-05-16 | 2011-05-18 | 359 | 2011-05-12 | 2011-05-12 | 1d | 0d |  | Structural Work-GF Slab [4032 sft]; Filling Sand [1390 cft]; Readymix Concrete-3500 psi [2708.99 cft] | 1,307,035.98 |  |
| 361 | 1.3 | **SUPER STRUCTURE** | 370d | 2011-05-18 | 2012-06-07 |  | 2011-05-13 | 2012-06-02 | 370d | 0d |  |  |  |  |
| 362 | 1.3.1 | **GROUND FLOOR** | 25d | 2011-05-18 | 2011-06-12 |  | 2011-05-13 | 2011-06-07 | 25d | 0d |  |  |  |  |
| 363 | 1.3.1.1 | **Column** | 12d | 2011-05-18 | 2011-05-30 |  | 2011-05-13 | 2011-05-25 | 0d? | 0d |  |  |  | nos. |
| 364 | 1.3.1.1.1 | **1ST Lift** | 6d | 2011-05-18 | 2011-05-24 |  | 2011-05-13 | 2011-05-19 | 0d? | 0d |  |  |  |  |
| 365 | 1.3.1.1.1.1 | Re-Bar Work | 1d | 2011-05-18 | 2011-05-19 | 360 | 2011-05-13 | 2011-05-14 | 0d? | 0d |  |  |  |  |
| 366 | 1.3.1.1.1.2 | Form Work | 1d | 2011-05-19 | 2011-05-20 | 365 | 2011-05-14 | 2011-05-15 | 0d? | 0d |  |  |  |  |
| 367 | 1.3.1.1.1.3 | Concrete | 1d | 2011-05-20 | 2011-05-21 | 366 | 2011-05-15 | 2011-05-16 | 0d? | 0d |  |  |  |  |
| 368 | 1.3.1.1.1.4 | De-shuttering | 1d | 2011-05-23 | 2011-05-24 | 367FS+2d | 2011-05-18 | 2011-05-19 | 0d? | 0d |  |  |  |  |
| 369 | 1.3.1.1.2 | **2nd Lift** | 6d | 2011-05-24 | 2011-05-30 |  | 2011-05-19 | 2011-05-25 | 0d? | 0d |  |  |  |  |
| 370 | 1.3.1.1.2.1 | Re-Bar Work | 1d | 2011-05-24 | 2011-05-25 | 368 | 2011-05-19 | 2011-05-20 | 0d? | 0d |  |  |  |  |
| 371 | 1.3.1.1.2.2 | Form Work | 1d | 2011-05-25 | 2011-05-26 | 370 | 2011-05-20 | 2011-05-21 | 0d? | 0d |  |  |  |  |
| 372 | 1.3.1.1.2.3 | Concrete | 1d | 2011-05-26 | 2011-05-27 | 371 | 2011-05-21 | 2011-05-22 | 0d? | 0d |  |  |  |  |
| 373 | 1.3.1.1.2.4 | De-shuttering | 1d | 2011-05-29 | 2011-05-30 | 372FS+2d | 2011-05-24 | 2011-05-25 | 0d? | 0d |  |  |  |  |
| 374 | 1.3.1.2 | **Shear Wall** | 12d | 2011-05-18 | 2011-05-30 |  | 2011-05-13 | 2011-05-25 | 0d? | 0d |  |  |  | nos. |
| 375 | 1.3.1.2.1 | **1st Lift** | 6d | 2011-05-18 | 2011-05-24 |  | 2011-05-13 | 2011-05-19 | 0d? | 0d |  |  |  |  |
| 376 | 1.3.1.2.1.1 | Re-Bar Work | 1d | 2011-05-18 | 2011-05-19 | 360 | 2011-05-13 | 2011-05-14 | 0d? | 0d |  |  |  |  |
| 377 | 1.3.1.2.1.2 | Form Work | 1d | 2011-05-19 | 2011-05-20 | 376 | 2011-05-14 | 2011-05-15 | 0d? | 0d |  |  |  |  |
| 378 | 1.3.1.2.1.3 | Concrete | 1d | 2011-05-20 | 2011-05-21 | 377 | 2011-05-15 | 2011-05-16 | 0d? | 0d |  |  |  |  |
| 379 | 1.3.1.2.1.4 | De-shuttering | 1d | 2011-05-23 | 2011-05-24 | 378FS+2d | 2011-05-18 | 2011-05-19 | 0d? | 0d |  |  |  |  |

| ID | WBS | Task | Duration | Start | Finish | Predecessors | Baseline start | Baseline finish | Baseline duration | Total slack | Free slack | Text1 |
| --- | --- | --- | --- | --- | --- | --- | --- | --- | --- | --- | --- | --- |
| 380 | 1.3.1.2.2 | **2nd Lift** | 6d | 2011-05-24 | 2011-05-30 |  | 2011-05-19 | 2011-05-25 | 0d? | 0d |  |  |
| 381 | 1.3.1.2.2.1 | Re-Bar Work | 1d | 2011-05-24 | 2011-05-25 | 379 | 2011-05-19 | 2011-05-20 | 0d? | 0d |  |  |
| 382 | 1.3.1.2.2.2 | Form Work | 1d | 2011-05-25 | 2011-05-26 | 381 | 2011-05-20 | 2011-05-21 | 0d? | 0d |  |  |
| 383 | 1.3.1.2.2.3 | Concrete | 1d | 2011-05-26 | 2011-05-27 | 382 | 2011-05-21 | 2011-05-22 | 0d? | 0d |  |  |
| 384 | 1.3.1.2.2.4 | De-shuttering | 1d | 2011-05-29 | 2011-05-30 | 383FS+2d | 2011-05-24 | 2011-05-25 | 0d? | 0d |  |  |
| 385 | 1.3.1.3 | **Stair - 1 & 2** | 7d | 2011-05-18 | 2011-05-25 |  | 2011-05-13 | 2011-05-20 | 0d? | 5d |  |  |
| 386 | 1.3.1.3.1 | **1st Flight** | 4d | 2011-05-18 | 2011-05-22 |  | 2011-05-13 | 2011-05-17 | 0d? | 5d |  |  |
| 387 | 1.3.1.3.1.1 | Brick Work | 1d | 2011-05-18 | 2011-05-19 | 360 | 2011-05-13 | 2011-05-14 | 0d? | 5d | 0d |  |
| 388 | 1.3.1.3.1.2 | Form Work | 1d | 2011-05-19 | 2011-05-20 | 387 | 2011-05-14 | 2011-05-15 | 0d? | 5d | 0d |  |
| 389 | 1.3.1.3.1.3 | Re-bar Work | 1d | 2011-05-20 | 2011-05-21 | 388 | 2011-05-15 | 2011-05-16 | 0d? | 5d | 0d |  |
| 390 | 1.3.1.3.1.4 | Concrete | 1d | 2011-05-21 | 2011-05-22 | 389 | 2011-05-16 | 2011-05-17 | 0d? | 5d | 0d |  |
| 391 | 1.3.1.3.2 | **2nd Flight** | 3d | 2011-05-22 | 2011-05-25 |  | 2011-05-17 | 2011-05-20 | 0d? | 5d |  |  |
| 392 | 1.3.1.3.2.1 | Form Work | 1d | 2011-05-22 | 2011-05-23 | 390 | 2011-05-17 | 2011-05-18 | 0d? | 5d | 0d |  |
| 393 | 1.3.1.3.2.2 | Re-bar | 1d | 2011-05-23 | 2011-05-24 | 392 | 2011-05-18 | 2011-05-19 | 0d? | 5d | 0d |  |
| 394 | 1.3.1.3.2.3 | Concrete | 1d | 2011-05-24 | 2011-05-25 | 393 | 2011-05-19 | 2011-05-20 | 0d? | 5d |  |  |
| 395 | 1.3.1.4 | **Roof Slab** | 13d | 2011-05-30 | 2011-06-12 |  | 2011-05-25 | 2011-06-07 | 0d? | 0d |  |  |
| 396 | 1.3.1.4.1 | Form Work | 5d | 2011-05-30 | 2011-06-04 | 373, 384, 394 | 2011-05-25 | 2011-05-30 | 0d? | 0d |  |  |
| 397 | 1.3.1.4.2 | Re-bar | 4d | 2011-06-04 | 2011-06-08 | 396 | 2011-05-30 | 2011-06-03 | 0d? | 0d |  |  |
| 398 | 1.3.1.4.3 | MEP Work | 1d | 2011-06-08 | 2011-06-09 | 397 | 2011-06-03 | 2011-06-04 | 0d? | 0d |  |  |
| 399 | 1.3.1.4.4 | Inspection | 1d | 2011-06-09 | 2011-06-10 | 398 | 2011-06-04 | 2011-06-05 | 0d? | 0d |  |  |
| 400 | 1.3.1.4.5 | Concrete | 2d | 2011-06-10 | 2011-06-12 | 399 | 2011-06-05 | 2011-06-07 | 0d? | 0d |  |  |
| 401 | 1.3.2 | **1ST FLOOR** | 25d | 2011-06-12 | 2011-07-07 |  | 2011-06-07 | 2011-07-02 | 25d | 0d |  |  |
| 402 | 1.3.2.1 | **Column** | 12d | 2011-06-12 | 2011-06-24 |  | 2011-06-07 | 2011-06-19 | 0d? | 0d |  | nos. |
| 403 | 1.3.2.1.1 | **1ST Lift** | 6d | 2011-06-12 | 2011-06-18 |  | 2011-06-07 | 2011-06-13 | 0d? | 0d |  |  |
| 404 | 1.3.2.1.1.1 | Re-Bar Work | 1d | 2011-06-12 | 2011-06-13 | 400 | 2011-06-07 | 2011-06-08 | 0d? | 0d |  |  |
| 405 | 1.3.2.1.1.2 | Form Work | 1d | 2011-06-13 | 2011-06-14 | 404 | 2011-06-08 | 2011-06-09 | 0d? | 0d |  |  |
| 406 | 1.3.2.1.1.3 | Concrete | 1d | 2011-06-14 | 2011-06-15 | 405 | 2011-06-09 | 2011-06-10 | 0d? | 0d |  |  |
| 407 | 1.3.2.1.1.4 | De-shuttering | 1d | 2011-06-17 | 2011-06-18 | 406FS+2d | 2011-06-12 | 2011-06-13 | 0d? | 0d |  |  |

| ID | WBS | Task | Duration | Start | Finish | Predecessors | Baseline start | Baseline finish | Baseline duration | Total slack | Free slack | Text1 |
| --- | --- | --- | --- | --- | --- | --- | --- | --- | --- | --- | --- | --- |
| 408 | 1.3.2.1.2 | **2nd Lift** | 6d | 2011-06-18 | 2011-06-24 |  | 2011-06-13 | 2011-06-19 | 0d? | 0d |  |  |
| 409 | 1.3.2.1.2.1 | Re-Bar Work | 1d | 2011-06-18 | 2011-06-19 | 407 | 2011-06-13 | 2011-06-14 | 0d? | 0d |  |  |
| 410 | 1.3.2.1.2.2 | Form Work | 1d | 2011-06-19 | 2011-06-20 | 409 | 2011-06-14 | 2011-06-15 | 0d? | 0d |  |  |
| 411 | 1.3.2.1.2.3 | Concrete | 1d | 2011-06-20 | 2011-06-21 | 410 | 2011-06-15 | 2011-06-16 | 0d? | 0d |  |  |
| 412 | 1.3.2.1.2.4 | De-shuttering | 1d | 2011-06-23 | 2011-06-24 | 411FS+2d | 2011-06-18 | 2011-06-19 | 0d? | 0d |  |  |
| 413 | 1.3.2.2 | **Shear Wall** | 12d | 2011-06-12 | 2011-06-24 |  | 2011-06-07 | 2011-06-19 | 0d? | 0d |  | nos. |
| 414 | 1.3.2.2.1 | **1st Lift** | 6d | 2011-06-12 | 2011-06-18 |  | 2011-06-07 | 2011-06-13 | 0d? | 0d |  |  |
| 415 | 1.3.2.2.1.1 | Re-Bar Work | 1d | 2011-06-12 | 2011-06-13 | 400 | 2011-06-07 | 2011-06-08 | 0d? | 0d |  |  |
| 416 | 1.3.2.2.1.2 | Form Work | 1d | 2011-06-13 | 2011-06-14 | 415 | 2011-06-08 | 2011-06-09 | 0d? | 0d |  |  |
| 417 | 1.3.2.2.1.3 | Concrete | 1d | 2011-06-14 | 2011-06-15 | 416 | 2011-06-09 | 2011-06-10 | 0d? | 0d |  |  |
| 418 | 1.3.2.2.1.4 | De-shuttering | 1d | 2011-06-17 | 2011-06-18 | 417FS+2d | 2011-06-12 | 2011-06-13 | 0d? | 0d |  |  |
| 419 | 1.3.2.2.2 | **2nd Lift** | 6d | 2011-06-18 | 2011-06-24 |  | 2011-06-13 | 2011-06-19 | 0d? | 0d |  |  |
| 420 | 1.3.2.2.2.1 | Re-Bar Work | 1d | 2011-06-18 | 2011-06-19 | 418 | 2011-06-13 | 2011-06-14 | 0d? | 0d |  |  |
| 421 | 1.3.2.2.2.2 | Form Work | 1d | 2011-06-19 | 2011-06-20 | 420 | 2011-06-14 | 2011-06-15 | 0d? | 0d |  |  |
| 422 | 1.3.2.2.2.3 | Concrete | 1d | 2011-06-20 | 2011-06-21 | 421 | 2011-06-15 | 2011-06-16 | 0d? | 0d |  |  |
| 423 | 1.3.2.2.2.4 | De-shuttering | 1d | 2011-06-23 | 2011-06-24 | 422FS+2d | 2011-06-18 | 2011-06-19 | 0d? | 0d |  |  |
| 424 | 1.3.2.3 | **Stair - 1 & 2** | 7d | 2011-06-12 | 2011-06-19 |  | 2011-06-07 | 2011-06-14 | 0d? | 5d |  |  |
| 425 | 1.3.2.3.1 | **1st Flight** | 4d | 2011-06-12 | 2011-06-16 |  | 2011-06-07 | 2011-06-11 | 0d? | 5d |  |  |
| 426 | 1.3.2.3.1.1 | Brick Work | 1d | 2011-06-12 | 2011-06-13 | 400 | 2011-06-07 | 2011-06-08 | 0d? | 5d | 0d |  |
| 427 | 1.3.2.3.1.2 | Form Work | 1d | 2011-06-13 | 2011-06-14 | 426 | 2011-06-08 | 2011-06-09 | 0d? | 5d | 0d |  |
| 428 | 1.3.2.3.1.3 | Re-bar Work | 1d | 2011-06-14 | 2011-06-15 | 427 | 2011-06-09 | 2011-06-10 | 0d? | 5d | 0d |  |
| 429 | 1.3.2.3.1.4 | Concrete | 1d | 2011-06-15 | 2011-06-16 | 428 | 2011-06-10 | 2011-06-11 | 0d? | 5d | 0d |  |
| 430 | 1.3.2.3.2 | **2nd Flight** | 3d | 2011-06-16 | 2011-06-19 |  | 2011-06-11 | 2011-06-14 | 0d? | 5d |  |  |
| 431 | 1.3.2.3.2.1 | Form Work | 1d | 2011-06-16 | 2011-06-17 | 429 | 2011-06-11 | 2011-06-12 | 0d? | 5d | 0d |  |
| 432 | 1.3.2.3.2.2 | Re-bar | 1d | 2011-06-17 | 2011-06-18 | 431 | 2011-06-12 | 2011-06-13 | 0d? | 5d | 0d |  |
| 433 | 1.3.2.3.2.3 | Concrete | 1d | 2011-06-18 | 2011-06-19 | 432 | 2011-06-13 | 2011-06-14 | 0d? | 5d |  |  |

| ID | WBS | Task | Duration | Start | Finish | Predecessors | Baseline start | Baseline finish | Baseline duration | Total slack | Text1 |
| --- | --- | --- | --- | --- | --- | --- | --- | --- | --- | --- | --- |
| 434 | 1.3.2.4 | **Roof Slab** | 13d | 2011-06-24 | 2011-07-07 |  | 2011-06-19 | 2011-07-02 | 0d? | 0d |  |
| 435 | 1.3.2.4.1 | Form Work | 5d | 2011-06-24 | 2011-06-29 | 412, 423, 433 | 2011-06-19 | 2011-06-24 | 0d? | 0d |  |
| 436 | 1.3.2.4.2 | Re-bar | 4d | 2011-06-29 | 2011-07-03 | 435 | 2011-06-24 | 2011-06-28 | 0d? | 0d |  |
| 437 | 1.3.2.4.3 | MEP Work | 1d | 2011-07-03 | 2011-07-04 | 436 | 2011-06-28 | 2011-06-29 | 0d? | 0d |  |
| 438 | 1.3.2.4.4 | Inspection | 1d | 2011-07-04 | 2011-07-05 | 437 | 2011-06-29 | 2011-06-30 | 0d? | 0d |  |
| 439 | 1.3.2.4.5 | Concrete | 2d | 2011-07-05 | 2011-07-07 | 438 | 2011-06-30 | 2011-07-02 | 0d? | 0d |  |
| 440 | 1.3.3 | **2ND FLOOR** | 25d | 2011-07-07 | 2011-08-01 |  | 2011-07-02 | 2011-07-27 | 25d | 0d |  |
| 441 | 1.3.3.1 | **Column** | 12d | 2011-07-07 | 2011-07-19 |  | 2011-07-02 | 2011-07-14 | 0d? | 0d | nos. |
| 442 | 1.3.3.1.1 | **1ST Lift** | 6d | 2011-07-07 | 2011-07-13 |  | 2011-07-02 | 2011-07-08 | 0d? | 0d |  |
| 443 | 1.3.3.1.1.1 | Re-Bar Work | 1d | 2011-07-07 | 2011-07-08 | 439 | 2011-07-02 | 2011-07-03 | 0d? | 0d |  |
| 444 | 1.3.3.1.1.2 | Form Work | 1d | 2011-07-08 | 2011-07-09 | 443 | 2011-07-03 | 2011-07-04 | 0d? | 0d |  |
| 445 | 1.3.3.1.1.3 | Concrete | 1d | 2011-07-09 | 2011-07-10 | 444 | 2011-07-04 | 2011-07-05 | 0d? | 0d |  |
| 446 | 1.3.3.1.1.4 | De-shuttering | 1d | 2011-07-12 | 2011-07-13 | 445FS+2d | 2011-07-07 | 2011-07-08 | 0d? | 0d |  |
| 447 | 1.3.3.1.2 | **2nd Lift** | 6d | 2011-07-13 | 2011-07-19 |  | 2011-07-08 | 2011-07-14 | 0d? | 0d |  |
| 448 | 1.3.3.1.2.1 | Re-Bar Work | 1d | 2011-07-13 | 2011-07-14 | 446 | 2011-07-08 | 2011-07-09 | 0d? | 0d |  |
| 449 | 1.3.3.1.2.2 | Form Work | 1d | 2011-07-14 | 2011-07-15 | 448 | 2011-07-09 | 2011-07-10 | 0d? | 0d |  |
| 450 | 1.3.3.1.2.3 | Concrete | 1d | 2011-07-15 | 2011-07-16 | 449 | 2011-07-10 | 2011-07-11 | 0d? | 0d |  |
| 451 | 1.3.3.1.2.4 | De-shuttering | 1d | 2011-07-18 | 2011-07-19 | 450FS+2d | 2011-07-13 | 2011-07-14 | 0d? | 0d |  |
| 452 | 1.3.3.2 | **Shear Wall** | 12d | 2011-07-07 | 2011-07-19 |  | 2011-07-02 | 2011-07-14 | 0d? | 0d | nos. |
| 453 | 1.3.3.2.1 | **1st Lift** | 6d | 2011-07-07 | 2011-07-13 |  | 2011-07-02 | 2011-07-08 | 0d? | 0d |  |
| 454 | 1.3.3.2.1.1 | Re-Bar Work | 1d | 2011-07-07 | 2011-07-08 | 439 | 2011-07-02 | 2011-07-03 | 0d? | 0d |  |
| 455 | 1.3.3.2.1.2 | Form Work | 1d | 2011-07-08 | 2011-07-09 | 454 | 2011-07-03 | 2011-07-04 | 0d? | 0d |  |
| 456 | 1.3.3.2.1.3 | Concrete | 1d | 2011-07-09 | 2011-07-10 | 455 | 2011-07-04 | 2011-07-05 | 0d? | 0d |  |
| 457 | 1.3.3.2.1.4 | De-shuttering | 1d | 2011-07-12 | 2011-07-13 | 456FS+2d | 2011-07-07 | 2011-07-08 | 0d? | 0d |  |

| ID | WBS | Task | Duration | Start | Finish | Predecessors | Baseline start | Baseline finish | Baseline duration | Total slack | Free slack | Text1 |
| --- | --- | --- | --- | --- | --- | --- | --- | --- | --- | --- | --- | --- |
| 458 | 1.3.3.2.2 | **2nd Lift** | 6d | 2011-07-13 | 2011-07-19 |  | 2011-07-08 | 2011-07-14 | 0d? | 0d |  |  |
| 459 | 1.3.3.2.2.1 | Re-Bar Work | 1d | 2011-07-13 | 2011-07-14 | 457 | 2011-07-08 | 2011-07-09 | 0d? | 0d |  |  |
| 460 | 1.3.3.2.2.2 | Form Work | 1d | 2011-07-14 | 2011-07-15 | 459 | 2011-07-09 | 2011-07-10 | 0d? | 0d |  |  |
| 461 | 1.3.3.2.2.3 | Concrete | 1d | 2011-07-15 | 2011-07-16 | 460 | 2011-07-10 | 2011-07-11 | 0d? | 0d |  |  |
| 462 | 1.3.3.2.2.4 | De-shuttering | 1d | 2011-07-18 | 2011-07-19 | 461FS+2d | 2011-07-13 | 2011-07-14 | 0d? | 0d |  |  |
| 463 | 1.3.3.3 | **Stair - 1 & 2** | 7d | 2011-07-07 | 2011-07-14 |  | 2011-07-02 | 2011-07-09 | 0d? | 5d |  |  |
| 464 | 1.3.3.3.1 | **1st Flight** | 4d | 2011-07-07 | 2011-07-11 |  | 2011-07-02 | 2011-07-06 | 0d? | 5d |  |  |
| 465 | 1.3.3.3.1.1 | Brick Work | 1d | 2011-07-07 | 2011-07-08 | 439 | 2011-07-02 | 2011-07-03 | 0d? | 5d | 0d |  |
| 466 | 1.3.3.3.1.2 | Form Work | 1d | 2011-07-08 | 2011-07-09 | 465 | 2011-07-03 | 2011-07-04 | 0d? | 5d | 0d |  |
| 467 | 1.3.3.3.1.3 | Re-bar Work | 1d | 2011-07-09 | 2011-07-10 | 466 | 2011-07-04 | 2011-07-05 | 0d? | 5d | 0d |  |
| 468 | 1.3.3.3.1.4 | Concrete | 1d | 2011-07-10 | 2011-07-11 | 467 | 2011-07-05 | 2011-07-06 | 0d? | 5d | 0d |  |
| 469 | 1.3.3.3.2 | **2nd Flight** | 3d | 2011-07-11 | 2011-07-14 |  | 2011-07-06 | 2011-07-09 | 0d? | 5d |  |  |
| 470 | 1.3.3.3.2.1 | Form Work | 1d | 2011-07-11 | 2011-07-12 | 468 | 2011-07-06 | 2011-07-07 | 0d? | 5d | 0d |  |
| 471 | 1.3.3.3.2.2 | Re-bar | 1d | 2011-07-12 | 2011-07-13 | 470 | 2011-07-07 | 2011-07-08 | 0d? | 5d | 0d |  |
| 472 | 1.3.3.3.2.3 | Concrete | 1d | 2011-07-13 | 2011-07-14 | 471 | 2011-07-08 | 2011-07-09 | 0d? | 5d |  |  |
| 473 | 1.3.3.4 | **Roof Slab** | 13d | 2011-07-19 | 2011-08-01 |  | 2011-07-14 | 2011-07-27 | 0d? | 0d |  |  |
| 474 | 1.3.3.4.1 | Form Work | 5d | 2011-07-19 | 2011-07-24 | 451, 462, 472 | 2011-07-14 | 2011-07-19 | 0d? | 0d |  |  |
| 475 | 1.3.3.4.2 | Re-bar | 4d | 2011-07-24 | 2011-07-28 | 474 | 2011-07-19 | 2011-07-23 | 0d? | 0d |  |  |
| 476 | 1.3.3.4.3 | MEP Work | 1d | 2011-07-28 | 2011-07-29 | 475 | 2011-07-23 | 2011-07-24 | 0d? | 0d |  |  |
| 477 | 1.3.3.4.4 | Inspection | 1d | 2011-07-29 | 2011-07-30 | 476 | 2011-07-24 | 2011-07-25 | 0d? | 0d |  |  |
| 478 | 1.3.3.4.5 | Concrete | 2d | 2011-07-30 | 2011-08-01 | 477 | 2011-07-25 | 2011-07-27 | 0d? | 0d |  |  |
| 479 | 1.3.4 | **3RD FLOOR** | 25d | 2011-08-01 | 2011-09-03 |  | 2011-07-27 | 2011-08-21 | 25d | 0d |  |  |
| 480 | 1.3.4.1 | **Column** | 12d | 2011-08-01 | 2011-08-13 |  | 2011-07-27 | 2011-08-08 | 0d? | 0d |  | nos. |
| 481 | 1.3.4.1.1 | **1ST Lift** | 6d | 2011-08-01 | 2011-08-07 |  | 2011-07-27 | 2011-08-02 | 0d? | 0d |  |  |
| 482 | 1.3.4.1.1.1 | Re-Bar Work | 1d | 2011-08-01 | 2011-08-02 | 478 | 2011-07-27 | 2011-07-28 | 0d? | 0d |  |  |
| 483 | 1.3.4.1.1.2 | Form Work | 1d | 2011-08-02 | 2011-08-03 | 482 | 2011-07-28 | 2011-07-29 | 0d? | 0d |  |  |
| 484 | 1.3.4.1.1.3 | Concrete | 1d | 2011-08-03 | 2011-08-04 | 483 | 2011-07-29 | 2011-07-30 | 0d? | 0d |  |  |
| 485 | 1.3.4.1.1.4 | De-shuttering | 1d | 2011-08-06 | 2011-08-07 | 484FS+2d | 2011-08-01 | 2011-08-02 | 0d? | 0d |  |  |

| ID | WBS | Task | Duration | Start | Finish | Predecessors | Baseline start | Baseline finish | Baseline duration | Total slack | Free slack | Text1 |
| --- | --- | --- | --- | --- | --- | --- | --- | --- | --- | --- | --- | --- |
| 486 | 1.3.4.1.2 | **2nd Lift** | 6d | 2011-08-07 | 2011-08-13 |  | 2011-08-02 | 2011-08-08 | 0d? | 0d |  |  |
| 487 | 1.3.4.1.2.1 | Re-Bar Work | 1d | 2011-08-07 | 2011-08-08 | 485 | 2011-08-02 | 2011-08-03 | 0d? | 0d |  |  |
| 488 | 1.3.4.1.2.2 | Form Work | 1d | 2011-08-08 | 2011-08-09 | 487 | 2011-08-03 | 2011-08-04 | 0d? | 0d |  |  |
| 489 | 1.3.4.1.2.3 | Concrete | 1d | 2011-08-09 | 2011-08-10 | 488 | 2011-08-04 | 2011-08-05 | 0d? | 0d |  |  |
| 490 | 1.3.4.1.2.4 | De-shuttering | 1d | 2011-08-12 | 2011-08-13 | 489FS+2d | 2011-08-07 | 2011-08-08 | 0d? | 0d |  |  |
| 491 | 1.3.4.2 | **Shear Wall** | 12d | 2011-08-01 | 2011-08-13 |  | 2011-07-27 | 2011-08-08 | 0d? | 0d |  | nos. |
| 492 | 1.3.4.2.1 | **1st Lift** | 6d | 2011-08-01 | 2011-08-07 |  | 2011-07-27 | 2011-08-02 | 0d? | 0d |  |  |
| 493 | 1.3.4.2.1.1 | Re-Bar Work | 1d | 2011-08-01 | 2011-08-02 | 478 | 2011-07-27 | 2011-07-28 | 0d? | 0d |  |  |
| 494 | 1.3.4.2.1.2 | Form Work | 1d | 2011-08-02 | 2011-08-03 | 493 | 2011-07-28 | 2011-07-29 | 0d? | 0d |  |  |
| 495 | 1.3.4.2.1.3 | Concrete | 1d | 2011-08-03 | 2011-08-04 | 494 | 2011-07-29 | 2011-07-30 | 0d? | 0d |  |  |
| 496 | 1.3.4.2.1.4 | De-shuttering | 1d | 2011-08-06 | 2011-08-07 | 495FS+2d | 2011-08-01 | 2011-08-02 | 0d? | 0d |  |  |
| 497 | 1.3.4.2.2 | **2nd Lift** | 6d | 2011-08-07 | 2011-08-13 |  | 2011-08-02 | 2011-08-08 | 0d? | 0d |  |  |
| 498 | 1.3.4.2.2.1 | Re-Bar Work | 1d | 2011-08-07 | 2011-08-08 | 496 | 2011-08-02 | 2011-08-03 | 0d? | 0d |  |  |
| 499 | 1.3.4.2.2.2 | Form Work | 1d | 2011-08-08 | 2011-08-09 | 498 | 2011-08-03 | 2011-08-04 | 0d? | 0d |  |  |
| 500 | 1.3.4.2.2.3 | Concrete | 1d | 2011-08-09 | 2011-08-10 | 499 | 2011-08-04 | 2011-08-05 | 0d? | 0d |  |  |
| 501 | 1.3.4.2.2.4 | De-shuttering | 1d | 2011-08-12 | 2011-08-13 | 500FS+2d | 2011-08-07 | 2011-08-08 | 0d? | 0d |  |  |
| 502 | 1.3.4.3 | **Stair - 1 & 2** | 7d | 2011-08-01 | 2011-08-08 |  | 2011-07-27 | 2011-08-03 | 0d? | 5d |  |  |
| 503 | 1.3.4.3.1 | **1st Flight** | 4d | 2011-08-01 | 2011-08-05 |  | 2011-07-27 | 2011-07-31 | 0d? | 5d |  |  |
| 504 | 1.3.4.3.1.1 | Brick Work | 1d | 2011-08-01 | 2011-08-02 | 478 | 2011-07-27 | 2011-07-28 | 0d? | 5d | 0d |  |
| 505 | 1.3.4.3.1.2 | Form Work | 1d | 2011-08-02 | 2011-08-03 | 504 | 2011-07-28 | 2011-07-29 | 0d? | 5d | 0d |  |
| 506 | 1.3.4.3.1.3 | Re-bar Work | 1d | 2011-08-03 | 2011-08-04 | 505 | 2011-07-29 | 2011-07-30 | 0d? | 5d | 0d |  |
| 507 | 1.3.4.3.1.4 | Concrete | 1d | 2011-08-04 | 2011-08-05 | 506 | 2011-07-30 | 2011-07-31 | 0d? | 5d | 0d |  |
| 508 | 1.3.4.3.2 | **2nd Flight** | 3d | 2011-08-05 | 2011-08-08 |  | 2011-07-31 | 2011-08-03 | 0d? | 5d |  |  |
| 509 | 1.3.4.3.2.1 | Form Work | 1d | 2011-08-05 | 2011-08-06 | 507 | 2011-07-31 | 2011-08-01 | 0d? | 5d | 0d |  |
| 510 | 1.3.4.3.2.2 | Re-bar | 1d | 2011-08-06 | 2011-08-07 | 509 | 2011-08-01 | 2011-08-02 | 0d? | 5d | 0d |  |
| 511 | 1.3.4.3.2.3 | Concrete | 1d | 2011-08-07 | 2011-08-08 | 510 | 2011-08-02 | 2011-08-03 | 0d? | 5d |  |  |

| ID | WBS | Task | Duration | Start | Finish | Predecessors | Baseline start | Baseline finish | Baseline duration | Total slack | Text1 |
| --- | --- | --- | --- | --- | --- | --- | --- | --- | --- | --- | --- |
| 512 | 1.3.4.4 | **Roof Slab** | 13d | 2011-08-13 | 2011-09-03 |  | 2011-08-08 | 2011-08-21 | 0d? | 0d |  |
| 513 | 1.3.4.4.1 | Form Work | 5d | 2011-08-13 | 2011-08-18 | 490, 501, 511 | 2011-08-08 | 2011-08-13 | 0d? | 0d |  |
| 514 | 1.3.4.4.2 | Re-bar | 4d | 2011-08-18 | 2011-08-22 | 513 | 2011-08-13 | 2011-08-17 | 0d? | 0d |  |
| 515 | 1.3.4.4.3 | MEP Work | 1d | 2011-08-22 | 2011-08-23 | 514 | 2011-08-17 | 2011-08-18 | 0d? | 0d |  |
| 516 | 1.3.4.4.4 | Inspection | 1d | 2011-08-23 | 2011-08-24 | 515 | 2011-08-18 | 2011-08-19 | 0d? | 0d |  |
| 517 | 1.3.4.4.5 | Concrete | 2d | 2011-08-24 | 2011-09-03 | 516 | 2011-08-19 | 2011-08-21 | 0d? | 0d |  |
| 518 | 1.3.5 | **4TH FLOOR** | 25d | 2011-09-03 | 2011-09-28 |  | 2011-08-21 | 2011-09-23 | 25d | 0d |  |
| 519 | 1.3.5.1 | **Column** | 12d | 2011-09-03 | 2011-09-15 |  | 2011-08-21 | 2011-09-10 | 0d? | 0d | nos. |
| 520 | 1.3.5.1.1 | **1ST Lift** | 6d | 2011-09-03 | 2011-09-09 |  | 2011-08-21 | 2011-09-04 | 0d? | 0d |  |
| 521 | 1.3.5.1.1.1 | Re-Bar Work | 1d | 2011-09-03 | 2011-09-04 | 517 | 2011-08-21 | 2011-08-22 | 0d? | 0d |  |
| 522 | 1.3.5.1.1.2 | Form Work | 1d | 2011-09-04 | 2011-09-05 | 521 | 2011-08-22 | 2011-08-23 | 0d? | 0d |  |
| 523 | 1.3.5.1.1.3 | Concrete | 1d | 2011-09-05 | 2011-09-06 | 522 | 2011-08-23 | 2011-08-24 | 0d? | 0d |  |
| 524 | 1.3.5.1.1.4 | De-shuttering | 1d | 2011-09-08 | 2011-09-09 | 523FS+2d | 2011-09-03 | 2011-09-04 | 0d? | 0d |  |
| 525 | 1.3.5.1.2 | **2nd Lift** | 6d | 2011-09-09 | 2011-09-15 |  | 2011-09-04 | 2011-09-10 | 0d? | 0d |  |
| 526 | 1.3.5.1.2.1 | Re-Bar Work | 1d | 2011-09-09 | 2011-09-10 | 524 | 2011-09-04 | 2011-09-05 | 0d? | 0d |  |
| 527 | 1.3.5.1.2.2 | Form Work | 1d | 2011-09-10 | 2011-09-11 | 526 | 2011-09-05 | 2011-09-06 | 0d? | 0d |  |
| 528 | 1.3.5.1.2.3 | Concrete | 1d | 2011-09-11 | 2011-09-12 | 527 | 2011-09-06 | 2011-09-07 | 0d? | 0d |  |
| 529 | 1.3.5.1.2.4 | De-shuttering | 1d | 2011-09-14 | 2011-09-15 | 528FS+2d | 2011-09-09 | 2011-09-10 | 0d? | 0d |  |
| 530 | 1.3.5.2 | **Shear Wall** | 12d | 2011-09-03 | 2011-09-15 |  | 2011-08-21 | 2011-09-10 | 0d? | 0d | nos. |
| 531 | 1.3.5.2.1 | **1st Lift** | 6d | 2011-09-03 | 2011-09-09 |  | 2011-08-21 | 2011-09-04 | 0d? | 0d |  |
| 532 | 1.3.5.2.1.1 | Re-Bar Work | 1d | 2011-09-03 | 2011-09-04 | 517 | 2011-08-21 | 2011-08-22 | 0d? | 0d |  |
| 533 | 1.3.5.2.1.2 | Form Work | 1d | 2011-09-04 | 2011-09-05 | 532 | 2011-08-22 | 2011-08-23 | 0d? | 0d |  |
| 534 | 1.3.5.2.1.3 | Concrete | 1d | 2011-09-05 | 2011-09-06 | 533 | 2011-08-23 | 2011-08-24 | 0d? | 0d |  |
| 535 | 1.3.5.2.1.4 | De-shuttering | 1d | 2011-09-08 | 2011-09-09 | 534FS+2d | 2011-09-03 | 2011-09-04 | 0d? | 0d |  |

| ID | WBS | Task | Duration | Start | Finish | Predecessors | Baseline start | Baseline finish | Baseline duration | Total slack | Free slack | Text1 |
| --- | --- | --- | --- | --- | --- | --- | --- | --- | --- | --- | --- | --- |
| 536 | 1.3.5.2.2 | **2nd Lift** | 6d | 2011-09-09 | 2011-09-15 |  | 2011-09-04 | 2011-09-10 | 0d? | 0d |  |  |
| 537 | 1.3.5.2.2.1 | Re-Bar Work | 1d | 2011-09-09 | 2011-09-10 | 535 | 2011-09-04 | 2011-09-05 | 0d? | 0d |  |  |
| 538 | 1.3.5.2.2.2 | Form Work | 1d | 2011-09-10 | 2011-09-11 | 537 | 2011-09-05 | 2011-09-06 | 0d? | 0d |  |  |
| 539 | 1.3.5.2.2.3 | Concrete | 1d | 2011-09-11 | 2011-09-12 | 538 | 2011-09-06 | 2011-09-07 | 0d? | 0d |  |  |
| 540 | 1.3.5.2.2.4 | De-shuttering | 1d | 2011-09-14 | 2011-09-15 | 539FS+2d | 2011-09-09 | 2011-09-10 | 0d? | 0d |  |  |
| 541 | 1.3.5.3 | **Stair - 1 & 2** | 7d | 2011-09-03 | 2011-09-10 |  | 2011-08-21 | 2011-09-05 | 0d? | 5d |  |  |
| 542 | 1.3.5.3.1 | **1st Flight** | 4d | 2011-09-03 | 2011-09-07 |  | 2011-08-21 | 2011-08-25 | 0d? | 5d |  |  |
| 543 | 1.3.5.3.1.1 | Brick Work | 1d | 2011-09-03 | 2011-09-04 | 517 | 2011-08-21 | 2011-08-22 | 0d? | 5d | 0d |  |
| 544 | 1.3.5.3.1.2 | Form Work | 1d | 2011-09-04 | 2011-09-05 | 543 | 2011-08-22 | 2011-08-23 | 0d? | 5d | 0d |  |
| 545 | 1.3.5.3.1.3 | Re-bar Work | 1d | 2011-09-05 | 2011-09-06 | 544 | 2011-08-23 | 2011-08-24 | 0d? | 5d | 0d |  |
| 546 | 1.3.5.3.1.4 | Concrete | 1d | 2011-09-06 | 2011-09-07 | 545 | 2011-08-24 | 2011-08-25 | 0d? | 5d | 0d |  |
| 547 | 1.3.5.3.2 | **2nd Flight** | 3d | 2011-09-07 | 2011-09-10 |  | 2011-08-25 | 2011-09-05 | 0d? | 5d |  |  |
| 548 | 1.3.5.3.2.1 | Form Work | 1d | 2011-09-07 | 2011-09-08 | 546 | 2011-08-25 | 2011-09-03 | 0d? | 5d | 0d |  |
| 549 | 1.3.5.3.2.2 | Re-bar | 1d | 2011-09-08 | 2011-09-09 | 548 | 2011-09-03 | 2011-09-04 | 0d? | 5d | 0d |  |
| 550 | 1.3.5.3.2.3 | Concrete | 1d | 2011-09-09 | 2011-09-10 | 549 | 2011-09-04 | 2011-09-05 | 0d? | 5d |  |  |
| 551 | 1.3.5.4 | **Roof Slab** | 13d | 2011-09-15 | 2011-09-28 |  | 2011-09-10 | 2011-09-23 | 0d? | 0d |  |  |
| 552 | 1.3.5.4.1 | Form Work | 5d | 2011-09-15 | 2011-09-20 | 529, 540, 550 | 2011-09-10 | 2011-09-15 | 0d? | 0d |  |  |
| 553 | 1.3.5.4.2 | Re-bar | 4d | 2011-09-20 | 2011-09-24 | 552 | 2011-09-15 | 2011-09-19 | 0d? | 0d |  |  |
| 554 | 1.3.5.4.3 | MEP Work | 1d | 2011-09-24 | 2011-09-25 | 553 | 2011-09-19 | 2011-09-20 | 0d? | 0d |  |  |
| 555 | 1.3.5.4.4 | Inspection | 1d | 2011-09-25 | 2011-09-26 | 554 | 2011-09-20 | 2011-09-21 | 0d? | 0d |  |  |
| 556 | 1.3.5.4.5 | Concrete | 2d | 2011-09-26 | 2011-09-28 | 555 | 2011-09-21 | 2011-09-23 | 0d? | 0d |  |  |
| 557 | 1.3.6 | **5TH FLOOR** | 25d | 2011-09-28 | 2011-10-23 |  | 2011-09-23 | 2011-10-18 | 25d | 0d |  |  |
| 558 | 1.3.6.1 | **Column** | 12d | 2011-09-28 | 2011-10-10 |  | 2011-09-23 | 2011-10-05 | 0d? | 0d |  | nos. |
| 559 | 1.3.6.1.1 | **1ST Lift** | 6d | 2011-09-28 | 2011-10-04 |  | 2011-09-23 | 2011-09-29 | 0d? | 0d |  |  |
| 560 | 1.3.6.1.1.1 | Re-Bar Work | 1d | 2011-09-28 | 2011-09-29 | 556 | 2011-09-23 | 2011-09-24 | 0d? | 0d |  |  |
| 561 | 1.3.6.1.1.2 | Form Work | 1d | 2011-09-29 | 2011-09-30 | 560 | 2011-09-24 | 2011-09-25 | 0d? | 0d |  |  |
| 562 | 1.3.6.1.1.3 | Concrete | 1d | 2011-09-30 | 2011-10-01 | 561 | 2011-09-25 | 2011-09-26 | 0d? | 0d |  |  |
| 563 | 1.3.6.1.1.4 | De-shuttering | 1d | 2011-10-03 | 2011-10-04 | 562FS+2d | 2011-09-28 | 2011-09-29 | 0d? | 0d |  |  |

| ID | WBS | Task | Duration | Start | Finish | Predecessors | Baseline start | Baseline finish | Baseline duration | Total slack | Free slack | Text1 |
| --- | --- | --- | --- | --- | --- | --- | --- | --- | --- | --- | --- | --- |
| 564 | 1.3.6.1.2 | **2nd Lift** | 6d | 2011-10-04 | 2011-10-10 |  | 2011-09-29 | 2011-10-05 | 0d? | 0d |  |  |
| 565 | 1.3.6.1.2.1 | Re-Bar Work | 1d | 2011-10-04 | 2011-10-05 | 563 | 2011-09-29 | 2011-09-30 | 0d? | 0d |  |  |
| 566 | 1.3.6.1.2.2 | Form Work | 1d | 2011-10-05 | 2011-10-06 | 565 | 2011-09-30 | 2011-10-01 | 0d? | 0d |  |  |
| 567 | 1.3.6.1.2.3 | Concrete | 1d | 2011-10-06 | 2011-10-07 | 566 | 2011-10-01 | 2011-10-02 | 0d? | 0d |  |  |
| 568 | 1.3.6.1.2.4 | De-shuttering | 1d | 2011-10-09 | 2011-10-10 | 567FS+2d | 2011-10-04 | 2011-10-05 | 0d? | 0d |  |  |
| 569 | 1.3.6.2 | **Shear Wall** | 12d | 2011-09-28 | 2011-10-10 |  | 2011-09-23 | 2011-10-05 | 0d? | 0d |  | nos. |
| 570 | 1.3.6.2.1 | **1st Lift** | 6d | 2011-09-28 | 2011-10-04 |  | 2011-09-23 | 2011-09-29 | 0d? | 0d |  |  |
| 571 | 1.3.6.2.1.1 | Re-Bar Work | 1d | 2011-09-28 | 2011-09-29 | 556 | 2011-09-23 | 2011-09-24 | 0d? | 0d |  |  |
| 572 | 1.3.6.2.1.2 | Form Work | 1d | 2011-09-29 | 2011-09-30 | 571 | 2011-09-24 | 2011-09-25 | 0d? | 0d |  |  |
| 573 | 1.3.6.2.1.3 | Concrete | 1d | 2011-09-30 | 2011-10-01 | 572 | 2011-09-25 | 2011-09-26 | 0d? | 0d |  |  |
| 574 | 1.3.6.2.1.4 | De-shuttering | 1d | 2011-10-03 | 2011-10-04 | 573FS+2d | 2011-09-28 | 2011-09-29 | 0d? | 0d |  |  |
| 575 | 1.3.6.2.2 | **2nd Lift** | 6d | 2011-10-04 | 2011-10-10 |  | 2011-09-29 | 2011-10-05 | 0d? | 0d |  |  |
| 576 | 1.3.6.2.2.1 | Re-Bar Work | 1d | 2011-10-04 | 2011-10-05 | 574 | 2011-09-29 | 2011-09-30 | 0d? | 0d |  |  |
| 577 | 1.3.6.2.2.2 | Form Work | 1d | 2011-10-05 | 2011-10-06 | 576 | 2011-09-30 | 2011-10-01 | 0d? | 0d |  |  |
| 578 | 1.3.6.2.2.3 | Concrete | 1d | 2011-10-06 | 2011-10-07 | 577 | 2011-10-01 | 2011-10-02 | 0d? | 0d |  |  |
| 579 | 1.3.6.2.2.4 | De-shuttering | 1d | 2011-10-09 | 2011-10-10 | 578FS+2d | 2011-10-04 | 2011-10-05 | 0d? | 0d |  |  |
| 580 | 1.3.6.3 | **Stair - 1 & 2** | 7d | 2011-09-28 | 2011-10-05 |  | 2011-09-23 | 2011-09-30 | 0d? | 5d |  |  |
| 581 | 1.3.6.3.1 | **1st Flight** | 4d | 2011-09-28 | 2011-10-02 |  | 2011-09-23 | 2011-09-27 | 0d? | 5d |  |  |
| 582 | 1.3.6.3.1.1 | Brick Work | 1d | 2011-09-28 | 2011-09-29 | 556 | 2011-09-23 | 2011-09-24 | 0d? | 5d | 0d |  |
| 583 | 1.3.6.3.1.2 | Form Work | 1d | 2011-09-29 | 2011-09-30 | 582 | 2011-09-24 | 2011-09-25 | 0d? | 5d | 0d |  |
| 584 | 1.3.6.3.1.3 | Re-bar Work | 1d | 2011-09-30 | 2011-10-01 | 583 | 2011-09-25 | 2011-09-26 | 0d? | 5d | 0d |  |
| 585 | 1.3.6.3.1.4 | Concrete | 1d | 2011-10-01 | 2011-10-02 | 584 | 2011-09-26 | 2011-09-27 | 0d? | 5d | 0d |  |
| 586 | 1.3.6.3.2 | **2nd Flight** | 3d | 2011-10-02 | 2011-10-05 |  | 2011-09-27 | 2011-09-30 | 0d? | 5d |  |  |
| 587 | 1.3.6.3.2.1 | Form Work | 1d | 2011-10-02 | 2011-10-03 | 585 | 2011-09-27 | 2011-09-28 | 0d? | 5d | 0d |  |
| 588 | 1.3.6.3.2.2 | Re-bar | 1d | 2011-10-03 | 2011-10-04 | 587 | 2011-09-28 | 2011-09-29 | 0d? | 5d | 0d |  |
| 589 | 1.3.6.3.2.3 | Concrete | 1d | 2011-10-04 | 2011-10-05 | 588 | 2011-09-29 | 2011-09-30 | 0d? | 5d |  |  |

| ID | WBS | Task | Duration | Start | Finish | Predecessors | Baseline start | Baseline finish | Baseline duration | Total slack | Text1 |
| --- | --- | --- | --- | --- | --- | --- | --- | --- | --- | --- | --- |
| 590 | 1.3.6.4 | **Roof Slab** | 13d | 2011-10-10 | 2011-10-23 |  | 2011-10-05 | 2011-10-18 | 0d? | 0d |  |
| 591 | 1.3.6.4.1 | Form Work | 5d | 2011-10-10 | 2011-10-15 | 568, 579, 589 | 2011-10-05 | 2011-10-10 | 0d? | 0d |  |
| 592 | 1.3.6.4.2 | Re-bar | 4d | 2011-10-15 | 2011-10-19 | 591 | 2011-10-10 | 2011-10-14 | 0d? | 0d |  |
| 593 | 1.3.6.4.3 | MEP Work | 1d | 2011-10-19 | 2011-10-20 | 592 | 2011-10-14 | 2011-10-15 | 0d? | 0d |  |
| 594 | 1.3.6.4.4 | Inspection | 1d | 2011-10-20 | 2011-10-21 | 593 | 2011-10-15 | 2011-10-16 | 0d? | 0d |  |
| 595 | 1.3.6.4.5 | Concrete | 2d | 2011-10-21 | 2011-10-23 | 594 | 2011-10-16 | 2011-10-18 | 0d? | 0d |  |
| 596 | 1.3.7 | **6TH FLOOR** | 25d | 2011-10-23 | 2011-11-25 |  | 2011-10-18 | 2011-11-20 | 25d | 0d |  |
| 597 | 1.3.7.1 | **Column** | 12d | 2011-10-23 | 2011-11-04 |  | 2011-10-18 | 2011-10-30 | 0d? | 0d | nos. |
| 598 | 1.3.7.1.1 | **1ST Lift** | 6d | 2011-10-23 | 2011-10-29 |  | 2011-10-18 | 2011-10-24 | 0d? | 0d |  |
| 599 | 1.3.7.1.1.1 | Re-Bar Work | 1d | 2011-10-23 | 2011-10-24 | 595 | 2011-10-18 | 2011-10-19 | 0d? | 0d |  |
| 600 | 1.3.7.1.1.2 | Form Work | 1d | 2011-10-24 | 2011-10-25 | 599 | 2011-10-19 | 2011-10-20 | 0d? | 0d |  |
| 601 | 1.3.7.1.1.3 | Concrete | 1d | 2011-10-25 | 2011-10-26 | 600 | 2011-10-20 | 2011-10-21 | 0d? | 0d |  |
| 602 | 1.3.7.1.1.4 | De-shuttering | 1d | 2011-10-28 | 2011-10-29 | 601FS+2d | 2011-10-23 | 2011-10-24 | 0d? | 0d |  |
| 603 | 1.3.7.1.2 | **2nd Lift** | 6d | 2011-10-29 | 2011-11-04 |  | 2011-10-24 | 2011-10-30 | 0d? | 0d |  |
| 604 | 1.3.7.1.2.1 | Re-Bar Work | 1d | 2011-10-29 | 2011-10-30 | 602 | 2011-10-24 | 2011-10-25 | 0d? | 0d |  |
| 605 | 1.3.7.1.2.2 | Form Work | 1d | 2011-10-30 | 2011-10-31 | 604 | 2011-10-25 | 2011-10-26 | 0d? | 0d |  |
| 606 | 1.3.7.1.2.3 | Concrete | 1d | 2011-10-31 | 2011-11-01 | 605 | 2011-10-26 | 2011-10-27 | 0d? | 0d |  |
| 607 | 1.3.7.1.2.4 | De-shuttering | 1d | 2011-11-03 | 2011-11-04 | 606FS+2d | 2011-10-29 | 2011-10-30 | 0d? | 0d |  |
| 608 | 1.3.7.2 | **Shear Wall** | 12d | 2011-10-23 | 2011-11-04 |  | 2011-10-18 | 2011-10-30 | 0d? | 0d | nos. |
| 609 | 1.3.7.2.1 | **1st Lift** | 6d | 2011-10-23 | 2011-10-29 |  | 2011-10-18 | 2011-10-24 | 0d? | 0d |  |
| 610 | 1.3.7.2.1.1 | Re-Bar Work | 1d | 2011-10-23 | 2011-10-24 | 595 | 2011-10-18 | 2011-10-19 | 0d? | 0d |  |
| 611 | 1.3.7.2.1.2 | Form Work | 1d | 2011-10-24 | 2011-10-25 | 610 | 2011-10-19 | 2011-10-20 | 0d? | 0d |  |
| 612 | 1.3.7.2.1.3 | Concrete | 1d | 2011-10-25 | 2011-10-26 | 611 | 2011-10-20 | 2011-10-21 | 0d? | 0d |  |
| 613 | 1.3.7.2.1.4 | De-shuttering | 1d | 2011-10-28 | 2011-10-29 | 612FS+2d | 2011-10-23 | 2011-10-24 | 0d? | 0d |  |

| ID | WBS | Task | Duration | Start | Finish | Predecessors | Baseline start | Baseline finish | Baseline duration | Total slack | Free slack | Text1 |
| --- | --- | --- | --- | --- | --- | --- | --- | --- | --- | --- | --- | --- |
| 614 | 1.3.7.2.2 | **2nd Lift** | 6d | 2011-10-29 | 2011-11-04 |  | 2011-10-24 | 2011-10-30 | 0d? | 0d |  |  |
| 615 | 1.3.7.2.2.1 | Re-Bar Work | 1d | 2011-10-29 | 2011-10-30 | 613 | 2011-10-24 | 2011-10-25 | 0d? | 0d |  |  |
| 616 | 1.3.7.2.2.2 | Form Work | 1d | 2011-10-30 | 2011-10-31 | 615 | 2011-10-25 | 2011-10-26 | 0d? | 0d |  |  |
| 617 | 1.3.7.2.2.3 | Concrete | 1d | 2011-10-31 | 2011-11-01 | 616 | 2011-10-26 | 2011-10-27 | 0d? | 0d |  |  |
| 618 | 1.3.7.2.2.4 | De-shuttering | 1d | 2011-11-03 | 2011-11-04 | 617FS+2d | 2011-10-29 | 2011-10-30 | 0d? | 0d |  |  |
| 619 | 1.3.7.3 | **Stair - 1 & 2** | 7d | 2011-10-23 | 2011-10-30 |  | 2011-10-18 | 2011-10-25 | 0d? | 5d |  |  |
| 620 | 1.3.7.3.1 | **1st Flight** | 4d | 2011-10-23 | 2011-10-27 |  | 2011-10-18 | 2011-10-22 | 0d? | 5d |  |  |
| 621 | 1.3.7.3.1.1 | Brick Work | 1d | 2011-10-23 | 2011-10-24 | 595 | 2011-10-18 | 2011-10-19 | 0d? | 5d | 0d |  |
| 622 | 1.3.7.3.1.2 | Form Work | 1d | 2011-10-24 | 2011-10-25 | 621 | 2011-10-19 | 2011-10-20 | 0d? | 5d | 0d |  |
| 623 | 1.3.7.3.1.3 | Re-bar Work | 1d | 2011-10-25 | 2011-10-26 | 622 | 2011-10-20 | 2011-10-21 | 0d? | 5d | 0d |  |
| 624 | 1.3.7.3.1.4 | Concrete | 1d | 2011-10-26 | 2011-10-27 | 623 | 2011-10-21 | 2011-10-22 | 0d? | 5d | 0d |  |
| 625 | 1.3.7.3.2 | **2nd Flight** | 3d | 2011-10-27 | 2011-10-30 |  | 2011-10-22 | 2011-10-25 | 0d? | 5d |  |  |
| 626 | 1.3.7.3.2.1 | Form Work | 1d | 2011-10-27 | 2011-10-28 | 624 | 2011-10-22 | 2011-10-23 | 0d? | 5d | 0d |  |
| 627 | 1.3.7.3.2.2 | Re-bar | 1d | 2011-10-28 | 2011-10-29 | 626 | 2011-10-23 | 2011-10-24 | 0d? | 5d | 0d |  |
| 628 | 1.3.7.3.2.3 | Concrete | 1d | 2011-10-29 | 2011-10-30 | 627 | 2011-10-24 | 2011-10-25 | 0d? | 5d |  |  |
| 629 | 1.3.7.4 | **Roof Slab** | 13d | 2011-11-04 | 2011-11-25 |  | 2011-10-30 | 2011-11-20 | 0d? | 0d |  |  |
| 630 | 1.3.7.4.1 | Form Work | 5d | 2011-11-04 | 2011-11-09 | 607, 618, 628 | 2011-10-30 | 2011-11-04 | 0d? | 0d |  |  |
| 631 | 1.3.7.4.2 | Re-bar | 4d | 2011-11-09 | 2011-11-21 | 630 | 2011-11-04 | 2011-11-08 | 0d? | 0d |  |  |
| 632 | 1.3.7.4.3 | MEP Work | 1d | 2011-11-21 | 2011-11-22 | 631 | 2011-11-08 | 2011-11-09 | 0d? | 0d |  |  |
| 633 | 1.3.7.4.4 | Inspection | 1d | 2011-11-22 | 2011-11-23 | 632 | 2011-11-09 | 2011-11-10 | 0d? | 0d |  |  |
| 634 | 1.3.7.4.5 | Concrete | 2d | 2011-11-23 | 2011-11-25 | 633 | 2011-11-10 | 2011-11-20 | 0d? | 0d |  |  |
| 635 | 1.3.8 | **7TH FLOOR** | 25d | 2011-11-25 | 2011-12-20 |  | 2011-11-20 | 2011-12-15 | 25d | 0d |  |  |
| 636 | 1.3.8.1 | **Column** | 12d | 2011-11-25 | 2011-12-07 |  | 2011-11-20 | 2011-12-02 | 0d? | 0d |  | nos. |
| 637 | 1.3.8.1.1 | **1ST Lift** | 6d | 2011-11-25 | 2011-12-01 |  | 2011-11-20 | 2011-11-26 | 0d? | 0d |  |  |
| 638 | 1.3.8.1.1.1 | Re-Bar Work | 1d | 2011-11-25 | 2011-11-26 | 634 | 2011-11-20 | 2011-11-21 | 0d? | 0d |  |  |
| 639 | 1.3.8.1.1.2 | Form Work | 1d | 2011-11-26 | 2011-11-27 | 638 | 2011-11-21 | 2011-11-22 | 0d? | 0d |  |  |
| 640 | 1.3.8.1.1.3 | Concrete | 1d | 2011-11-27 | 2011-11-28 | 639 | 2011-11-22 | 2011-11-23 | 0d? | 0d |  |  |
| 641 | 1.3.8.1.1.4 | De-shuttering | 1d | 2011-11-30 | 2011-12-01 | 640FS+2d | 2011-11-25 | 2011-11-26 | 0d? | 0d |  |  |

| ID | WBS | Task | Duration | Start | Finish | Predecessors | Baseline start | Baseline finish | Baseline duration | Total slack | Free slack | Text1 |
| --- | --- | --- | --- | --- | --- | --- | --- | --- | --- | --- | --- | --- |
| 642 | 1.3.8.1.2 | **2nd Lift** | 6d | 2011-12-01 | 2011-12-07 |  | 2011-11-26 | 2011-12-02 | 0d? | 0d |  |  |
| 643 | 1.3.8.1.2.1 | Re-Bar Work | 1d | 2011-12-01 | 2011-12-02 | 641 | 2011-11-26 | 2011-11-27 | 0d? | 0d |  |  |
| 644 | 1.3.8.1.2.2 | Form Work | 1d | 2011-12-02 | 2011-12-03 | 643 | 2011-11-27 | 2011-11-28 | 0d? | 0d |  |  |
| 645 | 1.3.8.1.2.3 | Concrete | 1d | 2011-12-03 | 2011-12-04 | 644 | 2011-11-28 | 2011-11-29 | 0d? | 0d |  |  |
| 646 | 1.3.8.1.2.4 | De-shuttering | 1d | 2011-12-06 | 2011-12-07 | 645FS+2d | 2011-12-01 | 2011-12-02 | 0d? | 0d |  |  |
| 647 | 1.3.8.2 | **Shear Wall** | 12d | 2011-11-25 | 2011-12-07 |  | 2011-11-20 | 2011-12-02 | 0d? | 0d |  | nos. |
| 648 | 1.3.8.2.1 | **1st Lift** | 6d | 2011-11-25 | 2011-12-01 |  | 2011-11-20 | 2011-11-26 | 0d? | 0d |  |  |
| 649 | 1.3.8.2.1.1 | Re-Bar Work | 1d | 2011-11-25 | 2011-11-26 | 634 | 2011-11-20 | 2011-11-21 | 0d? | 0d |  |  |
| 650 | 1.3.8.2.1.2 | Form Work | 1d | 2011-11-26 | 2011-11-27 | 649 | 2011-11-21 | 2011-11-22 | 0d? | 0d |  |  |
| 651 | 1.3.8.2.1.3 | Concrete | 1d | 2011-11-27 | 2011-11-28 | 650 | 2011-11-22 | 2011-11-23 | 0d? | 0d |  |  |
| 652 | 1.3.8.2.1.4 | De-shuttering | 1d | 2011-11-30 | 2011-12-01 | 651FS+2d | 2011-11-25 | 2011-11-26 | 0d? | 0d |  |  |
| 653 | 1.3.8.2.2 | **2nd Lift** | 6d | 2011-12-01 | 2011-12-07 |  | 2011-11-26 | 2011-12-02 | 0d? | 0d |  |  |
| 654 | 1.3.8.2.2.1 | Re-Bar Work | 1d | 2011-12-01 | 2011-12-02 | 652 | 2011-11-26 | 2011-11-27 | 0d? | 0d |  |  |
| 655 | 1.3.8.2.2.2 | Form Work | 1d | 2011-12-02 | 2011-12-03 | 654 | 2011-11-27 | 2011-11-28 | 0d? | 0d |  |  |
| 656 | 1.3.8.2.2.3 | Concrete | 1d | 2011-12-03 | 2011-12-04 | 655 | 2011-11-28 | 2011-11-29 | 0d? | 0d |  |  |
| 657 | 1.3.8.2.2.4 | De-shuttering | 1d | 2011-12-06 | 2011-12-07 | 656FS+2d | 2011-12-01 | 2011-12-02 | 0d? | 0d |  |  |
| 658 | 1.3.8.3 | **Stair - 1 & 2** | 7d | 2011-11-25 | 2011-12-02 |  | 2011-11-20 | 2011-11-27 | 0d? | 5d |  |  |
| 659 | 1.3.8.3.1 | **1st Flight** | 4d | 2011-11-25 | 2011-11-29 |  | 2011-11-20 | 2011-11-24 | 0d? | 5d |  |  |
| 660 | 1.3.8.3.1.1 | Brick Work | 1d | 2011-11-25 | 2011-11-26 | 634 | 2011-11-20 | 2011-11-21 | 0d? | 5d | 0d |  |
| 661 | 1.3.8.3.1.2 | Form Work | 1d | 2011-11-26 | 2011-11-27 | 660 | 2011-11-21 | 2011-11-22 | 0d? | 5d | 0d |  |
| 662 | 1.3.8.3.1.3 | Re-bar Work | 1d | 2011-11-27 | 2011-11-28 | 661 | 2011-11-22 | 2011-11-23 | 0d? | 5d | 0d |  |
| 663 | 1.3.8.3.1.4 | Concrete | 1d | 2011-11-28 | 2011-11-29 | 662 | 2011-11-23 | 2011-11-24 | 0d? | 5d | 0d |  |
| 664 | 1.3.8.3.2 | **2nd Flight** | 3d | 2011-11-29 | 2011-12-02 |  | 2011-11-24 | 2011-11-27 | 0d? | 5d |  |  |
| 665 | 1.3.8.3.2.1 | Form Work | 1d | 2011-11-29 | 2011-11-30 | 663 | 2011-11-24 | 2011-11-25 | 0d? | 5d | 0d |  |
| 666 | 1.3.8.3.2.2 | Re-bar | 1d | 2011-11-30 | 2011-12-01 | 665 | 2011-11-25 | 2011-11-26 | 0d? | 5d | 0d |  |
| 667 | 1.3.8.3.2.3 | Concrete | 1d | 2011-12-01 | 2011-12-02 | 666 | 2011-11-26 | 2011-11-27 | 0d? | 5d |  |  |

| ID | WBS | Task | Duration | Start | Finish | Predecessors | Baseline start | Baseline finish | Baseline duration | Total slack | Text1 |
| --- | --- | --- | --- | --- | --- | --- | --- | --- | --- | --- | --- |
| 668 | 1.3.8.4 | **Roof Slab** | 13d | 2011-12-07 | 2011-12-20 |  | 2011-12-02 | 2011-12-15 | 0d? | 0d |  |
| 669 | 1.3.8.4.1 | Form Work | 5d | 2011-12-07 | 2011-12-12 | 646, 657, 667 | 2011-12-02 | 2011-12-07 | 0d? | 0d |  |
| 670 | 1.3.8.4.2 | Re-bar | 4d | 2011-12-12 | 2011-12-16 | 669 | 2011-12-07 | 2011-12-11 | 0d? | 0d |  |
| 671 | 1.3.8.4.3 | MEP Work | 1d | 2011-12-16 | 2011-12-17 | 670 | 2011-12-11 | 2011-12-12 | 0d? | 0d |  |
| 672 | 1.3.8.4.4 | Inspection | 1d | 2011-12-17 | 2011-12-18 | 671 | 2011-12-12 | 2011-12-13 | 0d? | 0d |  |
| 673 | 1.3.8.4.5 | Concrete | 2d | 2011-12-18 | 2011-12-20 | 672 | 2011-12-13 | 2011-12-15 | 0d? | 0d |  |
| 674 | 1.3.9 | **8TH FLOOR** | 25d | 2011-12-20 | 2012-01-14 |  | 2011-12-15 | 2012-01-09 | 25d | 0d |  |
| 675 | 1.3.9.1 | **Column** | 12d | 2011-12-20 | 2012-01-01 |  | 2011-12-15 | 2011-12-27 | 0d? | 0d | nos. |
| 676 | 1.3.9.1.1 | **1ST Lift** | 6d | 2011-12-20 | 2011-12-26 |  | 2011-12-15 | 2011-12-21 | 0d? | 0d |  |
| 677 | 1.3.9.1.1.1 | Re-Bar Work | 1d | 2011-12-20 | 2011-12-21 | 673 | 2011-12-15 | 2011-12-16 | 0d? | 0d |  |
| 678 | 1.3.9.1.1.2 | Form Work | 1d | 2011-12-21 | 2011-12-22 | 677 | 2011-12-16 | 2011-12-17 | 0d? | 0d |  |
| 679 | 1.3.9.1.1.3 | Concrete | 1d | 2011-12-22 | 2011-12-23 | 678 | 2011-12-17 | 2011-12-18 | 0d? | 0d |  |
| 680 | 1.3.9.1.1.4 | De-shuttering | 1d | 2011-12-25 | 2011-12-26 | 679FS+2d | 2011-12-20 | 2011-12-21 | 0d? | 0d |  |
| 681 | 1.3.9.1.2 | **2nd Lift** | 6d | 2011-12-26 | 2012-01-01 |  | 2011-12-21 | 2011-12-27 | 0d? | 0d |  |
| 682 | 1.3.9.1.2.1 | Re-Bar Work | 1d | 2011-12-26 | 2011-12-27 | 680 | 2011-12-21 | 2011-12-22 | 0d? | 0d |  |
| 683 | 1.3.9.1.2.2 | Form Work | 1d | 2011-12-27 | 2011-12-28 | 682 | 2011-12-22 | 2011-12-23 | 0d? | 0d |  |
| 684 | 1.3.9.1.2.3 | Concrete | 1d | 2011-12-28 | 2011-12-29 | 683 | 2011-12-23 | 2011-12-24 | 0d? | 0d |  |
| 685 | 1.3.9.1.2.4 | De-shuttering | 1d | 2011-12-31 | 2012-01-01 | 684FS+2d | 2011-12-26 | 2011-12-27 | 0d? | 0d |  |
| 686 | 1.3.9.2 | **Shear Wall** | 12d | 2011-12-20 | 2012-01-01 |  | 2011-12-15 | 2011-12-27 | 0d? | 0d | nos. |
| 687 | 1.3.9.2.1 | **1st Lift** | 6d | 2011-12-20 | 2011-12-26 |  | 2011-12-15 | 2011-12-21 | 0d? | 0d |  |
| 688 | 1.3.9.2.1.1 | Re-Bar Work | 1d | 2011-12-20 | 2011-12-21 | 673 | 2011-12-15 | 2011-12-16 | 0d? | 0d |  |
| 689 | 1.3.9.2.1.2 | Form Work | 1d | 2011-12-21 | 2011-12-22 | 688 | 2011-12-16 | 2011-12-17 | 0d? | 0d |  |
| 690 | 1.3.9.2.1.3 | Concrete | 1d | 2011-12-22 | 2011-12-23 | 689 | 2011-12-17 | 2011-12-18 | 0d? | 0d |  |
| 691 | 1.3.9.2.1.4 | De-shuttering | 1d | 2011-12-25 | 2011-12-26 | 690FS+2d | 2011-12-20 | 2011-12-21 | 0d? | 0d |  |

| ID | WBS | Task | Duration | Start | Finish | Predecessors | Baseline start | Baseline finish | Baseline duration | Total slack | Free slack | Text1 |
| --- | --- | --- | --- | --- | --- | --- | --- | --- | --- | --- | --- | --- |
| 692 | 1.3.9.2.2 | **2nd Lift** | 6d | 2011-12-26 | 2012-01-01 |  | 2011-12-21 | 2011-12-27 | 0d? | 0d |  |  |
| 693 | 1.3.9.2.2.1 | Re-Bar Work | 1d | 2011-12-26 | 2011-12-27 | 691 | 2011-12-21 | 2011-12-22 | 0d? | 0d |  |  |
| 694 | 1.3.9.2.2.2 | Form Work | 1d | 2011-12-27 | 2011-12-28 | 693 | 2011-12-22 | 2011-12-23 | 0d? | 0d |  |  |
| 695 | 1.3.9.2.2.3 | Concrete | 1d | 2011-12-28 | 2011-12-29 | 694 | 2011-12-23 | 2011-12-24 | 0d? | 0d |  |  |
| 696 | 1.3.9.2.2.4 | De-shuttering | 1d | 2011-12-31 | 2012-01-01 | 695FS+2d | 2011-12-26 | 2011-12-27 | 0d? | 0d |  |  |
| 697 | 1.3.9.3 | **Stair - 1 & 2** | 7d | 2011-12-20 | 2011-12-27 |  | 2011-12-15 | 2011-12-22 | 0d? | 5d |  |  |
| 698 | 1.3.9.3.1 | **1st Flight** | 4d | 2011-12-20 | 2011-12-24 |  | 2011-12-15 | 2011-12-19 | 0d? | 5d |  |  |
| 699 | 1.3.9.3.1.1 | Brick Work | 1d | 2011-12-20 | 2011-12-21 | 673 | 2011-12-15 | 2011-12-16 | 0d? | 5d | 0d |  |
| 700 | 1.3.9.3.1.2 | Form Work | 1d | 2011-12-21 | 2011-12-22 | 699 | 2011-12-16 | 2011-12-17 | 0d? | 5d | 0d |  |
| 701 | 1.3.9.3.1.3 | Re-bar Work | 1d | 2011-12-22 | 2011-12-23 | 700 | 2011-12-17 | 2011-12-18 | 0d? | 5d | 0d |  |
| 702 | 1.3.9.3.1.4 | Concrete | 1d | 2011-12-23 | 2011-12-24 | 701 | 2011-12-18 | 2011-12-19 | 0d? | 5d | 0d |  |
| 703 | 1.3.9.3.2 | **2nd Flight** | 3d | 2011-12-24 | 2011-12-27 |  | 2011-12-19 | 2011-12-22 | 0d? | 5d |  |  |
| 704 | 1.3.9.3.2.1 | Form Work | 1d | 2011-12-24 | 2011-12-25 | 702 | 2011-12-19 | 2011-12-20 | 0d? | 5d | 0d |  |
| 705 | 1.3.9.3.2.2 | Re-bar | 1d | 2011-12-25 | 2011-12-26 | 704 | 2011-12-20 | 2011-12-21 | 0d? | 5d | 0d |  |
| 706 | 1.3.9.3.2.3 | Concrete | 1d | 2011-12-26 | 2011-12-27 | 705 | 2011-12-21 | 2011-12-22 | 0d? | 5d |  |  |
| 707 | 1.3.9.4 | **Roof Slab** | 13d | 2012-01-01 | 2012-01-14 |  | 2011-12-27 | 2012-01-09 | 0d? | 0d |  |  |
| 708 | 1.3.9.4.1 | Form Work | 5d | 2012-01-01 | 2012-01-06 | 685, 696, 706 | 2011-12-27 | 2012-01-01 | 0d? | 0d |  |  |
| 709 | 1.3.9.4.2 | Re-bar | 4d | 2012-01-06 | 2012-01-10 | 708 | 2012-01-01 | 2012-01-05 | 0d? | 0d |  |  |
| 710 | 1.3.9.4.3 | MEP Work | 1d | 2012-01-10 | 2012-01-11 | 709 | 2012-01-05 | 2012-01-06 | 0d? | 0d |  |  |
| 711 | 1.3.9.4.4 | Inspection | 1d | 2012-01-11 | 2012-01-12 | 710 | 2012-01-06 | 2012-01-07 | 0d? | 0d |  |  |
| 712 | 1.3.9.4.5 | Concrete | 2d | 2012-01-12 | 2012-01-14 | 711 | 2012-01-07 | 2012-01-09 | 0d? | 0d |  |  |
| 713 | 1.3.10 | **9TH FLOOR** | 25d | 2012-01-14 | 2012-02-08 |  | 2012-01-09 | 2012-02-03 | 25d | 0d |  |  |
| 714 | 1.3.10.1 | **Column** | 12d | 2012-01-14 | 2012-01-26 |  | 2012-01-09 | 2012-01-21 | 0d? | 0d |  | nos. |
| 715 | 1.3.10.1.1 | **1ST Lift** | 6d | 2012-01-14 | 2012-01-20 |  | 2012-01-09 | 2012-01-15 | 0d? | 0d |  |  |
| 716 | 1.3.10.1.1.1 | Re-Bar Work | 1d | 2012-01-14 | 2012-01-15 | 712 | 2012-01-09 | 2012-01-10 | 0d? | 0d |  |  |
| 717 | 1.3.10.1.1.2 | Form Work | 1d | 2012-01-15 | 2012-01-16 | 716 | 2012-01-10 | 2012-01-11 | 0d? | 0d |  |  |
| 718 | 1.3.10.1.1.3 | Concrete | 1d | 2012-01-16 | 2012-01-17 | 717 | 2012-01-11 | 2012-01-12 | 0d? | 0d |  |  |
| 719 | 1.3.10.1.1.4 | De-shuttering | 1d | 2012-01-19 | 2012-01-20 | 718FS+2d | 2012-01-14 | 2012-01-15 | 0d? | 0d |  |  |

| ID | WBS | Task | Duration | Start | Finish | Predecessors | Baseline start | Baseline finish | Baseline duration | Total slack | Free slack | Text1 |
| --- | --- | --- | --- | --- | --- | --- | --- | --- | --- | --- | --- | --- |
| 720 | 1.3.10.1.2 | **2nd Lift** | 6d | 2012-01-20 | 2012-01-26 |  | 2012-01-15 | 2012-01-21 | 0d? | 0d |  |  |
| 721 | 1.3.10.1.2.1 | Re-Bar Work | 1d | 2012-01-20 | 2012-01-21 | 719 | 2012-01-15 | 2012-01-16 | 0d? | 0d |  |  |
| 722 | 1.3.10.1.2.2 | Form Work | 1d | 2012-01-21 | 2012-01-22 | 721 | 2012-01-16 | 2012-01-17 | 0d? | 0d |  |  |
| 723 | 1.3.10.1.2.3 | Concrete | 1d | 2012-01-22 | 2012-01-23 | 722 | 2012-01-17 | 2012-01-18 | 0d? | 0d |  |  |
| 724 | 1.3.10.1.2.4 | De-shuttering | 1d | 2012-01-25 | 2012-01-26 | 723FS+2d | 2012-01-20 | 2012-01-21 | 0d? | 0d |  |  |
| 725 | 1.3.10.2 | **Shear Wall** | 12d | 2012-01-14 | 2012-01-26 |  | 2012-01-09 | 2012-01-21 | 0d? | 0d |  | nos. |
| 726 | 1.3.10.2.1 | **1st Lift** | 6d | 2012-01-14 | 2012-01-20 |  | 2012-01-09 | 2012-01-15 | 0d? | 0d |  |  |
| 727 | 1.3.10.2.1.1 | Re-Bar Work | 1d | 2012-01-14 | 2012-01-15 | 712 | 2012-01-09 | 2012-01-10 | 0d? | 0d |  |  |
| 728 | 1.3.10.2.1.2 | Form Work | 1d | 2012-01-15 | 2012-01-16 | 727 | 2012-01-10 | 2012-01-11 | 0d? | 0d |  |  |
| 729 | 1.3.10.2.1.3 | Concrete | 1d | 2012-01-16 | 2012-01-17 | 728 | 2012-01-11 | 2012-01-12 | 0d? | 0d |  |  |
| 730 | 1.3.10.2.1.4 | De-shuttering | 1d | 2012-01-19 | 2012-01-20 | 729FS+2d | 2012-01-14 | 2012-01-15 | 0d? | 0d |  |  |
| 731 | 1.3.10.2.2 | **2nd Lift** | 6d | 2012-01-20 | 2012-01-26 |  | 2012-01-15 | 2012-01-21 | 0d? | 0d |  |  |
| 732 | 1.3.10.2.2.1 | Re-Bar Work | 1d | 2012-01-20 | 2012-01-21 | 730 | 2012-01-15 | 2012-01-16 | 0d? | 0d |  |  |
| 733 | 1.3.10.2.2.2 | Form Work | 1d | 2012-01-21 | 2012-01-22 | 732 | 2012-01-16 | 2012-01-17 | 0d? | 0d |  |  |
| 734 | 1.3.10.2.2.3 | Concrete | 1d | 2012-01-22 | 2012-01-23 | 733 | 2012-01-17 | 2012-01-18 | 0d? | 0d |  |  |
| 735 | 1.3.10.2.2.4 | De-shuttering | 1d | 2012-01-25 | 2012-01-26 | 734FS+2d | 2012-01-20 | 2012-01-21 | 0d? | 0d |  |  |
| 736 | 1.3.10.3 | **Stair - 1 & 2** | 7d | 2012-01-14 | 2012-01-21 |  | 2012-01-09 | 2012-01-16 | 0d? | 5d |  |  |
| 737 | 1.3.10.3.1 | **1st Flight** | 4d | 2012-01-14 | 2012-01-18 |  | 2012-01-09 | 2012-01-13 | 0d? | 5d |  |  |
| 738 | 1.3.10.3.1.1 | Brick Work | 1d | 2012-01-14 | 2012-01-15 | 712 | 2012-01-09 | 2012-01-10 | 0d? | 5d | 0d |  |
| 739 | 1.3.10.3.1.2 | Form Work | 1d | 2012-01-15 | 2012-01-16 | 738 | 2012-01-10 | 2012-01-11 | 0d? | 5d | 0d |  |
| 740 | 1.3.10.3.1.3 | Re-bar Work | 1d | 2012-01-16 | 2012-01-17 | 739 | 2012-01-11 | 2012-01-12 | 0d? | 5d | 0d |  |
| 741 | 1.3.10.3.1.4 | Concrete | 1d | 2012-01-17 | 2012-01-18 | 740 | 2012-01-12 | 2012-01-13 | 0d? | 5d | 0d |  |
| 742 | 1.3.10.3.2 | **2nd Flight** | 3d | 2012-01-18 | 2012-01-21 |  | 2012-01-13 | 2012-01-16 | 0d? | 5d |  |  |
| 743 | 1.3.10.3.2.1 | Form Work | 1d | 2012-01-18 | 2012-01-19 | 741 | 2012-01-13 | 2012-01-14 | 0d? | 5d | 0d |  |
| 744 | 1.3.10.3.2.2 | Re-bar | 1d | 2012-01-19 | 2012-01-20 | 743 | 2012-01-14 | 2012-01-15 | 0d? | 5d | 0d |  |
| 745 | 1.3.10.3.2.3 | Concrete | 1d | 2012-01-20 | 2012-01-21 | 744 | 2012-01-15 | 2012-01-16 | 0d? | 5d |  |  |

| ID | WBS | Task | Duration | Start | Finish | Predecessors | Baseline start | Baseline finish | Baseline duration | Total slack | Text1 |
| --- | --- | --- | --- | --- | --- | --- | --- | --- | --- | --- | --- |
| 746 | 1.3.10.4 | **Roof Slab** | 13d | 2012-01-26 | 2012-02-08 |  | 2012-01-21 | 2012-02-03 | 0d? | 0d |  |
| 747 | 1.3.10.4.1 | Form Work | 5d | 2012-01-26 | 2012-01-31 | 724, 735, 745 | 2012-01-21 | 2012-01-26 | 0d? | 0d |  |
| 748 | 1.3.10.4.2 | Re-bar | 4d | 2012-01-31 | 2012-02-04 | 747 | 2012-01-26 | 2012-01-30 | 0d? | 0d |  |
| 749 | 1.3.10.4.3 | MEP Work | 1d | 2012-02-04 | 2012-02-05 | 748 | 2012-01-30 | 2012-01-31 | 0d? | 0d |  |
| 750 | 1.3.10.4.4 | Inspection | 1d | 2012-02-05 | 2012-02-06 | 749 | 2012-01-31 | 2012-02-01 | 0d? | 0d |  |
| 751 | 1.3.10.4.5 | Concrete | 2d | 2012-02-06 | 2012-02-08 | 750 | 2012-02-01 | 2012-02-03 | 0d? | 0d |  |
| 752 | 1.3.11 | **10TH FLOOR** | 25d | 2012-02-08 | 2012-03-04 |  | 2012-02-03 | 2012-02-28 | 25d | 0d |  |
| 753 | 1.3.11.1 | **Column** | 12d | 2012-02-08 | 2012-02-20 |  | 2012-02-03 | 2012-02-15 | 0d? | 0d | nos. |
| 754 | 1.3.11.1.1 | **1ST Lift** | 6d | 2012-02-08 | 2012-02-14 |  | 2012-02-03 | 2012-02-09 | 0d? | 0d |  |
| 755 | 1.3.11.1.1.1 | Re-Bar Work | 1d | 2012-02-08 | 2012-02-09 | 751 | 2012-02-03 | 2012-02-04 | 0d? | 0d |  |
| 756 | 1.3.11.1.1.2 | Form Work | 1d | 2012-02-09 | 2012-02-10 | 755 | 2012-02-04 | 2012-02-05 | 0d? | 0d |  |
| 757 | 1.3.11.1.1.3 | Concrete | 1d | 2012-02-10 | 2012-02-11 | 756 | 2012-02-05 | 2012-02-06 | 0d? | 0d |  |
| 758 | 1.3.11.1.1.4 | De-shuttering | 1d | 2012-02-13 | 2012-02-14 | 757FS+2d | 2012-02-08 | 2012-02-09 | 0d? | 0d |  |
| 759 | 1.3.11.1.2 | **2nd Lift** | 6d | 2012-02-14 | 2012-02-20 |  | 2012-02-09 | 2012-02-15 | 0d? | 0d |  |
| 760 | 1.3.11.1.2.1 | Re-Bar Work | 1d | 2012-02-14 | 2012-02-15 | 758 | 2012-02-09 | 2012-02-10 | 0d? | 0d |  |
| 761 | 1.3.11.1.2.2 | Form Work | 1d | 2012-02-15 | 2012-02-16 | 760 | 2012-02-10 | 2012-02-11 | 0d? | 0d |  |
| 762 | 1.3.11.1.2.3 | Concrete | 1d | 2012-02-16 | 2012-02-17 | 761 | 2012-02-11 | 2012-02-12 | 0d? | 0d |  |
| 763 | 1.3.11.1.2.4 | De-shuttering | 1d | 2012-02-19 | 2012-02-20 | 762FS+2d | 2012-02-14 | 2012-02-15 | 0d? | 0d |  |
| 764 | 1.3.11.2 | **Shear Wall** | 12d | 2012-02-08 | 2012-02-20 |  | 2012-02-03 | 2012-02-15 | 0d? | 0d | nos. |
| 765 | 1.3.11.2.1 | **1st Lift** | 6d | 2012-02-08 | 2012-02-14 |  | 2012-02-03 | 2012-02-09 | 0d? | 0d |  |
| 766 | 1.3.11.2.1.1 | Re-Bar Work | 1d | 2012-02-08 | 2012-02-09 | 751 | 2012-02-03 | 2012-02-04 | 0d? | 0d |  |
| 767 | 1.3.11.2.1.2 | Form Work | 1d | 2012-02-09 | 2012-02-10 | 766 | 2012-02-04 | 2012-02-05 | 0d? | 0d |  |
| 768 | 1.3.11.2.1.3 | Concrete | 1d | 2012-02-10 | 2012-02-11 | 767 | 2012-02-05 | 2012-02-06 | 0d? | 0d |  |
| 769 | 1.3.11.2.1.4 | De-shuttering | 1d | 2012-02-13 | 2012-02-14 | 768FS+2d | 2012-02-08 | 2012-02-09 | 0d? | 0d |  |

| ID | WBS | Task | Duration | Start | Finish | Predecessors | Baseline start | Baseline finish | Baseline duration | Total slack | Free slack | Text1 |
| --- | --- | --- | --- | --- | --- | --- | --- | --- | --- | --- | --- | --- |
| 770 | 1.3.11.2.2 | **2nd Lift** | 6d | 2012-02-14 | 2012-02-20 |  | 2012-02-09 | 2012-02-15 | 0d? | 0d |  |  |
| 771 | 1.3.11.2.2.1 | Re-Bar Work | 1d | 2012-02-14 | 2012-02-15 | 769 | 2012-02-09 | 2012-02-10 | 0d? | 0d |  |  |
| 772 | 1.3.11.2.2.2 | Form Work | 1d | 2012-02-15 | 2012-02-16 | 771 | 2012-02-10 | 2012-02-11 | 0d? | 0d |  |  |
| 773 | 1.3.11.2.2.3 | Concrete | 1d | 2012-02-16 | 2012-02-17 | 772 | 2012-02-11 | 2012-02-12 | 0d? | 0d |  |  |
| 774 | 1.3.11.2.2.4 | De-shuttering | 1d | 2012-02-19 | 2012-02-20 | 773FS+2d | 2012-02-14 | 2012-02-15 | 0d? | 0d |  |  |
| 775 | 1.3.11.3 | **Stair - 1 & 2** | 7d | 2012-02-08 | 2012-02-15 |  | 2012-02-03 | 2012-02-10 | 0d? | 5d |  |  |
| 776 | 1.3.11.3.1 | **1st Flight** | 4d | 2012-02-08 | 2012-02-12 |  | 2012-02-03 | 2012-02-07 | 0d? | 5d |  |  |
| 777 | 1.3.11.3.1.1 | Brick Work | 1d | 2012-02-08 | 2012-02-09 | 751 | 2012-02-03 | 2012-02-04 | 0d? | 5d | 0d |  |
| 778 | 1.3.11.3.1.2 | Form Work | 1d | 2012-02-09 | 2012-02-10 | 777 | 2012-02-04 | 2012-02-05 | 0d? | 5d | 0d |  |
| 779 | 1.3.11.3.1.3 | Re-bar Work | 1d | 2012-02-10 | 2012-02-11 | 778 | 2012-02-05 | 2012-02-06 | 0d? | 5d | 0d |  |
| 780 | 1.3.11.3.1.4 | Concrete | 1d | 2012-02-11 | 2012-02-12 | 779 | 2012-02-06 | 2012-02-07 | 0d? | 5d | 0d |  |
| 781 | 1.3.11.3.2 | **2nd Flight** | 3d | 2012-02-12 | 2012-02-15 |  | 2012-02-07 | 2012-02-10 | 0d? | 5d |  |  |
| 782 | 1.3.11.3.2.1 | Form Work | 1d | 2012-02-12 | 2012-02-13 | 780 | 2012-02-07 | 2012-02-08 | 0d? | 5d | 0d |  |
| 783 | 1.3.11.3.2.2 | Re-bar | 1d | 2012-02-13 | 2012-02-14 | 782 | 2012-02-08 | 2012-02-09 | 0d? | 5d | 0d |  |
| 784 | 1.3.11.3.2.3 | Concrete | 1d | 2012-02-14 | 2012-02-15 | 783 | 2012-02-09 | 2012-02-10 | 0d? | 5d |  |  |
| 785 | 1.3.11.4 | **Roof Slab** | 13d | 2012-02-20 | 2012-03-04 |  | 2012-02-15 | 2012-02-28 | 0d? | 0d |  |  |
| 786 | 1.3.11.4.1 | Form Work | 5d | 2012-02-20 | 2012-02-25 | 763, 774, 784 | 2012-02-15 | 2012-02-20 | 0d? | 0d |  |  |
| 787 | 1.3.11.4.2 | Re-bar | 4d | 2012-02-25 | 2012-02-29 | 786 | 2012-02-20 | 2012-02-24 | 0d? | 0d |  |  |
| 788 | 1.3.11.4.3 | MEP Work | 1d | 2012-02-29 | 2012-03-01 | 787 | 2012-02-24 | 2012-02-25 | 0d? | 0d |  |  |
| 789 | 1.3.11.4.4 | Inspection | 1d | 2012-03-01 | 2012-03-02 | 788 | 2012-02-25 | 2012-02-26 | 0d? | 0d |  |  |
| 790 | 1.3.11.4.5 | Concrete | 2d | 2012-03-02 | 2012-03-04 | 789 | 2012-02-26 | 2012-02-28 | 0d? | 0d |  |  |
| 791 | 1.3.12 | **11TH FLOOR** | 25d | 2012-03-04 | 2012-03-29 |  | 2012-02-28 | 2012-03-24 | 25d | 0d |  |  |
| 792 | 1.3.12.1 | **Column** | 12d | 2012-03-04 | 2012-03-16 |  | 2012-02-28 | 2012-03-11 | 0d? | 0d |  | nos. |
| 793 | 1.3.12.1.1 | **1ST Lift** | 6d | 2012-03-04 | 2012-03-10 |  | 2012-02-28 | 2012-03-05 | 0d? | 0d |  |  |
| 794 | 1.3.12.1.1.1 | Re-Bar Work | 1d | 2012-03-04 | 2012-03-05 | 790 | 2012-02-28 | 2012-02-29 | 0d? | 0d |  |  |
| 795 | 1.3.12.1.1.2 | Form Work | 1d | 2012-03-05 | 2012-03-06 | 794 | 2012-02-29 | 2012-03-01 | 0d? | 0d |  |  |
| 796 | 1.3.12.1.1.3 | Concrete | 1d | 2012-03-06 | 2012-03-07 | 795 | 2012-03-01 | 2012-03-02 | 0d? | 0d |  |  |
| 797 | 1.3.12.1.1.4 | De-shuttering | 1d | 2012-03-09 | 2012-03-10 | 796FS+2d | 2012-03-04 | 2012-03-05 | 0d? | 0d |  |  |

| ID | WBS | Task | Duration | Start | Finish | Predecessors | Baseline start | Baseline finish | Baseline duration | Total slack | Free slack | Text1 |
| --- | --- | --- | --- | --- | --- | --- | --- | --- | --- | --- | --- | --- |
| 798 | 1.3.12.1.2 | **2nd Lift** | 6d | 2012-03-10 | 2012-03-16 |  | 2012-03-05 | 2012-03-11 | 0d? | 0d |  |  |
| 799 | 1.3.12.1.2.1 | Re-Bar Work | 1d | 2012-03-10 | 2012-03-11 | 797 | 2012-03-05 | 2012-03-06 | 0d? | 0d |  |  |
| 800 | 1.3.12.1.2.2 | Form Work | 1d | 2012-03-11 | 2012-03-12 | 799 | 2012-03-06 | 2012-03-07 | 0d? | 0d |  |  |
| 801 | 1.3.12.1.2.3 | Concrete | 1d | 2012-03-12 | 2012-03-13 | 800 | 2012-03-07 | 2012-03-08 | 0d? | 0d |  |  |
| 802 | 1.3.12.1.2.4 | De-shuttering | 1d | 2012-03-15 | 2012-03-16 | 801FS+2d | 2012-03-10 | 2012-03-11 | 0d? | 0d |  |  |
| 803 | 1.3.12.2 | **Shear Wall** | 12d | 2012-03-04 | 2012-03-16 |  | 2012-02-28 | 2012-03-11 | 0d? | 0d |  | nos. |
| 804 | 1.3.12.2.1 | **1st Lift** | 6d | 2012-03-04 | 2012-03-10 |  | 2012-02-28 | 2012-03-05 | 0d? | 0d |  |  |
| 805 | 1.3.12.2.1.1 | Re-Bar Work | 1d | 2012-03-04 | 2012-03-05 | 790 | 2012-02-28 | 2012-02-29 | 0d? | 0d |  |  |
| 806 | 1.3.12.2.1.2 | Form Work | 1d | 2012-03-05 | 2012-03-06 | 805 | 2012-02-29 | 2012-03-01 | 0d? | 0d |  |  |
| 807 | 1.3.12.2.1.3 | Concrete | 1d | 2012-03-06 | 2012-03-07 | 806 | 2012-03-01 | 2012-03-02 | 0d? | 0d |  |  |
| 808 | 1.3.12.2.1.4 | De-shuttering | 1d | 2012-03-09 | 2012-03-10 | 807FS+2d | 2012-03-04 | 2012-03-05 | 0d? | 0d |  |  |
| 809 | 1.3.12.2.2 | **2nd Lift** | 6d | 2012-03-10 | 2012-03-16 |  | 2012-03-05 | 2012-03-11 | 0d? | 0d |  |  |
| 810 | 1.3.12.2.2.1 | Re-Bar Work | 1d | 2012-03-10 | 2012-03-11 | 808 | 2012-03-05 | 2012-03-06 | 0d? | 0d |  |  |
| 811 | 1.3.12.2.2.2 | Form Work | 1d | 2012-03-11 | 2012-03-12 | 810 | 2012-03-06 | 2012-03-07 | 0d? | 0d |  |  |
| 812 | 1.3.12.2.2.3 | Concrete | 1d | 2012-03-12 | 2012-03-13 | 811 | 2012-03-07 | 2012-03-08 | 0d? | 0d |  |  |
| 813 | 1.3.12.2.2.4 | De-shuttering | 1d | 2012-03-15 | 2012-03-16 | 812FS+2d | 2012-03-10 | 2012-03-11 | 0d? | 0d |  |  |
| 814 | 1.3.12.3 | **Stair - 1 & 2** | 7d | 2012-03-04 | 2012-03-11 |  | 2012-02-28 | 2012-03-06 | 0d? | 5d |  |  |
| 815 | 1.3.12.3.1 | **1st Flight** | 4d | 2012-03-04 | 2012-03-08 |  | 2012-02-28 | 2012-03-03 | 0d? | 5d |  |  |
| 816 | 1.3.12.3.1.1 | Brick Work | 1d | 2012-03-04 | 2012-03-05 | 790 | 2012-02-28 | 2012-02-29 | 0d? | 5d | 0d |  |
| 817 | 1.3.12.3.1.2 | Form Work | 1d | 2012-03-05 | 2012-03-06 | 816 | 2012-02-29 | 2012-03-01 | 0d? | 5d | 0d |  |
| 818 | 1.3.12.3.1.3 | Re-bar Work | 1d | 2012-03-06 | 2012-03-07 | 817 | 2012-03-01 | 2012-03-02 | 0d? | 5d | 0d |  |
| 819 | 1.3.12.3.1.4 | Concrete | 1d | 2012-03-07 | 2012-03-08 | 818 | 2012-03-02 | 2012-03-03 | 0d? | 5d | 0d |  |
| 820 | 1.3.12.3.2 | **2nd Flight** | 3d | 2012-03-08 | 2012-03-11 |  | 2012-03-03 | 2012-03-06 | 0d? | 5d |  |  |
| 821 | 1.3.12.3.2.1 | Form Work | 1d | 2012-03-08 | 2012-03-09 | 819 | 2012-03-03 | 2012-03-04 | 0d? | 5d | 0d |  |
| 822 | 1.3.12.3.2.2 | Re-bar | 1d | 2012-03-09 | 2012-03-10 | 821 | 2012-03-04 | 2012-03-05 | 0d? | 5d | 0d |  |
| 823 | 1.3.12.3.2.3 | Concrete | 1d | 2012-03-10 | 2012-03-11 | 822 | 2012-03-05 | 2012-03-06 | 0d? | 5d |  |  |

| ID | WBS | Task | Duration | Start | Finish | Predecessors | Baseline start | Baseline finish | Baseline duration | Total slack | Text1 |
| --- | --- | --- | --- | --- | --- | --- | --- | --- | --- | --- | --- |
| 824 | 1.3.12.4 | **Roof Slab** | 13d | 2012-03-16 | 2012-03-29 |  | 2012-03-11 | 2012-03-24 | 0d? | 0d |  |
| 825 | 1.3.12.4.1 | Form Work | 5d | 2012-03-16 | 2012-03-21 | 802, 813, 823 | 2012-03-11 | 2012-03-16 | 0d? | 0d |  |
| 826 | 1.3.12.4.2 | Re-bar | 4d | 2012-03-21 | 2012-03-25 | 825 | 2012-03-16 | 2012-03-20 | 0d? | 0d |  |
| 827 | 1.3.12.4.3 | MEP Work | 1d | 2012-03-25 | 2012-03-26 | 826 | 2012-03-20 | 2012-03-21 | 0d? | 0d |  |
| 828 | 1.3.12.4.4 | Inspection | 1d | 2012-03-26 | 2012-03-27 | 827 | 2012-03-21 | 2012-03-22 | 0d? | 0d |  |
| 829 | 1.3.12.4.5 | Concrete | 2d | 2012-03-27 | 2012-03-29 | 828 | 2012-03-22 | 2012-03-24 | 0d? | 0d |  |
| 830 | 1.3.13 | **12TH FLOOR** | 25d | 2012-03-29 | 2012-04-23 |  | 2012-03-24 | 2012-04-18 | 25d | 0d |  |
| 831 | 1.3.13.1 | **Column** | 12d | 2012-03-29 | 2012-04-10 |  | 2012-03-24 | 2012-04-05 | 0d? | 0d | nos. |
| 832 | 1.3.13.1.1 | **1ST Lift** | 6d | 2012-03-29 | 2012-04-04 |  | 2012-03-24 | 2012-03-30 | 0d? | 0d |  |
| 833 | 1.3.13.1.1.1 | Re-Bar Work | 1d | 2012-03-29 | 2012-03-30 | 829 | 2012-03-24 | 2012-03-25 | 0d? | 0d |  |
| 834 | 1.3.13.1.1.2 | Form Work | 1d | 2012-03-30 | 2012-03-31 | 833 | 2012-03-25 | 2012-03-26 | 0d? | 0d |  |
| 835 | 1.3.13.1.1.3 | Concrete | 1d | 2012-03-31 | 2012-04-01 | 834 | 2012-03-26 | 2012-03-27 | 0d? | 0d |  |
| 836 | 1.3.13.1.1.4 | De-shuttering | 1d | 2012-04-03 | 2012-04-04 | 835FS+2d | 2012-03-29 | 2012-03-30 | 0d? | 0d |  |
| 837 | 1.3.13.1.2 | **2nd Lift** | 6d | 2012-04-04 | 2012-04-10 |  | 2012-03-30 | 2012-04-05 | 0d? | 0d |  |
| 838 | 1.3.13.1.2.1 | Re-Bar Work | 1d | 2012-04-04 | 2012-04-05 | 836 | 2012-03-30 | 2012-03-31 | 0d? | 0d |  |
| 839 | 1.3.13.1.2.2 | Form Work | 1d | 2012-04-05 | 2012-04-06 | 838 | 2012-03-31 | 2012-04-01 | 0d? | 0d |  |
| 840 | 1.3.13.1.2.3 | Concrete | 1d | 2012-04-06 | 2012-04-07 | 839 | 2012-04-01 | 2012-04-02 | 0d? | 0d |  |
| 841 | 1.3.13.1.2.4 | De-shuttering | 1d | 2012-04-09 | 2012-04-10 | 840FS+2d | 2012-04-04 | 2012-04-05 | 0d? | 0d |  |
| 842 | 1.3.13.2 | **Shear Wall** | 12d | 2012-03-29 | 2012-04-10 |  | 2012-03-24 | 2012-04-05 | 0d? | 0d | nos. |
| 843 | 1.3.13.2.1 | **1st Lift** | 6d | 2012-03-29 | 2012-04-04 |  | 2012-03-24 | 2012-03-30 | 0d? | 0d |  |
| 844 | 1.3.13.2.1.1 | Re-Bar Work | 1d | 2012-03-29 | 2012-03-30 | 829 | 2012-03-24 | 2012-03-25 | 0d? | 0d |  |
| 845 | 1.3.13.2.1.2 | Form Work | 1d | 2012-03-30 | 2012-03-31 | 844 | 2012-03-25 | 2012-03-26 | 0d? | 0d |  |
| 846 | 1.3.13.2.1.3 | Concrete | 1d | 2012-03-31 | 2012-04-01 | 845 | 2012-03-26 | 2012-03-27 | 0d? | 0d |  |
| 847 | 1.3.13.2.1.4 | De-shuttering | 1d | 2012-04-03 | 2012-04-04 | 846FS+2d | 2012-03-29 | 2012-03-30 | 0d? | 0d |  |

| ID | WBS | Task | Duration | Start | Finish | Predecessors | Baseline start | Baseline finish | Baseline duration | Total slack | Free slack | Text1 |
| --- | --- | --- | --- | --- | --- | --- | --- | --- | --- | --- | --- | --- |
| 848 | 1.3.13.2.2 | **2nd Lift** | 6d | 2012-04-04 | 2012-04-10 |  | 2012-03-30 | 2012-04-05 | 0d? | 0d |  |  |
| 849 | 1.3.13.2.2.1 | Re-Bar Work | 1d | 2012-04-04 | 2012-04-05 | 847 | 2012-03-30 | 2012-03-31 | 0d? | 0d |  |  |
| 850 | 1.3.13.2.2.2 | Form Work | 1d | 2012-04-05 | 2012-04-06 | 849 | 2012-03-31 | 2012-04-01 | 0d? | 0d |  |  |
| 851 | 1.3.13.2.2.3 | Concrete | 1d | 2012-04-06 | 2012-04-07 | 850 | 2012-04-01 | 2012-04-02 | 0d? | 0d |  |  |
| 852 | 1.3.13.2.2.4 | De-shuttering | 1d | 2012-04-09 | 2012-04-10 | 851FS+2d | 2012-04-04 | 2012-04-05 | 0d? | 0d |  |  |
| 853 | 1.3.13.3 | **Stair - 1 & 2** | 7d | 2012-03-29 | 2012-04-05 |  | 2012-03-24 | 2012-03-31 | 0d? | 5d |  |  |
| 854 | 1.3.13.3.1 | **1st Flight** | 4d | 2012-03-29 | 2012-04-02 |  | 2012-03-24 | 2012-03-28 | 0d? | 5d |  |  |
| 855 | 1.3.13.3.1.1 | Brick Work | 1d | 2012-03-29 | 2012-03-30 | 829 | 2012-03-24 | 2012-03-25 | 0d? | 5d | 0d |  |
| 856 | 1.3.13.3.1.2 | Form Work | 1d | 2012-03-30 | 2012-03-31 | 855 | 2012-03-25 | 2012-03-26 | 0d? | 5d | 0d |  |
| 857 | 1.3.13.3.1.3 | Re-bar Work | 1d | 2012-03-31 | 2012-04-01 | 856 | 2012-03-26 | 2012-03-27 | 0d? | 5d | 0d |  |
| 858 | 1.3.13.3.1.4 | Concrete | 1d | 2012-04-01 | 2012-04-02 | 857 | 2012-03-27 | 2012-03-28 | 0d? | 5d | 0d |  |
| 859 | 1.3.13.3.2 | **2nd Flight** | 3d | 2012-04-02 | 2012-04-05 |  | 2012-03-28 | 2012-03-31 | 0d? | 5d |  |  |
| 860 | 1.3.13.3.2.1 | Form Work | 1d | 2012-04-02 | 2012-04-03 | 858 | 2012-03-28 | 2012-03-29 | 0d? | 5d | 0d |  |
| 861 | 1.3.13.3.2.2 | Re-bar | 1d | 2012-04-03 | 2012-04-04 | 860 | 2012-03-29 | 2012-03-30 | 0d? | 5d | 0d |  |
| 862 | 1.3.13.3.2.3 | Concrete | 1d | 2012-04-04 | 2012-04-05 | 861 | 2012-03-30 | 2012-03-31 | 0d? | 5d |  |  |
| 863 | 1.3.13.4 | **Roof Slab** | 13d | 2012-04-10 | 2012-04-23 |  | 2012-04-05 | 2012-04-18 | 0d? | 0d |  |  |
| 864 | 1.3.13.4.1 | Form Work | 5d | 2012-04-10 | 2012-04-15 | 841, 852, 862 | 2012-04-05 | 2012-04-10 | 0d? | 0d |  |  |
| 865 | 1.3.13.4.2 | Re-bar | 4d | 2012-04-15 | 2012-04-19 | 864 | 2012-04-10 | 2012-04-14 | 0d? | 0d |  |  |
| 866 | 1.3.13.4.3 | MEP Work | 1d | 2012-04-19 | 2012-04-20 | 865 | 2012-04-14 | 2012-04-15 | 0d? | 0d |  |  |
| 867 | 1.3.13.4.4 | Inspection | 1d | 2012-04-20 | 2012-04-21 | 866 | 2012-04-15 | 2012-04-16 | 0d? | 0d |  |  |
| 868 | 1.3.13.4.5 | Concrete | 2d | 2012-04-21 | 2012-04-23 | 867 | 2012-04-16 | 2012-04-18 | 0d? | 0d |  |  |
| 869 | 1.3.14 | **13TH FLOOR** | 25d | 2012-04-23 | 2012-05-18 |  | 2012-04-18 | 2012-05-13 | 25d | 0d |  |  |
| 870 | 1.3.14.1 | **Column** | 12d | 2012-04-23 | 2012-05-05 |  | 2012-04-18 | 2012-04-30 | 0d? | 0d |  | nos. |
| 871 | 1.3.14.1.1 | **1ST Lift** | 6d | 2012-04-23 | 2012-04-29 |  | 2012-04-18 | 2012-04-24 | 0d? | 0d |  |  |
| 872 | 1.3.14.1.1.1 | Re-Bar Work | 1d | 2012-04-23 | 2012-04-24 | 868 | 2012-04-18 | 2012-04-19 | 0d? | 0d |  |  |
| 873 | 1.3.14.1.1.2 | Form Work | 1d | 2012-04-24 | 2012-04-25 | 872 | 2012-04-19 | 2012-04-20 | 0d? | 0d |  |  |
| 874 | 1.3.14.1.1.3 | Concrete | 1d | 2012-04-25 | 2012-04-26 | 873 | 2012-04-20 | 2012-04-21 | 0d? | 0d |  |  |
| 875 | 1.3.14.1.1.4 | De-shuttering | 1d | 2012-04-28 | 2012-04-29 | 874FS+2d | 2012-04-23 | 2012-04-24 | 0d? | 0d |  |  |

| ID | WBS | Task | Duration | Start | Finish | Predecessors | Baseline start | Baseline finish | Baseline duration | Total slack | Free slack | Text1 |
| --- | --- | --- | --- | --- | --- | --- | --- | --- | --- | --- | --- | --- |
| 876 | 1.3.14.1.2 | **2nd Lift** | 6d | 2012-04-29 | 2012-05-05 |  | 2012-04-24 | 2012-04-30 | 0d? | 0d |  |  |
| 877 | 1.3.14.1.2.1 | Re-Bar Work | 1d | 2012-04-29 | 2012-04-30 | 875 | 2012-04-24 | 2012-04-25 | 0d? | 0d |  |  |
| 878 | 1.3.14.1.2.2 | Form Work | 1d | 2012-04-30 | 2012-05-01 | 877 | 2012-04-25 | 2012-04-26 | 0d? | 0d |  |  |
| 879 | 1.3.14.1.2.3 | Concrete | 1d | 2012-05-01 | 2012-05-02 | 878 | 2012-04-26 | 2012-04-27 | 0d? | 0d |  |  |
| 880 | 1.3.14.1.2.4 | De-shuttering | 1d | 2012-05-04 | 2012-05-05 | 879FS+2d | 2012-04-29 | 2012-04-30 | 0d? | 0d |  |  |
| 881 | 1.3.14.2 | **Shear Wall** | 12d | 2012-04-23 | 2012-05-05 |  | 2012-04-18 | 2012-04-30 | 0d? | 0d |  | nos. |
| 882 | 1.3.14.2.1 | **1st Lift** | 6d | 2012-04-23 | 2012-04-29 |  | 2012-04-18 | 2012-04-24 | 0d? | 0d |  |  |
| 883 | 1.3.14.2.1.1 | Re-Bar Work | 1d | 2012-04-23 | 2012-04-24 | 868 | 2012-04-18 | 2012-04-19 | 0d? | 0d |  |  |
| 884 | 1.3.14.2.1.2 | Form Work | 1d | 2012-04-24 | 2012-04-25 | 883 | 2012-04-19 | 2012-04-20 | 0d? | 0d |  |  |
| 885 | 1.3.14.2.1.3 | Concrete | 1d | 2012-04-25 | 2012-04-26 | 884 | 2012-04-20 | 2012-04-21 | 0d? | 0d |  |  |
| 886 | 1.3.14.2.1.4 | De-shuttering | 1d | 2012-04-28 | 2012-04-29 | 885FS+2d | 2012-04-23 | 2012-04-24 | 0d? | 0d |  |  |
| 887 | 1.3.14.2.2 | **2nd Lift** | 6d | 2012-04-29 | 2012-05-05 |  | 2012-04-24 | 2012-04-30 | 0d? | 0d |  |  |
| 888 | 1.3.14.2.2.1 | Re-Bar Work | 1d | 2012-04-29 | 2012-04-30 | 886 | 2012-04-24 | 2012-04-25 | 0d? | 0d |  |  |
| 889 | 1.3.14.2.2.2 | Form Work | 1d | 2012-04-30 | 2012-05-01 | 888 | 2012-04-25 | 2012-04-26 | 0d? | 0d |  |  |
| 890 | 1.3.14.2.2.3 | Concrete | 1d | 2012-05-01 | 2012-05-02 | 889 | 2012-04-26 | 2012-04-27 | 0d? | 0d |  |  |
| 891 | 1.3.14.2.2.4 | De-shuttering | 1d | 2012-05-04 | 2012-05-05 | 890FS+2d | 2012-04-29 | 2012-04-30 | 0d? | 0d |  |  |
| 892 | 1.3.14.3 | **Stair - 1 & 2** | 7d | 2012-04-23 | 2012-04-30 |  | 2012-04-18 | 2012-04-25 | 0d? | 5d |  |  |
| 893 | 1.3.14.3.1 | **1st Flight** | 4d | 2012-04-23 | 2012-04-27 |  | 2012-04-18 | 2012-04-22 | 0d? | 5d |  |  |
| 894 | 1.3.14.3.1.1 | Brick Work | 1d | 2012-04-23 | 2012-04-24 | 868 | 2012-04-18 | 2012-04-19 | 0d? | 5d | 0d |  |
| 895 | 1.3.14.3.1.2 | Form Work | 1d | 2012-04-24 | 2012-04-25 | 894 | 2012-04-19 | 2012-04-20 | 0d? | 5d | 0d |  |
| 896 | 1.3.14.3.1.3 | Re-bar Work | 1d | 2012-04-25 | 2012-04-26 | 895 | 2012-04-20 | 2012-04-21 | 0d? | 5d | 0d |  |
| 897 | 1.3.14.3.1.4 | Concrete | 1d | 2012-04-26 | 2012-04-27 | 896 | 2012-04-21 | 2012-04-22 | 0d? | 5d | 0d |  |
| 898 | 1.3.14.3.2 | **2nd Flight** | 3d | 2012-04-27 | 2012-04-30 |  | 2012-04-22 | 2012-04-25 | 0d? | 5d |  |  |
| 899 | 1.3.14.3.2.1 | Form Work | 1d | 2012-04-27 | 2012-04-28 | 897 | 2012-04-22 | 2012-04-23 | 0d? | 5d | 0d |  |
| 900 | 1.3.14.3.2.2 | Re-bar | 1d | 2012-04-28 | 2012-04-29 | 899 | 2012-04-23 | 2012-04-24 | 0d? | 5d | 0d |  |
| 901 | 1.3.14.3.2.3 | Concrete | 1d | 2012-04-29 | 2012-04-30 | 900 | 2012-04-24 | 2012-04-25 | 0d? | 5d |  |  |

| ID | WBS | Task | Duration | Start | Finish | Predecessors | Baseline start | Baseline finish | Baseline duration | Total slack | Free slack | Text1 |
| --- | --- | --- | --- | --- | --- | --- | --- | --- | --- | --- | --- | --- |
| 902 | 1.3.14.4 | **Roof Slab** | 13d | 2012-05-05 | 2012-05-18 |  | 2012-04-30 | 2012-05-13 | 0d? | 0d |  |  |
| 903 | 1.3.14.4.1 | Form Work | 5d | 2012-05-05 | 2012-05-10 | 880, 891, 901 | 2012-04-30 | 2012-05-05 | 0d? | 0d |  |  |
| 904 | 1.3.14.4.2 | Re-bar | 4d | 2012-05-10 | 2012-05-14 | 903 | 2012-05-05 | 2012-05-09 | 0d? | 0d |  |  |
| 905 | 1.3.14.4.3 | MEP Work | 1d | 2012-05-14 | 2012-05-15 | 904 | 2012-05-09 | 2012-05-10 | 0d? | 0d |  |  |
| 906 | 1.3.14.4.4 | Inspection | 1d | 2012-05-15 | 2012-05-16 | 905 | 2012-05-10 | 2012-05-11 | 0d? | 0d |  |  |
| 907 | 1.3.14.4.5 | Concrete | 2d | 2012-05-16 | 2012-05-18 | 906 | 2012-05-11 | 2012-05-13 | 0d? | 0d |  |  |
| 908 | 1.3.15 | **MACHINE FLOOR** | 20d | 2012-05-18 | 2012-06-07 |  | 2012-05-13 | 2012-06-02 | 20d | 0d |  |  |
| 909 | 1.3.15.1 | **Column** | 12d | 2012-05-18 | 2012-05-30 |  | 2012-05-13 | 2012-05-25 | 0d? | 0d |  | nos. |
| 910 | 1.3.15.1.1 | **1st Lift** | 6d | 2012-05-18 | 2012-05-24 | 907 | 2012-05-13 | 2012-05-19 | 0d? | 0d |  |  |
| 911 | 1.3.15.1.1.1 | Re-Bar Work | 1d | 2012-05-18 | 2012-05-19 |  | 2012-05-13 | 2012-05-14 | 0d? | 0d |  |  |
| 912 | 1.3.15.1.1.2 | Form Work | 1d | 2012-05-19 | 2012-05-20 | 911 | 2012-05-14 | 2012-05-15 | 0d? | 0d |  |  |
| 913 | 1.3.15.1.1.3 | Concrete | 1d | 2012-05-20 | 2012-05-21 | 912 | 2012-05-15 | 2012-05-16 | 0d? | 0d |  |  |
| 914 | 1.3.15.1.1.4 | De-shuttering | 1d | 2012-05-23 | 2012-05-24 | 913FS+2d | 2012-05-18 | 2012-05-19 | 0d? | 0d |  |  |
| 915 | 1.3.15.1.2 | **2nd Lift** | 6d | 2012-05-24 | 2012-05-30 |  | 2012-05-19 | 2012-05-25 | 0d? | 102d |  |  |
| 916 | 1.3.15.1.2.1 | Re-Bar Work | 1d | 2012-05-24 | 2012-05-25 | 914 | 2012-05-19 | 2012-05-20 | 0d? | 102d | 0d |  |
| 917 | 1.3.15.1.2.2 | Form Work | 1d | 2012-05-25 | 2012-05-26 | 916 | 2012-05-20 | 2012-05-21 | 0d? | 102d | 0d |  |
| 918 | 1.3.15.1.2.3 | Concrete | 1d | 2012-05-26 | 2012-05-27 | 917 | 2012-05-21 | 2012-05-22 | 0d? | 102d | 0d |  |
| 919 | 1.3.15.1.2.4 | De-shuttering | 1d | 2012-05-29 | 2012-05-30 | 918FS+2d | 2012-05-24 | 2012-05-25 | 0d? | 102d |  |  |
| 920 | 1.3.15.2 | Brcik Work upto M/c Room Bot Slab | 1d | 2012-05-18 | 2012-05-19 | 907 | 2012-05-13 | 2012-05-14 | 0d? | 5d |  |  |
| 921 | 1.3.15.3 | **M/c Room Bottom Slab** | 3d | 2012-05-24 | 2012-05-27 |  | 2012-05-19 | 2012-05-22 | 0d? | 0d |  |  |
| 922 | 1.3.15.3.1 | Form work | 1d | 2012-05-24 | 2012-05-25 | 920, 914 | 2012-05-19 | 2012-05-20 | 0d? | 0d |  |  |
| 923 | 1.3.15.3.2 | Re-bar | 1d | 2012-05-25 | 2012-05-26 | 922 | 2012-05-20 | 2012-05-21 | 0d? | 0d |  |  |
| 924 | 1.3.15.3.3 | Concrete | 1d | 2012-05-26 | 2012-05-27 | 923 | 2012-05-21 | 2012-05-22 | 0d? | 0d |  |  |
| 925 | 1.3.15.4 | Brick Work upto Top Slab | 1d | 2012-05-27 | 2012-05-28 | 924 | 2012-05-22 | 2012-05-23 | 0d? | 0d |  |  |

| ID | WBS | Task | Duration | Start | Finish | Predecessors | Baseline start | Baseline finish | Baseline duration | Total slack | Free slack |
| --- | --- | --- | --- | --- | --- | --- | --- | --- | --- | --- | --- |
| 926 | 1.3.15.5 | **Top slab** | 10d | 2012-05-28 | 2012-06-07 |  | 2012-05-23 | 2012-06-02 | 0d? | 0d |  |
| 927 | 1.3.15.5.1 | Form Work | 5d | 2012-05-28 | 2012-06-02 | 925, 920 | 2012-05-23 | 2012-05-28 | 0d? | 0d |  |
| 928 | 1.3.15.5.2 | Re-bar Work | 3d | 2012-06-02 | 2012-06-05 | 927 | 2012-05-28 | 2012-05-31 | 0d? | 0d |  |
| 929 | 1.3.15.5.3 | Inspection | 1d | 2012-06-05 | 2012-06-06 | 928 | 2012-05-31 | 2012-06-01 | 0d? | 0d |  |
| 930 | 1.3.15.5.4 | Concrete | 1d | 2012-06-06 | 2012-06-07 | 929 | 2012-06-01 | 2012-06-02 | 0d? | 0d |  |
| 931 | 1.3.15.6 | **Swimming Pool** | 5d | 2012-05-18 | 2012-05-23 |  | 2012-05-13 | 2012-05-18 | 0d? | 109d |  |
| 932 | 1.3.15.6.1 | **Vertical Wall** | 5d | 2012-05-18 | 2012-05-23 |  | 2012-05-13 | 2012-05-18 | 0d? | 109d |  |
| 933 | 1.3.15.6.1.1 | Re-bar | 2d | 2012-05-18 | 2012-05-20 | 907 | 2012-05-13 | 2012-05-15 | 0d? | 109d | 0d |
| 934 | 1.3.15.6.1.2 | Formwork | 2d | 2012-05-20 | 2012-05-22 | 933 | 2012-05-15 | 2012-05-17 | 0d? | 109d | 0d |
| 935 | 1.3.15.6.1.3 | Concrete | 1d | 2012-05-22 | 2012-05-23 | 934 | 2012-05-17 | 2012-05-18 | 0d? | 109d |  |
| 936 | 1.3.15.7 | **Planter Box** | 6d | 2012-05-18 | 2012-05-24 |  | 2012-05-13 | 2012-05-19 | 0d? | 103d |  |
| 937 | 1.3.15.7.1 | **Vertical Wall** | 6d | 2012-05-18 | 2012-05-24 |  | 2012-05-13 | 2012-05-19 | 0d? | 103d |  |
| 938 | 1.3.15.7.1.1 | Re-bar | 2d | 2012-05-18 | 2012-05-20 | 907 | 2012-05-13 | 2012-05-15 | 0d? | 103d | 0d |
| 939 | 1.3.15.7.1.2 | Formwork | 2d | 2012-05-20 | 2012-05-22 | 938 | 2012-05-15 | 2012-05-17 | 0d? | 103d | 0d |
| 940 | 1.3.15.7.1.3 | Concrete | 2d | 2012-05-22 | 2012-05-24 | 939 | 2012-05-17 | 2012-05-19 | 0d? | 108d |  |
| 941 | 1.4 | **FINISHING WORK** | 509d | 2011-03-01 | 2012-08-07 |  | 2011-04-15 | 2012-08-02 | 459d | 2d | 0d |
| 942 | 1.4.1 | **BASEMENT-3** | 77d | 2011-03-01 | 2011-05-17 |  | 2011-04-15 | 2011-07-01 | 77d | 432d |  |
| 943 | 1.4.1.1 | De-shuttering Roof Slab | 3d | 2011-03-01 | 2011-03-04 | 222FS+21d | 2011-04-15 | 2011-04-18 | 0d? | 432d | 0d |
| 944 | 1.4.1.2 | Brick Work | 14d | 2011-03-04 | 2011-03-18 | 943 | 2011-04-18 | 2011-05-02 | 0d? | 434d | 0d |
| 945 | 1.4.1.3 | Plaster | 14d | 2011-03-11 | 2011-03-25 | 944FF+7d | 2011-04-25 | 2011-05-09 | 0d? | 434d | 2d |
| 946 | 1.4.1.4 | Column Guard/ Car Stopper | 7d | 2011-04-18 | 2011-04-25 | 948SF | 2011-06-02 | 2011-06-10 | 0d? | 456d |  |
| 947 | 1.4.1.5 | Stair/Other Railing | 15d | 2011-04-10 | 2011-04-25 | 948SF | 2011-05-25 | 2011-06-10 | 0d? | 456d |  |
| 948 | 1.4.1.6 | Resin Floor | 15d | 2011-04-25 | 2011-05-10 | 1228FF+7d | 2011-06-09 | 2011-06-24 | 0d? | 434d | 0d |
| 949 | 1.4.1.7 | Painting | 30d | 2011-04-17 | 2011-05-17 | 948FF+7d, 945FS+21d | 2011-06-01 | 2011-07-01 | 0d? | 432d |  |

| ID | WBS | Task | Duration | Start | Finish | Predecessors | Baseline start | Baseline finish | Baseline duration | Total slack | Free slack |
| --- | --- | --- | --- | --- | --- | --- | --- | --- | --- | --- | --- |
| 950 | 1.4.2 | **BASEMENT-2** | 77d | 2011-04-10 | 2011-06-26 |  | 2011-05-09 | 2011-07-25 | 77d | 392d |  |
| 951 | 1.4.2.1 | De-shuttering Roof Slab | 3d | 2011-04-10 | 2011-04-13 | 291FS+21d | 2011-05-09 | 2011-05-12 | 0d? | 392d | 0d |
| 952 | 1.4.2.2 | Brick Work | 14d | 2011-04-13 | 2011-04-27 | 951 | 2011-05-12 | 2011-05-26 | 0d? | 394d | 0d |
| 953 | 1.4.2.3 | Plaster | 14d | 2011-04-20 | 2011-05-04 | 952FF+7d | 2011-05-19 | 2011-06-02 | 0d? | 394d | 2d |
| 954 | 1.4.2.4 | Column Guard/ Car Stopper | 7d | 2011-05-28 | 2011-06-04 | 956SF | 2011-06-26 | 2011-07-04 | 0d? | 414d |  |
| 955 | 1.4.2.5 | Stair/Other Railing | 15d | 2011-05-20 | 2011-06-04 | 956SF | 2011-06-18 | 2011-07-04 | 0d? | 414d |  |
| 956 | 1.4.2.6 | Resin Floor | 15d | 2011-06-04 | 2011-06-19 | 1229FF+7d | 2011-07-03 | 2011-07-18 | 0d? | 392d | 0d |
| 957 | 1.4.2.7 | Painting | 30d | 2011-05-27 | 2011-06-26 | 956FF+7d, 953FS+21d | 2011-06-25 | 2011-07-25 | 0d? | 392d |  |
| 958 | 1.4.3 | **BASEMENT-1** | 77d | 2011-06-08 | 2011-08-24 |  | 2011-06-03 | 2011-08-19 | 77d | 333d |  |
| 959 | 1.4.3.1 | De-shuttering Roof Slab | 3d | 2011-06-08 | 2011-06-11 | 360FS+21d | 2011-06-03 | 2011-06-06 | 0d? | 333d | 0d |
| 960 | 1.4.3.2 | Brick Work | 14d | 2011-06-11 | 2011-06-25 | 959 | 2011-06-06 | 2011-06-20 | 0d? | 335d | 0d |
| 961 | 1.4.3.3 | Plaster | 14d | 2011-06-18 | 2011-07-02 | 960FF+7d | 2011-06-13 | 2011-06-27 | 0d? | 335d | 2d |
| 962 | 1.4.3.4 | Column Guard/ Car Stopper | 7d | 2011-07-26 | 2011-08-02 | 964SF | 2011-07-21 | 2011-07-29 | 0d? | 355d |  |
| 963 | 1.4.3.5 | Stair/Other Railing | 15d | 2011-07-18 | 2011-08-02 | 964SF | 2011-07-13 | 2011-07-29 | 0d? | 355d |  |
| 964 | 1.4.3.6 | Resin Floor | 15d | 2011-08-02 | 2011-08-17 | 1230FF+7d | 2011-07-28 | 2011-08-12 | 0d? | 333d | 0d |
| 965 | 1.4.3.7 | Painting | 30d | 2011-07-25 | 2011-08-24 | 964FF+7d, 961FS+21d | 2011-07-20 | 2011-08-19 | 0d? | 333d |  |
| 966 | 1.4.4 | **GROUND FLOOR** | 62d | 2011-07-03 | 2011-09-11 |  | 2011-06-28 | 2011-09-06 | 62d | 323d |  |
| 967 | 1.4.4.1 | De-shuttering Roof Slab | 3d | 2011-07-03 | 2011-07-06 | 400FS+21d | 2011-06-28 | 2011-07-01 | 0d? | 323d | 0d |
| 968 | 1.4.4.2 | Brick Work | 7d | 2011-07-06 | 2011-07-13 | 967 | 2011-07-01 | 2011-07-08 | 0d? | 323d | 0d |
| 969 | 1.4.4.3 | Plaster | 7d | 2011-07-13 | 2011-07-20 | 968FF+7d | 2011-07-08 | 2011-07-15 | 0d? | 323d | 0d |
| 970 | 1.4.4.4 | **Toilet Cubicals** | 11d | 2011-07-20 | 2011-07-31 |  | 2011-07-15 | 2011-07-26 | 0d? | 357d |  |
| 971 | 1.4.4.4.1 | Water/ Sewarage Pipe Lines | 3d | 2011-07-20 | 2011-07-23 | 969 | 2011-07-15 | 2011-07-18 | 0d? | 357d | 0d |
| 972 | 1.4.4.4.2 | Water Proofing Works | 1d | 2011-07-23 | 2011-07-24 | 971 | 2011-07-18 | 2011-07-19 | 0d? | 357d | 0d |
| 973 | 1.4.4.4.3 | Tile Works/ Marble Top | 3d | 2011-07-24 | 2011-07-27 | 972 | 2011-07-19 | 2011-07-22 | 0d? | 357d | 0d |
| 974 | 1.4.4.4.4 | Cubicals Install | 3d | 2011-07-27 | 2011-07-30 | 973 | 2011-07-22 | 2011-07-25 | 0d? | 357d | 0d |
| 975 | 1.4.4.4.5 | Fitting & Fixtures | 1d | 2011-07-30 | 2011-07-31 | 974 | 2011-07-25 | 2011-07-26 | 0d? | 357d |  |
| 976 | 1.4.4.5 | False Ceiling Works | 15d | 2011-08-19 | 2011-09-11 | 1231 | 2011-08-14 | 2011-09-06 | 0d? | 323d |  |
| 977 | 1.4.4.6 | Paver Works | 15d | 2011-07-20 | 2011-08-04 | 969 | 2011-07-15 | 2011-07-30 | 0d? | 353d |  |
| 978 | 1.4.4.7 | Sone/Wood/Glazing in Wall | 14d | 2011-07-28 | 2011-08-11 | 981SF | 2011-07-23 | 2011-08-07 | 0d? | 346d |  |
| 979 | 1.4.4.8 | Stair/Other Railing | 15d | 2011-07-27 | 2011-08-11 | 981SF | 2011-07-22 | 2011-08-07 | 0d? | 346d |  |
| 980 | 1.4.4.9 | Granite Flooring | 10d | 2011-08-13 | 2011-08-23 | 981FF-3d | 2011-08-08 | 2011-08-18 | 0d? | 334d |  |
| 981 | 1.4.4.10 | Resin Floor | 15d | 2011-08-11 | 2011-09-03 | 1231FF+7d | 2011-08-06 | 2011-08-21 | 0d? | 324d | 0d |
| 982 | 1.4.4.11 | Fire Door Installation | 7d | 2011-08-22 | 2011-09-06 | 981FF+3d | 2011-08-17 | 2011-08-24 | 0d? | 328d |  |
| 983 | 1.4.4.12 | Painting | 15d | 2011-08-18 | 2011-09-10 | 981FF+7d, 969FS+21d | 2011-08-13 | 2011-09-05 | 0d? | 324d |  |

| ID | WBS | Task | Duration | Start | Finish | Predecessors | Baseline start | Baseline finish | Baseline duration | Total slack | Free slack |
| --- | --- | --- | --- | --- | --- | --- | --- | --- | --- | --- | --- |
| 984 | 1.4.5 | **1ST FLOOR** | 53d | 2011-07-28 | 2011-09-27 |  | 2011-07-23 | 2011-09-22 | 53d | 307d |  |
| 985 | 1.4.5.1 | De-shuttering Roof Slab | 3d | 2011-07-28 | 2011-07-31 | 439FS+21d | 2011-07-23 | 2011-07-26 | 0d? | 307d | 0d |
| 986 | 1.4.5.2 | Brick Work | 7d | 2011-07-31 | 2011-08-07 | 985 | 2011-07-26 | 2011-08-02 | 0d? | 307d | 0d |
| 987 | 1.4.5.3 | Plaster | 7d | 2011-08-07 | 2011-08-14 | 986FF+7d | 2011-08-02 | 2011-08-09 | 0d? | 307d | 0d |
| 988 | 1.4.5.4 | **Toilet Cubicals** | 11d | 2011-08-14 | 2011-08-25 |  | 2011-08-09 | 2011-08-20 | 0d? | 332d |  |
| 989 | 1.4.5.4.1 | Water/ Sewarage Pipe Lines | 3d | 2011-08-14 | 2011-08-17 | 987 | 2011-08-09 | 2011-08-12 | 0d? | 332d | 0d |
| 990 | 1.4.5.4.2 | Water Proofing Works | 1d | 2011-08-17 | 2011-08-18 | 989 | 2011-08-12 | 2011-08-13 | 0d? | 332d | 0d |
| 991 | 1.4.5.4.3 | Tile Works/ Marble Top | 3d | 2011-08-18 | 2011-08-21 | 990 | 2011-08-13 | 2011-08-16 | 0d? | 332d | 0d |
| 992 | 1.4.5.4.4 | Cubicals Install | 3d | 2011-08-21 | 2011-08-24 | 991 | 2011-08-16 | 2011-08-19 | 0d? | 332d | 0d |
| 993 | 1.4.5.4.5 | Fitting & Fixtures | 1d | 2011-08-24 | 2011-08-25 | 992 | 2011-08-19 | 2011-08-20 | 0d? | 332d |  |
| 994 | 1.4.5.5 | False Ceiling Works | 15d | 2011-09-07 | 2011-09-22 | 1232 | 2011-08-25 | 2011-09-17 | 0d? | 312d |  |
| 995 | 1.4.5.6 | Sone/Wood/Glazing in Wall | 14d | 2011-08-08 | 2011-08-22 | 998SF | 2011-08-03 | 2011-08-18 | 0d? | 335d |  |
| 996 | 1.4.5.7 | Stair/Other Railing | 15d | 2011-08-07 | 2011-08-22 | 998SF | 2011-08-02 | 2011-08-18 | 0d? | 335d |  |
| 997 | 1.4.5.8 | Granite Flooring | 10d | 2011-08-24 | 2011-09-11 | 998FF-3d | 2011-08-19 | 2011-09-06 | 0d? | 323d |  |
| 998 | 1.4.5.9 | Resin Floor | 15d | 2011-08-22 | 2011-09-14 | 1232FF+7d | 2011-08-17 | 2011-09-09 | 0d? | 313d | 0d |
| 999 | 1.4.5.10 | Fire Door Installation | 7d | 2011-09-10 | 2011-09-17 | 998FF+3d | 2011-09-05 | 2011-09-12 | 0d? | 317d |  |
| 1000 | 1.4.5.11 | Painting | 15d | 2011-09-12 | 2011-09-27 | 998FF+7d, 987FS+21d | 2011-09-07 | 2011-09-22 | 0d? | 307d |  |
| 1001 | 1.4.6 | **2ND FLOOR** | 53d | 2011-08-22 | 2011-10-22 |  | 2011-08-17 | 2011-10-17 | 53d | 282d |  |
| 1002 | 1.4.6.1 | De-shuttering Roof Slab | 3d | 2011-08-22 | 2011-08-25 | 478FS+21d | 2011-08-17 | 2011-08-20 | 0d? | 282d | 0d |
| 1003 | 1.4.6.2 | Brick Work | 7d | 2011-08-25 | 2011-09-09 | 1002 | 2011-08-20 | 2011-09-04 | 0d? | 282d | 0d |
| 1004 | 1.4.6.3 | Plaster | 7d | 2011-09-09 | 2011-09-16 | 1003FF+7d | 2011-09-04 | 2011-09-11 | 0d? | 282d | 0d |
| 1005 | 1.4.6.4 | **Toilet Cubicals** | 11d | 2011-09-16 | 2011-09-27 |  | 2011-09-11 | 2011-09-22 | 0d? | 307d |  |
| 1006 | 1.4.6.4.1 | Water/ Sewarage Pipe Lines | 3d | 2011-09-16 | 2011-09-19 | 1004 | 2011-09-11 | 2011-09-14 | 0d? | 307d | 0d |
| 1007 | 1.4.6.4.2 | Water Proofing Works | 1d | 2011-09-19 | 2011-09-20 | 1006 | 2011-09-14 | 2011-09-15 | 0d? | 307d | 0d |
| 1008 | 1.4.6.4.3 | Tile Works/ Marble Top | 3d | 2011-09-20 | 2011-09-23 | 1007 | 2011-09-15 | 2011-09-18 | 0d? | 307d | 0d |
| 1009 | 1.4.6.4.4 | Cubicals Install | 3d | 2011-09-23 | 2011-09-26 | 1008 | 2011-09-18 | 2011-09-21 | 0d? | 307d | 0d |
| 1010 | 1.4.6.4.5 | Fitting & Fixtures | 1d | 2011-09-26 | 2011-09-27 | 1009 | 2011-09-21 | 2011-09-22 | 0d? | 307d |  |
| 1011 | 1.4.6.5 | False Ceiling Works | 15d | 2011-10-02 | 2011-10-17 | 1233 | 2011-09-27 | 2011-10-12 | 0d? | 287d |  |
| 1012 | 1.4.6.6 | Sone/Wood/Glazing in Wall | 14d | 2011-09-10 | 2011-09-24 | 1015SF | 2011-09-05 | 2011-09-20 | 0d? | 310d |  |
| 1013 | 1.4.6.7 | Stair/Other Railing | 15d | 2011-09-09 | 2011-09-24 | 1015SF | 2011-09-04 | 2011-09-20 | 0d? | 310d |  |
| 1014 | 1.4.6.8 | Granite Flooring | 10d | 2011-09-26 | 2011-10-06 | 1015FF-3d | 2011-09-21 | 2011-10-01 | 0d? | 298d |  |
| 1015 | 1.4.6.9 | Resin Floor | 15d | 2011-09-24 | 2011-10-09 | 1233FF+7d | 2011-09-19 | 2011-10-04 | 0d? | 288d | 0d |
| 1016 | 1.4.6.10 | Fire Door Installation | 7d | 2011-10-05 | 2011-10-12 | 1015FF+3d | 2011-09-30 | 2011-10-07 | 0d? | 292d |  |
| 1017 | 1.4.6.11 | Painting | 15d | 2011-10-07 | 2011-10-22 | 1015FF+7d, 1004FS+21d | 2011-10-02 | 2011-10-17 | 0d? | 282d |  |

| ID | WBS | Task | Duration | Start | Finish | Predecessors | Baseline start | Baseline finish | Baseline duration | Total slack | Free slack |
| --- | --- | --- | --- | --- | --- | --- | --- | --- | --- | --- | --- |
| 1018 | 1.4.7 | **3RD FLOOR** | 53d | 2011-09-24 | 2011-11-24 |  | 2011-09-19 | 2011-11-19 | 53d | 257d |  |
| 1019 | 1.4.7.1 | De-shuttering Roof Slab | 3d | 2011-09-24 | 2011-09-27 | 517FS+21d | 2011-09-19 | 2011-09-22 | 0d? | 257d | 0d |
| 1020 | 1.4.7.2 | Brick Work | 7d | 2011-09-27 | 2011-10-04 | 1019 | 2011-09-22 | 2011-09-29 | 0d? | 257d | 0d |
| 1021 | 1.4.7.3 | Plaster | 7d | 2011-10-04 | 2011-10-11 | 1020FF+7d | 2011-09-29 | 2011-10-06 | 0d? | 257d | 0d |
| 1022 | 1.4.7.4 | **Toilet Cubicals** | 11d | 2011-10-11 | 2011-10-22 |  | 2011-10-06 | 2011-10-17 | 0d? | 282d |  |
| 1023 | 1.4.7.4.1 | Water/ Sewarage Pipe Lines | 3d | 2011-10-11 | 2011-10-14 | 1021 | 2011-10-06 | 2011-10-09 | 0d? | 282d | 0d |
| 1024 | 1.4.7.4.2 | Water Proofing Works | 1d | 2011-10-14 | 2011-10-15 | 1023 | 2011-10-09 | 2011-10-10 | 0d? | 282d | 0d |
| 1025 | 1.4.7.4.3 | Tile Works/ Marble Top | 3d | 2011-10-15 | 2011-10-18 | 1024 | 2011-10-10 | 2011-10-13 | 0d? | 282d | 0d |
| 1026 | 1.4.7.4.4 | Cubicals Install | 3d | 2011-10-18 | 2011-10-21 | 1025 | 2011-10-13 | 2011-10-16 | 0d? | 282d | 0d |
| 1027 | 1.4.7.4.5 | Fitting & Fixtures | 1d | 2011-10-21 | 2011-10-22 | 1026 | 2011-10-16 | 2011-10-17 | 0d? | 282d |  |
| 1028 | 1.4.7.5 | False Ceiling Works | 15d | 2011-10-27 | 2011-11-19 | 1234 | 2011-10-22 | 2011-11-06 | 0d? | 262d |  |
| 1029 | 1.4.7.6 | Sone/Wood/Glazing in Wall | 14d | 2011-10-05 | 2011-10-19 | 1032SF | 2011-09-30 | 2011-10-15 | 0d? | 285d |  |
| 1030 | 1.4.7.7 | Stair/Other Railing | 15d | 2011-10-04 | 2011-10-19 | 1032SF | 2011-09-29 | 2011-10-15 | 0d? | 285d |  |
| 1031 | 1.4.7.8 | Granite Flooring | 10d | 2011-10-21 | 2011-10-31 | 1032FF-3d | 2011-10-16 | 2011-10-26 | 0d? | 273d |  |
| 1032 | 1.4.7.9 | Resin Floor | 15d | 2011-10-19 | 2011-11-03 | 1234FF+7d | 2011-10-14 | 2011-10-29 | 0d? | 263d | 0d |
| 1033 | 1.4.7.10 | Fire Door Installation | 7d | 2011-10-30 | 2011-11-06 | 1032FF+3d | 2011-10-25 | 2011-11-01 | 0d? | 267d |  |
| 1034 | 1.4.7.11 | Painting | 15d | 2011-11-01 | 2011-11-24 | 1032FF+7d, 1021FS+21d | 2011-10-27 | 2011-11-19 | 0d? | 257d |  |
| 1035 | 1.4.8 | **4TH FLOOR** | 53d | 2011-10-19 | 2011-12-19 |  | 2011-10-14 | 2011-12-14 | 53d | 232d |  |
| 1036 | 1.4.8.1 | De-shuttering Roof Slab | 3d | 2011-10-19 | 2011-10-22 | 556FS+21d | 2011-10-14 | 2011-10-17 | 0d? | 232d | 0d |
| 1037 | 1.4.8.2 | Brick Work | 7d | 2011-10-22 | 2011-10-29 | 1036 | 2011-10-17 | 2011-10-24 | 0d? | 232d | 0d |
| 1038 | 1.4.8.3 | Plaster | 7d | 2011-10-29 | 2011-11-05 | 1037FF+7d | 2011-10-24 | 2011-10-31 | 0d? | 232d | 0d |
| 1039 | 1.4.8.4 | **Toilet Cubicals** | 11d | 2011-11-05 | 2011-11-24 |  | 2011-10-31 | 2011-11-19 | 0d? | 257d |  |
| 1040 | 1.4.8.4.1 | Water/ Sewarage Pipe Lines | 3d | 2011-11-05 | 2011-11-08 | 1038 | 2011-10-31 | 2011-11-03 | 0d? | 257d | 0d |
| 1041 | 1.4.8.4.2 | Water Proofing Works | 1d | 2011-11-08 | 2011-11-09 | 1040 | 2011-11-03 | 2011-11-04 | 0d? | 257d | 0d |
| 1042 | 1.4.8.4.3 | Tile Works/ Marble Top | 3d | 2011-11-09 | 2011-11-20 | 1041 | 2011-11-04 | 2011-11-07 | 0d? | 257d | 0d |
| 1043 | 1.4.8.4.4 | Cubicals Install | 3d | 2011-11-20 | 2011-11-23 | 1042 | 2011-11-07 | 2011-11-10 | 0d? | 257d | 0d |
| 1044 | 1.4.8.4.5 | Fitting & Fixtures | 1d | 2011-11-23 | 2011-11-24 | 1043 | 2011-11-10 | 2011-11-19 | 0d? | 257d |  |
| 1045 | 1.4.8.5 | False Ceiling Works | 15d | 2011-11-29 | 2011-12-14 | 1235 | 2011-11-24 | 2011-12-09 | 0d? | 237d |  |
| 1046 | 1.4.8.6 | Sone/Wood/Glazing in Wall | 14d | 2011-10-30 | 2011-11-21 | 1049SF | 2011-10-25 | 2011-11-09 | 0d? | 260d |  |
| 1047 | 1.4.8.7 | Stair/Other Railing | 15d | 2011-10-29 | 2011-11-21 | 1049SF | 2011-10-24 | 2011-11-09 | 0d? | 260d |  |
| 1048 | 1.4.8.8 | Granite Flooring | 10d | 2011-11-23 | 2011-12-03 | 1049FF-3d | 2011-11-10 | 2011-11-28 | 0d? | 248d |  |
| 1049 | 1.4.8.9 | Resin Floor | 15d | 2011-11-21 | 2011-12-06 | 1235FF+7d | 2011-11-08 | 2011-12-01 | 0d? | 238d | 0d |
| 1050 | 1.4.8.10 | Fire Door Installation | 7d | 2011-12-02 | 2011-12-09 | 1049FF+3d | 2011-11-27 | 2011-12-04 | 0d? | 242d |  |
| 1051 | 1.4.8.11 | Painting | 15d | 2011-12-04 | 2011-12-19 | 1049FF+7d, 1038FS+21d | 2011-11-29 | 2011-12-14 | 0d? | 232d |  |

| ID | WBS | Task | Duration | Start | Finish | Predecessors | Baseline start | Baseline finish | Baseline duration | Total slack | Free slack |
| --- | --- | --- | --- | --- | --- | --- | --- | --- | --- | --- | --- |
| 1052 | 1.4.9 | **5TH FLOOR** | 53d | 2011-11-21 | 2012-01-13 |  | 2011-11-08 | 2012-01-08 | 53d | 207d |  |
| 1053 | 1.4.9.1 | De-shuttering Roof Slab | 3d | 2011-11-21 | 2011-11-24 | 595FS+21d | 2011-11-08 | 2011-11-19 | 0d? | 207d | 0d |
| 1054 | 1.4.9.2 | Brick Work | 7d | 2011-11-24 | 2011-12-01 | 1053 | 2011-11-19 | 2011-11-26 | 0d? | 207d | 0d |
| 1055 | 1.4.9.3 | Plaster | 7d | 2011-12-01 | 2011-12-08 | 1054FF+7d | 2011-11-26 | 2011-12-03 | 0d? | 207d | 0d |
| 1056 | 1.4.9.4 | **Toilet Cubicals** | 11d | 2011-12-08 | 2011-12-19 |  | 2011-12-03 | 2011-12-14 | 0d? | 232d |  |
| 1057 | 1.4.9.4.1 | Water/ Sewarage Pipe Lines | 3d | 2011-12-08 | 2011-12-11 | 1055 | 2011-12-03 | 2011-12-06 | 0d? | 232d | 0d |
| 1058 | 1.4.9.4.2 | Water Proofing Works | 1d | 2011-12-11 | 2011-12-12 | 1057 | 2011-12-06 | 2011-12-07 | 0d? | 232d | 0d |
| 1059 | 1.4.9.4.3 | Tile Works/ Marble Top | 3d | 2011-12-12 | 2011-12-15 | 1058 | 2011-12-07 | 2011-12-10 | 0d? | 232d | 0d |
| 1060 | 1.4.9.4.4 | Cubicals Install | 3d | 2011-12-15 | 2011-12-18 | 1059 | 2011-12-10 | 2011-12-13 | 0d? | 232d | 0d |
| 1061 | 1.4.9.4.5 | Fitting & Fixtures | 1d | 2011-12-18 | 2011-12-19 | 1060 | 2011-12-13 | 2011-12-14 | 0d? | 232d |  |
| 1062 | 1.4.9.5 | False Ceiling Works | 15d | 2011-12-24 | 2012-01-08 | 1236 | 2011-12-19 | 2012-01-03 | 0d? | 212d |  |
| 1063 | 1.4.9.6 | Sone/Wood/Glazing in Wall | 14d | 2011-12-02 | 2011-12-16 | 1066SF | 2011-11-27 | 2011-12-12 | 0d? | 235d |  |
| 1064 | 1.4.9.7 | Stair/Other Railing | 15d | 2011-12-01 | 2011-12-16 | 1066SF | 2011-11-26 | 2011-12-12 | 0d? | 235d |  |
| 1065 | 1.4.9.8 | Granite Flooring | 10d | 2011-12-18 | 2011-12-28 | 1066FF-3d | 2011-12-13 | 2011-12-23 | 0d? | 223d |  |
| 1066 | 1.4.9.9 | Resin Floor | 15d | 2011-12-16 | 2011-12-31 | 1236FF+7d | 2011-12-11 | 2011-12-26 | 0d? | 213d | 0d |
| 1067 | 1.4.9.10 | Fire Door Installation | 7d | 2011-12-27 | 2012-01-03 | 1066FF+3d | 2011-12-22 | 2011-12-29 | 0d? | 217d |  |
| 1068 | 1.4.9.11 | Painting | 15d | 2011-12-29 | 2012-01-13 | 1066FF+7d, 1055FS+21d | 2011-12-24 | 2012-01-08 | 0d? | 207d |  |
| 1069 | 1.4.10 | **6TH FLOOR** | 53d | 2011-12-16 | 2012-02-07 |  | 2011-12-11 | 2012-02-02 | 53d | 182d |  |
| 1070 | 1.4.10.1 | De-shuttering Roof Slab | 3d | 2011-12-16 | 2011-12-19 | 634FS+21d | 2011-12-11 | 2011-12-14 | 0d? | 182d | 0d |
| 1071 | 1.4.10.2 | Brick Work | 7d | 2011-12-19 | 2011-12-26 | 1070 | 2011-12-14 | 2011-12-21 | 0d? | 182d | 0d |
| 1072 | 1.4.10.3 | Plaster | 7d | 2011-12-26 | 2012-01-02 | 1071FF+7d | 2011-12-21 | 2011-12-28 | 0d? | 182d | 0d |
| 1073 | 1.4.10.4 | **Toilet Cubicals** | 11d | 2012-01-02 | 2012-01-13 |  | 2011-12-28 | 2012-01-08 | 0d? | 207d |  |
| 1074 | 1.4.10.4.1 | Water/ Sewarage Pipe Lines | 3d | 2012-01-02 | 2012-01-05 | 1072 | 2011-12-28 | 2011-12-31 | 0d? | 207d | 0d |
| 1075 | 1.4.10.4.2 | Water Proofing Works | 1d | 2012-01-05 | 2012-01-06 | 1074 | 2011-12-31 | 2012-01-01 | 0d? | 207d | 0d |
| 1076 | 1.4.10.4.3 | Tile Works/ Marble Top | 3d | 2012-01-06 | 2012-01-09 | 1075 | 2012-01-01 | 2012-01-04 | 0d? | 207d | 0d |
| 1077 | 1.4.10.4.4 | Cubicals Install | 3d | 2012-01-09 | 2012-01-12 | 1076 | 2012-01-04 | 2012-01-07 | 0d? | 207d | 0d |
| 1078 | 1.4.10.4.5 | Fitting & Fixtures | 1d | 2012-01-12 | 2012-01-13 | 1077 | 2012-01-07 | 2012-01-08 | 0d? | 207d |  |
| 1079 | 1.4.10.5 | False Ceiling Works | 15d | 2012-01-18 | 2012-02-02 | 1237 | 2012-01-13 | 2012-01-28 | 0d? | 187d |  |
| 1080 | 1.4.10.6 | Sone/Wood/Glazing in Wall | 14d | 2011-12-27 | 2012-01-10 | 1083SF | 2011-12-22 | 2012-01-06 | 0d? | 210d |  |
| 1081 | 1.4.10.7 | Stair/Other Railing | 15d | 2011-12-26 | 2012-01-10 | 1083SF | 2011-12-21 | 2012-01-06 | 0d? | 210d |  |
| 1082 | 1.4.10.8 | Granite Flooring | 10d | 2012-01-12 | 2012-01-22 | 1083FF-3d | 2012-01-07 | 2012-01-17 | 0d? | 198d |  |
| 1083 | 1.4.10.9 | Resin Floor | 15d | 2012-01-10 | 2012-01-25 | 1237FF+7d | 2012-01-05 | 2012-01-20 | 0d? | 188d | 0d |
| 1084 | 1.4.10.10 | Fire Door Installation | 7d | 2012-01-21 | 2012-01-28 | 1083FF+3d | 2012-01-16 | 2012-01-23 | 0d? | 192d |  |
| 1085 | 1.4.10.11 | Painting | 15d | 2012-01-23 | 2012-02-07 | 1083FF+7d, 1072FS+21d | 2012-01-18 | 2012-02-02 | 0d? | 182d |  |

| ID | WBS | Task | Duration | Start | Finish | Predecessors | Baseline start | Baseline finish | Baseline duration | Total slack | Free slack |
| --- | --- | --- | --- | --- | --- | --- | --- | --- | --- | --- | --- |
| 1086 | 1.4.11 | **7TH FLOOR** | 53d | 2012-01-10 | 2012-03-03 |  | 2012-01-05 | 2012-02-27 | 53d | 157d |  |
| 1087 | 1.4.11.1 | De-shuttering Roof Slab | 3d | 2012-01-10 | 2012-01-13 | 673FS+21d | 2012-01-05 | 2012-01-08 | 0d? | 157d | 0d |
| 1088 | 1.4.11.2 | Brick Work | 7d | 2012-01-13 | 2012-01-20 | 1087 | 2012-01-08 | 2012-01-15 | 0d? | 157d | 0d |
| 1089 | 1.4.11.3 | Plaster | 7d | 2012-01-20 | 2012-01-27 | 1088FF+7d | 2012-01-15 | 2012-01-22 | 0d? | 157d | 0d |
| 1090 | 1.4.11.4 | **Toilet Cubicals** | 11d | 2012-01-27 | 2012-02-07 |  | 2012-01-22 | 2012-02-02 | 0d? | 182d |  |
| 1091 | 1.4.11.4.1 | Water/ Sewarage Pipe Lines | 3d | 2012-01-27 | 2012-01-30 | 1089 | 2012-01-22 | 2012-01-25 | 0d? | 182d | 0d |
| 1092 | 1.4.11.4.2 | Water Proofing Works | 1d | 2012-01-30 | 2012-01-31 | 1091 | 2012-01-25 | 2012-01-26 | 0d? | 182d | 0d |
| 1093 | 1.4.11.4.3 | Tile Works/ Marble Top | 3d | 2012-01-31 | 2012-02-03 | 1092 | 2012-01-26 | 2012-01-29 | 0d? | 182d | 0d |
| 1094 | 1.4.11.4.4 | Cubicals Install | 3d | 2012-02-03 | 2012-02-06 | 1093 | 2012-01-29 | 2012-02-01 | 0d? | 182d | 0d |
| 1095 | 1.4.11.4.5 | Fitting & Fixtures | 1d | 2012-02-06 | 2012-02-07 | 1094 | 2012-02-01 | 2012-02-02 | 0d? | 182d |  |
| 1096 | 1.4.11.5 | False Ceiling Works | 15d | 2012-02-12 | 2012-02-27 | 1238 | 2012-02-07 | 2012-02-22 | 0d? | 162d |  |
| 1097 | 1.4.11.6 | Sone/Wood/Glazing in Wall | 14d | 2012-01-21 | 2012-02-04 | 1100SF | 2012-01-16 | 2012-01-31 | 0d? | 185d |  |
| 1098 | 1.4.11.7 | Stair/Other Railing | 15d | 2012-01-20 | 2012-02-04 | 1100SF | 2012-01-15 | 2012-01-31 | 0d? | 185d |  |
| 1099 | 1.4.11.8 | Granite Flooring | 10d | 2012-02-06 | 2012-02-16 | 1100FF-3d | 2012-02-01 | 2012-02-11 | 0d? | 173d |  |
| 1100 | 1.4.11.9 | Resin Floor | 15d | 2012-02-04 | 2012-02-19 | 1238FF+7d | 2012-01-30 | 2012-02-14 | 0d? | 163d | 0d |
| 1101 | 1.4.11.10 | Fire Door Installation | 7d | 2012-02-15 | 2012-02-22 | 1100FF+3d | 2012-02-10 | 2012-02-17 | 0d? | 167d |  |
| 1102 | 1.4.11.11 | Painting | 15d | 2012-02-17 | 2012-03-03 | 1100FF+7d, 1089FS+21d | 2012-02-12 | 2012-02-27 | 0d? | 157d |  |
| 1103 | 1.4.12 | **8TH FLOOR** | 53d | 2012-02-16 | 2012-04-09 |  | 2012-02-11 | 2012-04-04 | 53d | 120d |  |
| 1104 | 1.4.12.1 | De-shuttering Roof Slab | 3d | 2012-02-16 | 2012-02-19 | 714FS+21d | 2012-02-11 | 2012-02-14 | 0d? | 120d | 0d |
| 1105 | 1.4.12.2 | Brick Work | 7d | 2012-02-19 | 2012-02-26 | 1104 | 2012-02-14 | 2012-02-21 | 0d? | 120d | 0d |
| 1106 | 1.4.12.3 | Plaster | 7d | 2012-02-26 | 2012-03-04 | 1105FF+7d | 2012-02-21 | 2012-02-28 | 0d? | 120d | 0d |
| 1107 | 1.4.12.4 | **Toilet Cubicals** | 11d | 2012-03-04 | 2012-03-15 |  | 2012-02-28 | 2012-03-10 | 0d? | 145d |  |
| 1108 | 1.4.12.4.1 | Water/ Sewarage Pipe Lines | 3d | 2012-03-04 | 2012-03-07 | 1106 | 2012-02-28 | 2012-03-02 | 0d? | 145d | 0d |
| 1109 | 1.4.12.4.2 | Water Proofing Works | 1d | 2012-03-07 | 2012-03-08 | 1108 | 2012-03-02 | 2012-03-03 | 0d? | 145d | 0d |
| 1110 | 1.4.12.4.3 | Tile Works/ Marble Top | 3d | 2012-03-08 | 2012-03-11 | 1109 | 2012-03-03 | 2012-03-06 | 0d? | 145d | 0d |
| 1111 | 1.4.12.4.4 | Cubicals Install | 3d | 2012-03-11 | 2012-03-14 | 1110 | 2012-03-06 | 2012-03-09 | 0d? | 145d | 0d |
| 1112 | 1.4.12.4.5 | Fitting & Fixtures | 1d | 2012-03-14 | 2012-03-15 | 1111 | 2012-03-09 | 2012-03-10 | 0d? | 145d |  |
| 1113 | 1.4.12.5 | False Ceiling Works | 15d | 2012-03-20 | 2012-04-04 | 1239 | 2012-03-15 | 2012-03-30 | 0d? | 125d |  |
| 1114 | 1.4.12.6 | Sone/Wood/Glazing in Wall | 14d | 2012-02-27 | 2012-03-12 | 1117SF | 2012-02-22 | 2012-03-08 | 0d? | 148d |  |
| 1115 | 1.4.12.7 | Stair/Other Railing | 15d | 2012-02-26 | 2012-03-12 | 1117SF | 2012-02-21 | 2012-03-08 | 0d? | 148d |  |
| 1116 | 1.4.12.8 | Granite Flooring | 10d | 2012-03-14 | 2012-03-24 | 1117FF-3d | 2012-03-09 | 2012-03-19 | 0d? | 136d |  |
| 1117 | 1.4.12.9 | Resin Floor | 15d | 2012-03-12 | 2012-03-27 | 1239FF+7d | 2012-03-07 | 2012-03-22 | 0d? | 126d | 0d |
| 1118 | 1.4.12.10 | Fire Door Installation | 7d | 2012-03-23 | 2012-03-30 | 1117FF+3d | 2012-03-18 | 2012-03-25 | 0d? | 130d |  |
| 1119 | 1.4.12.11 | Painting | 15d | 2012-03-25 | 2012-04-09 | 1117FF+7d, 1106FS+21d | 2012-03-20 | 2012-04-04 | 0d? | 120d |  |

| ID | WBS | Task | Duration | Start | Finish | Predecessors | Baseline start | Baseline finish | Baseline duration | Total slack | Free slack |
| --- | --- | --- | --- | --- | --- | --- | --- | --- | --- | --- | --- |
| 1120 | 1.4.13 | **9TH FLOOR** | 53d | 2012-02-29 | 2012-04-22 |  | 2012-02-24 | 2012-04-17 | 53d | 107d |  |
| 1121 | 1.4.13.1 | De-shuttering Roof Slab | 3d | 2012-02-29 | 2012-03-03 | 751FS+21d | 2012-02-24 | 2012-02-27 | 0d? | 107d | 0d |
| 1122 | 1.4.13.2 | Brick Work | 7d | 2012-03-03 | 2012-03-10 | 1121 | 2012-02-27 | 2012-03-05 | 0d? | 107d | 0d |
| 1123 | 1.4.13.3 | Plaster | 7d | 2012-03-10 | 2012-03-17 | 1122FF+7d | 2012-03-05 | 2012-03-12 | 0d? | 107d | 0d |
| 1124 | 1.4.13.4 | **Toilet Cubicals** | 11d | 2012-03-17 | 2012-03-28 |  | 2012-03-12 | 2012-03-23 | 0d? | 132d |  |
| 1125 | 1.4.13.4.1 | Water/ Sewarage Pipe Lines | 3d | 2012-03-17 | 2012-03-20 | 1123 | 2012-03-12 | 2012-03-15 | 0d? | 132d | 0d |
| 1126 | 1.4.13.4.2 | Water Proofing Works | 1d | 2012-03-20 | 2012-03-21 | 1125 | 2012-03-15 | 2012-03-16 | 0d? | 132d | 0d |
| 1127 | 1.4.13.4.3 | Tile Works/ Marble Top | 3d | 2012-03-21 | 2012-03-24 | 1126 | 2012-03-16 | 2012-03-19 | 0d? | 132d | 0d |
| 1128 | 1.4.13.4.4 | Cubicals Install | 3d | 2012-03-24 | 2012-03-27 | 1127 | 2012-03-19 | 2012-03-22 | 0d? | 132d | 0d |
| 1129 | 1.4.13.4.5 | Fitting & Fixtures | 1d | 2012-03-27 | 2012-03-28 | 1128 | 2012-03-22 | 2012-03-23 | 0d? | 132d |  |
| 1130 | 1.4.13.5 | False Ceiling Works | 15d | 2012-04-02 | 2012-04-17 | 1240 | 2012-03-28 | 2012-04-12 | 0d? | 112d |  |
| 1131 | 1.4.13.6 | Sone/Wood/Glazing in Wall | 14d | 2012-03-11 | 2012-03-25 | 1134SF | 2012-03-06 | 2012-03-21 | 0d? | 135d |  |
| 1132 | 1.4.13.7 | Stair/Other Railing | 15d | 2012-03-10 | 2012-03-25 | 1134SF | 2012-03-05 | 2012-03-21 | 0d? | 135d |  |
| 1133 | 1.4.13.8 | Granite Flooring | 10d | 2012-03-27 | 2012-04-06 | 1134FF-3d | 2012-03-22 | 2012-04-01 | 0d? | 123d |  |
| 1134 | 1.4.13.9 | Resin Floor | 15d | 2012-03-25 | 2012-04-09 | 1240FF+7d | 2012-03-20 | 2012-04-04 | 0d? | 113d | 0d |
| 1135 | 1.4.13.10 | Fire Door Installation | 7d | 2012-04-05 | 2012-04-12 | 1134FF+3d | 2012-03-31 | 2012-04-07 | 0d? | 117d |  |
| 1136 | 1.4.13.11 | Painting | 15d | 2012-04-07 | 2012-04-22 | 1134FF+7d, 1123FS+21d | 2012-04-02 | 2012-04-17 | 0d? | 107d |  |
| 1137 | 1.4.14 | **10TH FLOOR** | 53d | 2012-03-25 | 2012-05-17 |  | 2012-03-20 | 2012-05-12 | 53d | 82d |  |
| 1138 | 1.4.14.1 | De-shuttering Roof Slab | 3d | 2012-03-25 | 2012-03-28 | 790FS+21d | 2012-03-20 | 2012-03-23 | 0d? | 82d | 0d |
| 1139 | 1.4.14.2 | Brick Work | 7d | 2012-03-28 | 2012-04-04 | 1138 | 2012-03-23 | 2012-03-30 | 0d? | 82d | 0d |
| 1140 | 1.4.14.3 | Plaster | 7d | 2012-04-04 | 2012-04-11 | 1139FF+7d | 2012-03-30 | 2012-04-06 | 0d? | 82d | 0d |
| 1141 | 1.4.14.4 | **Toilet Cubicals** | 11d | 2012-04-11 | 2012-04-22 |  | 2012-04-06 | 2012-04-17 | 0d? | 107d |  |
| 1142 | 1.4.14.4.1 | Water/ Sewarage Pipe Lines | 3d | 2012-04-11 | 2012-04-14 | 1140 | 2012-04-06 | 2012-04-09 | 0d? | 107d | 0d |
| 1143 | 1.4.14.4.2 | Water Proofing Works | 1d | 2012-04-14 | 2012-04-15 | 1142 | 2012-04-09 | 2012-04-10 | 0d? | 107d | 0d |
| 1144 | 1.4.14.4.3 | Tile Works/ Marble Top | 3d | 2012-04-15 | 2012-04-18 | 1143 | 2012-04-10 | 2012-04-13 | 0d? | 107d | 0d |
| 1145 | 1.4.14.4.4 | Cubicals Install | 3d | 2012-04-18 | 2012-04-21 | 1144 | 2012-04-13 | 2012-04-16 | 0d? | 107d | 0d |
| 1146 | 1.4.14.4.5 | Fitting & Fixtures | 1d | 2012-04-21 | 2012-04-22 | 1145 | 2012-04-16 | 2012-04-17 | 0d? | 107d |  |
| 1147 | 1.4.14.5 | False Ceiling Works | 15d | 2012-04-27 | 2012-05-12 | 1241 | 2012-04-22 | 2012-05-07 | 0d? | 87d |  |
| 1148 | 1.4.14.6 | Sone/Wood/Glazing in Wall | 14d | 2012-04-05 | 2012-04-19 | 1151SF | 2012-03-31 | 2012-04-15 | 0d? | 110d |  |
| 1149 | 1.4.14.7 | Stair/Other Railing | 15d | 2012-04-04 | 2012-04-19 | 1151SF | 2012-03-30 | 2012-04-15 | 0d? | 110d |  |
| 1150 | 1.4.14.8 | Granite Flooring | 10d | 2012-04-21 | 2012-05-01 | 1151FF-3d | 2012-04-16 | 2012-04-26 | 0d? | 98d |  |
| 1151 | 1.4.14.9 | Resin Floor | 15d | 2012-04-19 | 2012-05-04 | 1241FF+7d | 2012-04-14 | 2012-04-29 | 0d? | 88d | 0d |
| 1152 | 1.4.14.10 | Fire Door Installation | 7d | 2012-04-30 | 2012-05-07 | 1151FF+3d | 2012-04-25 | 2012-05-02 | 0d? | 92d |  |
| 1153 | 1.4.14.11 | Painting | 15d | 2012-05-02 | 2012-05-17 | 1151FF+7d, 1140FS+21d | 2012-04-27 | 2012-05-12 | 0d? | 82d |  |

| ID | WBS | Task | Duration | Start | Finish | Predecessors | Baseline start | Baseline finish | Baseline duration | Total slack | Free slack |
| --- | --- | --- | --- | --- | --- | --- | --- | --- | --- | --- | --- |
| 1154 | 1.4.15 | **11TH FLOOR** | 53d | 2012-04-19 | 2012-06-11 |  | 2012-04-14 | 2012-06-06 | 53d | 57d |  |
| 1155 | 1.4.15.1 | De-shuttering Roof Slab | 3d | 2012-04-19 | 2012-04-22 | 829FS+21d | 2012-04-14 | 2012-04-17 | 0d? | 57d | 0d |
| 1156 | 1.4.15.2 | Brick Work | 7d | 2012-04-22 | 2012-04-29 | 1155 | 2012-04-17 | 2012-04-24 | 0d? | 57d | 0d |
| 1157 | 1.4.15.3 | Plaster | 7d | 2012-04-29 | 2012-05-06 | 1156FF+7d | 2012-04-24 | 2012-05-01 | 0d? | 57d | 0d |
| 1158 | 1.4.15.4 | **Toilet Cubicals** | 11d | 2012-05-06 | 2012-05-17 |  | 2012-05-01 | 2012-05-12 | 0d? | 82d |  |
| 1159 | 1.4.15.4.1 | Water/ Sewarage Pipe Lines | 3d | 2012-05-06 | 2012-05-09 | 1157 | 2012-05-01 | 2012-05-04 | 0d? | 82d | 0d |
| 1160 | 1.4.15.4.2 | Water Proofing Works | 1d | 2012-05-09 | 2012-05-10 | 1159 | 2012-05-04 | 2012-05-05 | 0d? | 82d | 0d |
| 1161 | 1.4.15.4.3 | Tile Works/ Marble Top | 3d | 2012-05-10 | 2012-05-13 | 1160 | 2012-05-05 | 2012-05-08 | 0d? | 82d | 0d |
| 1162 | 1.4.15.4.4 | Cubicals Install | 3d | 2012-05-13 | 2012-05-16 | 1161 | 2012-05-08 | 2012-05-11 | 0d? | 82d | 0d |
| 1163 | 1.4.15.4.5 | Fitting & Fixtures | 1d | 2012-05-16 | 2012-05-17 | 1162 | 2012-05-11 | 2012-05-12 | 0d? | 82d |  |
| 1164 | 1.4.15.5 | False Ceiling Works | 15d | 2012-05-22 | 2012-06-06 | 1242 | 2012-05-17 | 2012-06-01 | 0d? | 62d |  |
| 1165 | 1.4.15.6 | Sone/Wood/Glazing in Wall | 14d | 2012-04-30 | 2012-05-14 | 1168SF | 2012-04-25 | 2012-05-10 | 0d? | 85d |  |
| 1166 | 1.4.15.7 | Stair/Other Railing | 15d | 2012-04-29 | 2012-05-14 | 1168SF | 2012-04-24 | 2012-05-10 | 0d? | 85d |  |
| 1167 | 1.4.15.8 | Granite Flooring | 10d | 2012-05-16 | 2012-05-26 | 1168FF-3d | 2012-05-11 | 2012-05-21 | 0d? | 73d |  |
| 1168 | 1.4.15.9 | Resin Floor | 15d | 2012-05-14 | 2012-05-29 | 1242FF+7d | 2012-05-09 | 2012-05-24 | 0d? | 63d | 0d |
| 1169 | 1.4.15.10 | Fire Door Installation | 7d | 2012-05-25 | 2012-06-01 | 1168FF+3d | 2012-05-20 | 2012-05-27 | 0d? | 67d |  |
| 1170 | 1.4.15.11 | Painting | 15d | 2012-05-27 | 2012-06-11 | 1168FF+7d, 1157FS+21d | 2012-05-22 | 2012-06-06 | 0d? | 57d |  |
| 1171 | 1.4.16 | **12TH FLOOR** | 53d | 2012-05-14 | 2012-07-06 |  | 2012-05-09 | 2012-07-01 | 53d | 32d |  |
| 1172 | 1.4.16.1 | De-shuttering Roof Slab | 3d | 2012-05-14 | 2012-05-17 | 868FS+21d | 2012-05-09 | 2012-05-12 | 0d? | 32d | 0d |
| 1173 | 1.4.16.2 | Brick Work | 7d | 2012-05-17 | 2012-05-24 | 1172 | 2012-05-12 | 2012-05-19 | 0d? | 32d | 0d |
| 1174 | 1.4.16.3 | Plaster | 7d | 2012-05-24 | 2012-05-31 | 1173FF+7d | 2012-05-19 | 2012-05-26 | 0d? | 32d | 0d |
| 1175 | 1.4.16.4 | **Toilet Cubicals** | 11d | 2012-05-31 | 2012-06-11 |  | 2012-05-26 | 2012-06-06 | 0d? | 57d |  |
| 1176 | 1.4.16.4.1 | Water/ Sewarage Pipe Lines | 3d | 2012-05-31 | 2012-06-03 | 1174 | 2012-05-26 | 2012-05-29 | 0d? | 57d | 0d |
| 1177 | 1.4.16.4.2 | Water Proofing Works | 1d | 2012-06-03 | 2012-06-04 | 1176 | 2012-05-29 | 2012-05-30 | 0d? | 57d | 0d |
| 1178 | 1.4.16.4.3 | Tile Works/ Marble Top | 3d | 2012-06-04 | 2012-06-07 | 1177 | 2012-05-30 | 2012-06-02 | 0d? | 57d | 0d |
| 1179 | 1.4.16.4.4 | Cubicals Install | 3d | 2012-06-07 | 2012-06-10 | 1178 | 2012-06-02 | 2012-06-05 | 0d? | 57d | 0d |
| 1180 | 1.4.16.4.5 | Fitting & Fixtures | 1d | 2012-06-10 | 2012-06-11 | 1179 | 2012-06-05 | 2012-06-06 | 0d? | 57d |  |
| 1181 | 1.4.16.5 | False Ceiling Works | 15d | 2012-06-16 | 2012-07-01 | 1243 | 2012-06-11 | 2012-06-26 | 0d? | 37d |  |
| 1182 | 1.4.16.6 | Sone/Wood/Glazing in Wall | 14d | 2012-05-25 | 2012-06-08 | 1185SF | 2012-05-20 | 2012-06-04 | 0d? | 60d |  |
| 1183 | 1.4.16.7 | Stair/Other Railing | 15d | 2012-05-24 | 2012-06-08 | 1185SF | 2012-05-19 | 2012-06-04 | 0d? | 60d |  |
| 1184 | 1.4.16.8 | Granite Flooring | 10d | 2012-06-10 | 2012-06-20 | 1185FF-3d | 2012-06-05 | 2012-06-15 | 0d? | 48d |  |
| 1185 | 1.4.16.9 | Resin Floor | 15d | 2012-06-08 | 2012-06-23 | 1243FF+7d | 2012-06-03 | 2012-06-18 | 0d? | 38d | 0d |
| 1186 | 1.4.16.10 | Fire Door Installation | 7d | 2012-06-19 | 2012-06-26 | 1185FF+3d | 2012-06-14 | 2012-06-21 | 0d? | 42d |  |
| 1187 | 1.4.16.11 | Painting | 15d | 2012-06-21 | 2012-07-06 | 1185FF+7d, 1174FS+21d | 2012-06-16 | 2012-07-01 | 0d? | 32d |  |

| ID | WBS | Task | Duration | Start | Finish | Predecessors | Baseline start | Baseline finish | Baseline duration | Total slack | Free slack |
| --- | --- | --- | --- | --- | --- | --- | --- | --- | --- | --- | --- |
| 1188 | 1.4.17 | **13TH FLOOR** | 48d | 2012-06-08 | 2012-07-26 |  | 2012-06-03 | 2012-07-21 | 48d | 12d |  |
| 1189 | 1.4.17.1 | De-shuttering Roof Slab | 3d | 2012-06-08 | 2012-06-11 | 907FS+21d | 2012-06-03 | 2012-06-06 | 0d? | 12d | 0d |
| 1190 | 1.4.17.2 | Brick Work | 7d | 2012-06-11 | 2012-06-18 | 1189 | 2012-06-06 | 2012-06-13 | 0d? | 22d | 0d |
| 1191 | 1.4.17.3 | Plaster | 7d | 2012-06-18 | 2012-06-25 | 1190FF+7d | 2012-06-13 | 2012-06-20 | 0d? | 22d | 0d |
| 1192 | 1.4.17.4 | **Toilet Cubicals** | 11d | 2012-06-25 | 2012-07-06 |  | 2012-06-20 | 2012-07-01 | 0d? | 32d |  |
| 1193 | 1.4.17.4.1 | Water/ Sewarage Pipe Lines | 3d | 2012-06-25 | 2012-06-28 | 1191 | 2012-06-20 | 2012-06-23 | 0d? | 32d | 0d |
| 1194 | 1.4.17.4.2 | Water Proofing Works | 1d | 2012-06-28 | 2012-06-29 | 1193 | 2012-06-23 | 2012-06-24 | 0d? | 32d | 0d |
| 1195 | 1.4.17.4.3 | Tile Works/ Marble Top | 3d | 2012-06-29 | 2012-07-02 | 1194 | 2012-06-24 | 2012-06-27 | 0d? | 32d | 0d |
| 1196 | 1.4.17.4.4 | Cubicals Install | 3d | 2012-07-02 | 2012-07-05 | 1195 | 2012-06-27 | 2012-06-30 | 0d? | 32d | 0d |
| 1197 | 1.4.17.4.5 | Fitting & Fixtures | 1d | 2012-07-05 | 2012-07-06 | 1196 | 2012-06-30 | 2012-07-01 | 0d? | 32d |  |
| 1198 | 1.4.17.5 | False Ceiling Works | 15d | 2012-07-11 | 2012-07-26 | 1244 | 2012-07-06 | 2012-07-21 | 0d? | 12d |  |
| 1199 | 1.4.17.6 | Sone/Wood/Glazing in Wall | 14d | 2012-06-19 | 2012-07-03 | 1202SF | 2012-06-14 | 2012-06-29 | 0d? | 35d |  |
| 1200 | 1.4.17.7 | Stair/Other Railing | 15d | 2012-06-18 | 2012-07-03 | 1202SF | 2012-06-13 | 2012-06-29 | 0d? | 35d |  |
| 1201 | 1.4.17.8 | Granite Flooring | 10d | 2012-07-05 | 2012-07-15 | 1202FF-3d | 2012-06-30 | 2012-07-10 | 0d? | 23d |  |
| 1202 | 1.4.17.9 | Resin Floor | 15d | 2012-07-03 | 2012-07-18 | 1244FF+7d | 2012-06-28 | 2012-07-13 | 0d? | 13d | 0d |
| 1203 | 1.4.17.10 | Fire Door Installation | 7d | 2012-07-14 | 2012-07-21 | 1202FF+3d | 2012-07-09 | 2012-07-16 | 0d? | 17d |  |
| 1204 | 1.4.17.11 | Painting | 15d | 2012-07-10 | 2012-07-25 | 1202FF+7d, 1191FF+21d | 2012-07-05 | 2012-07-20 | 0d? | 13d |  |
| 1205 | 1.4.18 | **MACHINE FLOOR** | 40d | 2012-06-28 | 2012-08-07 |  | 2012-06-23 | 2012-08-02 | 40d | 0d |  |
| 1206 | 1.4.18.1 | Brick Work | 7d | 2012-06-28 | 2012-07-05 | 930FS+21d | 2012-06-23 | 2012-06-30 | 0d? | 0d |  |
| 1207 | 1.4.18.2 | Plaster | 5d | 2012-07-05 | 2012-07-10 | 1206 | 2012-06-30 | 2012-07-05 | 0d? | 0d |  |
| 1208 | 1.4.18.3 | Painting | 7d | 2012-07-31 | 2012-08-07 | 1245FF+7d, 1207FS+21d | 2012-07-26 | 2012-08-02 | 0d? | 0d |  |
| 1209 | 1.4.18.4 | **Sweeming Pool** | 31d | 2012-06-28 | 2012-07-29 |  | 2012-06-23 | 2012-07-24 | 0d? | 9d |  |
| 1210 | 1.4.18.4.1 | Deshuttering | 1d | 2012-06-28 | 2012-06-29 | 1206SS | 2012-06-23 | 2012-06-24 | 0d? | 9d | 0d |
| 1211 | 1.4.18.4.2 | Making Steps | 3d | 2012-06-29 | 2012-07-02 | 1210 | 2012-06-24 | 2012-06-27 | 0d? | 9d | 0d |
| 1212 | 1.4.18.4.3 | Water Proofing | 10d | 2012-07-02 | 2012-07-12 | 1211 | 2012-06-27 | 2012-07-07 | 0d? | 9d | 0d |
| 1213 | 1.4.18.4.4 | Lean Concrete | 1d | 2012-07-12 | 2012-07-13 | 1212 | 2012-07-07 | 2012-07-08 | 0d? | 9d | 0d |
| 1214 | 1.4.18.4.5 | Granaite Plaster | 3d | 2012-07-13 | 2012-07-16 | 1213 | 2012-07-08 | 2012-07-11 | 0d? | 9d | 0d |
| 1215 | 1.4.18.4.6 | Tile Work | 10d | 2012-07-16 | 2012-07-26 | 1214 | 2012-07-11 | 2012-07-21 | 0d? | 9d | 0d |
| 1216 | 1.4.18.4.7 | MEP Fittings | 3d | 2012-07-26 | 2012-07-29 | 1215 | 2012-07-21 | 2012-07-24 | 0d? | 9d |  |

| ID | WBS | Task | Duration | Start | Finish | Predecessors | Baseline start | Baseline finish | Baseline duration | Total slack | Free slack |
| --- | --- | --- | --- | --- | --- | --- | --- | --- | --- | --- | --- |
| 1217 | 1.4.18.5 | **Planter Box** | 24d | 2012-07-10 | 2012-08-03 |  | 2012-07-05 | 2012-07-29 | 0d? | 4d |  |
| 1218 | 1.4.18.5.1 | Water Proofing | 10d | 2012-07-10 | 2012-07-20 | 1207 | 2012-07-05 | 2012-07-15 | 0d? | 4d | 0d |
| 1219 | 1.4.18.5.2 | Making Bed For Plantation | 7d | 2012-07-20 | 2012-07-27 | 1218 | 2012-07-15 | 2012-07-22 | 0d? | 4d | 0d |
| 1220 | 1.4.18.5.3 | Plantation | 7d | 2012-07-27 | 2012-08-03 | 1219 | 2012-07-22 | 2012-07-29 | 0d? | 4d |  |
| 1221 | 1.4.18.6 | **Open Terrace** | 20d | 2012-07-10 | 2012-07-30 |  | 2012-07-05 | 2012-07-25 | 0d? | 8d |  |
| 1222 | 1.4.18.6.1 | Water Proofing | 10d | 2012-07-10 | 2012-07-20 | 1207 | 2012-07-05 | 2012-07-15 | 0d? | 8d | 0d |
| 1223 | 1.4.18.6.2 | Paver Fixing | 10d | 2012-07-20 | 2012-07-30 | 1222 | 2012-07-15 | 2012-07-25 | 0d? | 8d |  |
| 1224 | 1.4.19 | **TOP ROOF SLAB** | 20d | 2012-07-10 | 2012-07-30 |  | 2012-07-05 | 2012-07-25 | 20d | 8d |  |
| 1225 | 1.4.19.1 | Water proofing | 10d | 2012-07-10 | 2012-07-20 | 1207, 1252 | 2012-07-05 | 2012-07-15 | 0d? | 8d | 0d |
| 1226 | 1.4.19.2 | Paver Fixing | 10d | 2012-07-20 | 2012-07-30 | 1225 | 2012-07-15 | 2012-07-25 | 0d? | 8d |  |
| 1227 | 1.5 | **MEP WORKS** | 493d | 2011-03-04 | 2012-07-25 |  | 2011-04-18 | 2012-07-20 | 443d | 30d |  |
| 1228 | 1.5.1 | BASEMENT-3 | 60d | 2011-03-04 | 2011-05-03 | 943 | 2011-04-18 | 2011-06-17 | 0d? | 432d | 0d |
| 1229 | 1.5.2 | BASEMENT-2 | 60d | 2011-04-13 | 2011-06-12 | 951 | 2011-05-12 | 2011-07-11 | 0d? | 392d | 0d |
| 1230 | 1.5.3 | BASEMENT-1 | 60d | 2011-06-11 | 2011-08-10 | 959 | 2011-06-06 | 2011-08-05 | 0d? | 333d | 0d |
| 1231 | 1.5.4 | GROUND FLOOR | 30d | 2011-07-20 | 2011-08-19 | 969 | 2011-07-15 | 2011-08-14 | 0d? | 323d | 0d |
| 1232 | 1.5.5 | 1ST FLOOR | 30d | 2011-07-31 | 2011-09-07 | 985 | 2011-07-26 | 2011-08-25 | 0d? | 312d | 0d |
| 1233 | 1.5.6 | 2ND FLOOR | 30d | 2011-08-25 | 2011-10-02 | 1002 | 2011-08-20 | 2011-09-27 | 0d? | 287d | 0d |
| 1234 | 1.5.7 | 3RD FLOOR | 30d | 2011-09-27 | 2011-10-27 | 1019 | 2011-09-22 | 2011-10-22 | 0d? | 262d | 0d |
| 1235 | 1.5.8 | 4TH FLOOR | 30d | 2011-10-22 | 2011-11-29 | 1036 | 2011-10-17 | 2011-11-24 | 0d? | 237d | 0d |
| 1236 | 1.5.9 | 5TH FLOOR | 30d | 2011-11-24 | 2011-12-24 | 1053 | 2011-11-19 | 2011-12-19 | 0d? | 212d | 0d |
| 1237 | 1.5.10 | 6TH FLOOR | 30d | 2011-12-19 | 2012-01-18 | 1070 | 2011-12-14 | 2012-01-13 | 0d? | 187d | 0d |
| 1238 | 1.5.11 | 7TH FLOOR | 30d | 2012-01-13 | 2012-02-12 | 1087 | 2012-01-08 | 2012-02-07 | 0d? | 162d | 0d |
| 1239 | 1.5.12 | 8TH FLOOR | 30d | 2012-02-19 | 2012-03-20 | 1104 | 2012-02-14 | 2012-03-15 | 0d? | 125d | 0d |
| 1240 | 1.5.13 | 9TH FLOOR | 30d | 2012-03-03 | 2012-04-02 | 1121 | 2012-02-27 | 2012-03-28 | 0d? | 112d | 0d |
| 1241 | 1.5.14 | 10 TH FLOOR | 30d | 2012-03-28 | 2012-04-27 | 1138 | 2012-03-23 | 2012-04-22 | 0d? | 87d | 0d |
| 1242 | 1.5.15 | 11TH FLOOR | 30d | 2012-04-22 | 2012-05-22 | 1155 | 2012-04-17 | 2012-05-17 | 0d? | 62d | 0d |
| 1243 | 1.5.16 | 12TH FLOOR | 30d | 2012-05-17 | 2012-06-16 | 1172 | 2012-05-12 | 2012-06-11 | 0d? | 37d | 0d |
| 1244 | 1.5.17 | 13TH FLOOR | 30d | 2012-06-11 | 2012-07-11 | 1189 | 2012-06-06 | 2012-07-06 | 0d? | 12d | 0d |
| 1245 | 1.5.18 | MACHINE FLOOR | 60d | 2012-05-26 | 2012-07-25 | 1207FF+15d | 2012-05-21 | 2012-07-20 | 0d? | 6d | 0d |
| 1246 | 1.5.19 | MEP WORKS - OUTSIDE | 60d | 2012-05-26 | 2012-07-25 | 1245FF | 2012-05-21 | 2012-07-20 | 0d? | 30d |  |

| ID | WBS | Task | Duration | Start | Finish | Predecessors | Baseline start | Baseline finish | Baseline duration | Total slack | Free slack |
| --- | --- | --- | --- | --- | --- | --- | --- | --- | --- | --- | --- |
| 1247 | 1.6 | **OUTSIDE FINISHING** | 67d | 2012-06-06 | 2012-08-12 |  | 2012-06-01 | 2012-08-07 | 67d | 28d |  |
| 1248 | 1.6.1 | PLASTER REPAIR | 15d | 2012-06-06 | 2012-06-21 | 929 | 2012-06-01 | 2012-06-16 | 15d | 28d | 0d |
| 1249 | 1.6.2 | CURTAIN WALL | 45d | 2012-06-21 | 2012-08-05 | 1248 | 2012-06-16 | 2012-07-31 | 45d | 28d | 0d |
| 1250 | 1.6.3 | TITANIUM | 15d | 2012-06-21 | 2012-07-06 | 1248 | 2012-06-16 | 2012-07-01 | 15d | 65d |  |
| 1251 | 1.6.4 | LOUVER FIXING | 7d | 2012-08-05 | 2012-08-12 | 1249 | 2012-07-31 | 2012-08-07 | 7d | 28d |  |
| 1252 | 1.7 | CLOSING SLAB AFTER TC DISMANTLING | 30d | 2012-06-09 | 2012-07-09 | 48 | 2012-06-04 | 2012-07-04 | 30d | 9d | 1d |
| 1253 | 1.8 | LAND SCAPING | 60d | 2012-07-10 | 2012-09-18 | 1246FF+15d, 47FF+15d | 2012-07-05 | 2012-09-11 | 60d | 0d |  |
| 1254 | 1.9 | PROJECT COMPLETE | 1d | 2012-09-18 | 2012-09-19 | 1253 | 2012-09-11 | 2012-09-12 | 1d | 0d |  |
